# عمليات اجرايي پروژه 320 واحدي شهريار

Schedule from MS Project, 2008-05-09 to 2010-11-11, status date 2009-11-21.
Hewlett-Packard

## Calendars

- Standard: Mon-Sun 08:00-12:00, 13:00-17:00.

## Schedule

| ID | WBS | Task | Duration | Start | Finish | Predecessors | Total slack | Free slack | Plan Start | Plan Finish | Text1 | Text2 | واحد |
| --- | --- | --- | --- | --- | --- | --- | --- | --- | --- | --- | --- | --- | --- |
| 1 | 1 | **بلوك 1** | 900d | 2008-05-09 | 2010-11-11 |  | 0d |  | 87/2/20 | 89/8/20 |  |  |  |
| 2 | 1.1 | **طراحي پروژه** | 70d | 2008-05-09 | 2008-07-17 |  | 0d |  | 87/2/20 | 87/4/27 |  |  |  |
| 3 | 1.1.1 | طراحي فاز 1 و تاييد شهرداري | 35d | 2008-05-09 | 2008-06-12 |  | 0d |  | 87/2/20 | 87/3/23 |  |  |  |
| 4 | 1.1.2 | طراحي كامل (فاز 2) و تاييد شهرداري | 35d | 2008-06-13 | 2008-07-17 | 3 | 0d |  | 87/3/24 | 87/4/27 |  |  |  |
| 5 | 1.2 | اخذ پروانه | 5d | 2008-07-18 | 2008-07-22 | 4 | 0d |  | 87/4/28 | 87/5/1 |  |  |  |
| 6 | 1.3 | **آزمايشگاه مكانيك خاك و نقشه برداري** | 10d | 2008-07-23 | 2008-08-01 |  | 4d |  | 87/5/2 | 87/5/11 |  |  |  |
| 7 | 1.3.1 | آزمايشگاه مكانيك خاك | 5d | 2008-07-23 | 2008-07-27 | 5 | 820d |  | 87/5/2 | 87/5/6 |  |  |  |
| 8 | 1.3.2 | نقشه برداري | 10d | 2008-07-23 | 2008-08-01 | 5 | 4d |  | 87/5/2 | 87/5/11 |  |  |  |
| 9 | 1.4 | **انشعابات** | 14d | 2008-07-23 | 2008-08-05 |  | 0d |  | 87/5/2 | 87/5/15 |  |  |  |
| 10 | 1.4.1 | انشعاب آب و فاضلاب | 14d | 2008-07-23 | 2008-08-05 | 5 | 0d |  | 87/5/2 | 87/5/15 |  |  |  |
| 11 | 1.4.2 | انشعاب برق | 14d | 2008-07-23 | 2008-08-05 | 5 | 0d |  | 87/5/2 | 87/5/15 |  |  |  |
| 12 | 1.4.3 | انشعاب گاز | 14d | 2008-07-23 | 2008-08-05 | 5 | 0d |  | 87/5/2 | 87/5/15 |  |  |  |
| 13 | 1.4.4 | انشعاب تلفن | 14d | 2008-07-23 | 2008-08-05 | 5 | 0d |  | 87/5/2 | 87/5/15 |  |  |  |
| 14 | 1.5 | تجهيز كارگاه | 14d | 2008-07-23 | 2008-08-05 | 5 | 0d |  | 87/5/2 | 87/5/15 | 86/11/16 | 86/12/25 | درصد |
| 15 | 1.6 | **خاكبرداري** | 15d | 2008-08-06 | 2008-08-20 |  | 0d |  | 87/5/16 | 87/5/30 | 86/12/26 | 87/02/05 | درصد |
| 16 | 1.6.1 | خاکبرداري با ماشين | 15d | 2008-08-06 | 2008-08-20 | 8, 14, 9 | 0d |  | 87/5/16 | 87/5/30 | 86/12/26 | 87/01/16 | مترمکعب |
| 17 | 1.6.2 | خاكبرداري دستي و رگلاژ | 15d | 2008-08-06 | 2008-08-20 | 16FF | 0d |  | 87/5/16 | 87/5/30 | 87/01/17 | 87/02/05 |  |
| 18 | 1.7 | **اجراي فونداسيون** | 21d | 2008-08-21 | 2008-09-10 |  | 0d |  | 87/5/31 | 87/6/20 | 87/03/05 | 87/04/08 | درصد |
| 19 | 1.7.1 | بتن مگر | 5d | 2008-08-21 | 2008-08-25 | 15 | 0d |  | 87/5/31 | 87/6/4 | 87/03/06 | 87/03/10 | مترمکعب |
| 20 | 1.7.2 | آرماتور بندي فونداسيون | 10d | 2008-08-26 | 2008-09-04 | 19 | 0d |  | 87/6/5 | 87/6/14 | 87/03/11 | 87/03/20 | تن |
| 21 | 1.7.3 | قالب بندي فونداسيون | 10d | 2008-08-27 | 2008-09-05 | 20SS+1d | 0d |  | 87/6/6 | 87/6/15 | 87/03/07 | 87/03/21 | مترمربع |
| 22 | 1.7.4 | بتن ريزي فونداسيون | 5d | 2008-09-06 | 2008-09-10 | 21 | 0d |  | 87/6/16 | 87/6/20 | 87/03/22 | 87/04/08 | مترمکعب |
| 23 | 1.8 | **اجراي اسكلت سازه** | 412d | 2008-09-13 | 2009-11-07 |  | 0d |  | 87/6/23 | 88/8/16 |  |  | درصد |
| 24 | 1.8.1 | **آرماتوربندي ستونها و ديوارها** | 401d | 2008-09-13 | 2009-10-27 |  | 0d |  | 87/6/23 | 88/8/5 |  |  |  |
| 25 | 1.8.1.1 | آرماتور بندي ستونها و ديوارهاي زيرزمين دوم | 5d | 2008-09-13 | 2008-09-17 | 18FS+2d | 0d |  | 87/6/23 | 87/6/27 |  |  | تن |
| 26 | 1.8.1.2 | آرماتور بندي ستونها و ديوارهاي زيرزمين اول | 5d | 2008-10-16 | 2008-10-20 | 152 | 54d | 0d | 87/7/25 | 87/7/29 | 87/04/09 | 87/04/18 | تن |
| 27 | 1.8.1.3 | آرماتور بندي ستونها و ديوارهاي همكف | 5d | 2008-11-18 | 2008-11-22 | 153 | 54d | 0d | 87/8/28 | 87/9/2 | 87/05/11 | 87/05/20 | تن |
| 28 | 1.8.1.4 | آرماتور بندي ستونها و ديوارهاي طبقه اول | 5d | 2008-12-21 | 2008-12-25 | 154 | 61d | 0d | 87/10/1 | 87/10/5 | 87/06/13 | 87/06/22 | تن |
| 29 | 1.8.1.5 | آرماتور بندي ستونها و ديوارهاي طبقه دوم | 5d | 2009-01-23 | 2009-01-27 | 155 | 68d | 0d | 87/11/4 | 87/11/8 | 87/07/15 | 87/07/24 | تن |
| 30 | 1.8.1.6 | آرماتور بندي ستونها و ديوارهاي طبقه سوم | 5d | 2009-02-25 | 2009-03-01 | 156 | 75d | 0d | 87/12/7 | 87/12/11 | 87/08/18 | 87/08/27 | تن |
| 31 | 1.8.1.7 | آرماتور بندي ستونها وديوارهاي طبقه چهارم | 5d | 2009-04-08 | 2009-04-12 | 157 | 82d | 0d | 88/1/19 | 88/1/23 | 87/09/21 | 87/09/30 | تن |
| 32 | 1.8.1.8 | آرماتور بندي ستونها و ديوارهاي طبقه پنجم | 5d | 2009-05-11 | 2009-05-15 | 158 | 88d | 0d | 88/2/21 | 88/2/25 | 87/10/24 | 87/11/03 | تن |
| 33 | 1.8.1.9 | آرماتور بندي ستونها و ديوارهاي طبقه ششم | 5d | 2009-06-13 | 2009-06-17 | 159 | 88d | 0d | 88/3/23 | 88/3/27 | 87/11/27 | 87/12/06 | تن |
| 34 | 1.8.1.10 | آرماتور بندي ستونها و ديوارهاي طبقه هفتم | 5d | 2009-07-16 | 2009-07-20 | 160 | 93d | 0d | 88/4/25 | 88/4/29 | 87/12/30 | 88/01/09 | تن |
| 35 | 1.8.1.11 | آرماتور بندي ستونها و ديوارهاي طبقه هشتم | 5d | 2009-08-18 | 2009-08-22 | 161 | 100d | 0d | 88/5/27 | 88/5/31 | 88/02/02 | 88/02/11 | تن |
| 36 | 1.8.1.12 | آرماتور بندي ستونها و ديوارهاي طبقه نهم | 5d | 2009-09-20 | 2009-09-24 | 162 | 107d | 0d | 88/6/29 | 88/7/2 | 88/02/31 | 88/03/09 | تن |
| 37 | 1.8.1.13 | آرماتور بندي ستونها و ديوارهاي طبقه دهم و خرپشته | 5d | 2009-10-23 | 2009-10-27 | 163 | 114d | 0d | 88/8/1 | 88/8/5 | 88/04/02 | 88/04/11 | تن |

| ID | WBS | Task | Duration | Start | Finish | Predecessors | Total slack | Free slack | Plan Start | Plan Finish | واحد | Text1 | Text2 |
| --- | --- | --- | --- | --- | --- | --- | --- | --- | --- | --- | --- | --- | --- |
| 38 | 1.8.2 | **قالب بندي ستونها و ديوارها** | 401d | 2008-09-14 | 2009-10-28 |  | 0d |  | 87/6/24 | 88/8/6 |  |  |  |
| 39 | 1.8.2.1 | قالب بندي ستونها و ديوارهاي زيرزمين دوم | 5d | 2008-09-14 | 2008-09-18 | 25SS+1d | 0d |  | 87/6/24 | 87/6/28 | مترمربع |  |  |
| 40 | 1.8.2.2 | قالب بندي ستونها و ديوارها ي زيرزمين اول | 5d | 2008-10-17 | 2008-10-21 | 26SS+1d | 54d | 0d | 87/7/26 | 87/7/30 | مترمربع | 87/04/10 | 87/04/19 |
| 41 | 1.8.2.3 | قالب بندي ستونها و ديوارهاي همكف | 5d | 2008-11-19 | 2008-11-23 | 27SS+1d | 54d | 0d | 87/8/29 | 87/9/3 | مترمربع | 87/05/12 | 87/05/21 |
| 42 | 1.8.2.4 | قالب بندي ستونها و ديوارهاي طبقه اول | 5d | 2008-12-22 | 2008-12-26 | 28SS+1d | 61d | 0d | 87/10/2 | 87/10/6 | مترمربع | 87/06/14 | 87/06/23 |
| 43 | 1.8.2.5 | قالب بندي ستونها و ديوارهاي طبقه دوم | 5d | 2009-01-24 | 2009-01-28 | 29SS+1d | 68d | 0d | 87/11/5 | 87/11/9 | مترمربع | 87/07/16 | 87/07/25 |
| 44 | 1.8.2.6 | قالب بندي ستونها و ديوارهاي طبقه سوم | 5d | 2009-02-26 | 2009-03-02 | 30SS+1d | 75d | 0d | 87/12/8 | 87/12/12 | مترمربع | 87/08/19 | 87/08/28 |
| 45 | 1.8.2.7 | قالب بندي ستونها و ديوارهاي طبقه چهارم | 5d | 2009-04-09 | 2009-04-13 | 31SS+1d | 82d | 0d | 88/1/20 | 88/1/24 | مترمربع | 87/09/22 | 87/10/01 |
| 46 | 1.8.2.8 | قالب بندي ستونها و ديوارهاي طبقه پنجم | 5d | 2009-05-12 | 2009-05-16 | 32SS+1d | 88d | 0d | 88/2/22 | 88/2/26 | مترمربع | 87/10/25 | 87/11/04 |
| 47 | 1.8.2.9 | قالب بندي ستونها و ديوارهاي طبقه ششم | 5d | 2009-06-14 | 2009-06-18 | 33SS+1d | 88d | 0d | 88/3/24 | 88/3/28 | مترمربع | 87/11/28 | 87/12/07 |
| 48 | 1.8.2.10 | قالب بندي ستونها و ديوارهاي طبقه هفتم | 5d | 2009-07-17 | 2009-07-21 | 34SS+1d | 93d | 0d | 88/4/26 | 88/4/30 | مترمربع | 88/01/01 | 88/01/10 |
| 49 | 1.8.2.11 | قالب بندي ستونها و ديوارهاي طبقه هشتم | 5d | 2009-08-19 | 2009-08-23 | 35SS+1d | 100d | 0d | 88/5/28 | 88/6/1 | مترمربع | 88/02/03 | 88/02/12 |
| 50 | 1.8.2.12 | قالب بندي ستونها و ديوارهاي طبقه نهم | 5d | 2009-09-21 | 2009-09-25 | 36SS+1d | 107d | 0d | 88/6/30 | 88/7/3 | مترمربع | 88/03/01 | 88/03/10 |
| 51 | 1.8.2.13 | قالب بندي ستونها و ديوارهاي طبقه دهم و خرپشته | 5d | 2009-10-24 | 2009-10-28 | 37SS+1d | 114d | 0d | 88/8/2 | 88/8/6 | مترمربع | 88/04/03 | 88/04/12 |
| 52 | 1.8.3 | **بتن ريزي ستونها و ديوارها** | 398d | 2008-09-19 | 2009-10-30 |  | 0d |  | 87/6/29 | 88/8/8 |  |  |  |
| 53 | 1.8.3.1 | بتن ريزي ستونها و ديوارهاي زيرزمين دوم | 2d | 2008-09-19 | 2008-09-20 | 39 | 0d |  | 87/6/29 | 87/6/30 | مترمکعب |  |  |
| 54 | 1.8.3.2 | بتن ريزي ستونها و ديوارهاي زيرزمين اول | 2d | 2008-10-22 | 2008-10-23 | 40 | 54d | 0d | 87/8/1 | 87/8/2 | مترمکعب | 87/04/19 | 87/04/28 |
| 55 | 1.8.3.3 | بتن ريزي ستونها و ديوارهاي همكف | 2d | 2008-11-24 | 2008-11-25 | 41 | 54d | 0d | 87/9/4 | 87/9/5 | مترمکعب | 87/05/21 | 87/05/30 |
| 56 | 1.8.3.4 | بتن ريزي ستونها و ديوارهاي طبقه اول | 2d | 2008-12-27 | 2008-12-28 | 42 | 61d | 0d | 87/10/7 | 87/10/8 | مترمکعب | 87/06/23 | 87/07/01 |
| 57 | 1.8.3.5 | بتن ريزي ستونها و ديوارهاي طبقه دوم | 2d | 2009-01-29 | 2009-01-30 | 43 | 68d | 0d | 87/11/10 | 87/11/11 | مترمکعب | 87/07/24 | 87/07/25 |
| 58 | 1.8.3.6 | بتن ريزي ستونها و ديوارهاي طبقه سوم | 2d | 2009-03-03 | 2009-03-04 | 44 | 75d | 0d | 87/12/13 | 87/12/14 | مترمکعب | 87/08/27 | 87/08/28 |
| 59 | 1.8.3.7 | بتن ريزي ستونها و ديوارهاي طبقه چهارم | 2d | 2009-04-14 | 2009-04-15 | 45 | 82d | 0d | 88/1/25 | 88/1/26 | مترمکعب | 87/09/30 | 87/10/01 |
| 60 | 1.8.3.8 | بتن ريزي ستونها و ديوارهاي طبقه پنجم | 2d | 2009-05-17 | 2009-05-18 | 46 | 88d | 0d | 88/2/27 | 88/2/28 | مترمکعب | 87/11/03 | 87/11/04 |
| 61 | 1.8.3.9 | بتن ريزي ستونها و ديوارهاي طبقه ششم | 2d | 2009-06-19 | 2009-06-20 | 47 | 88d | 0d | 88/3/29 | 88/3/30 | مترمکعب | 87/12/06 | 87/12/07 |
| 62 | 1.8.3.10 | بتن ريزي ستونها و ديوارهاي طبقه هفتم | 2d | 2009-07-22 | 2009-07-23 | 48 | 93d | 0d | 88/4/31 | 88/5/1 | مترمکعب | 88/01/09 | 88/01/10 |
| 63 | 1.8.3.11 | بتن ريزي ستونها و ديوارهاي طبقه هشتم | 2d | 2009-08-24 | 2009-08-25 | 49 | 100d | 0d | 88/6/2 | 88/6/3 | مترمکعب | 88/02/11 | 88/02/12 |
| 64 | 1.8.3.12 | بتن ريزي ستونها و ديوارهاي طبقه نهم | 2d | 2009-09-26 | 2009-09-27 | 50 | 107d | 0d | 88/7/4 | 88/7/5 | مترمکعب | 88/03/09 | 88/03/10 |
| 65 | 1.8.3.13 | بتن ريزي ستونها و ديوارهاي طبقه دهم | 2d | 2009-10-29 | 2009-10-30 | 51 | 114d | 0d | 88/8/7 | 88/8/8 | مترمکعب | 88/04/11 | 88/04/12 |

| ID | WBS | Task | Duration | Start | Finish | Predecessors | Total slack | Free slack | Plan Start | Plan Finish | واحد | Text1 | Text2 |
| --- | --- | --- | --- | --- | --- | --- | --- | --- | --- | --- | --- | --- | --- |
| 66 | 1.8.4 | **آرماتوربندي تيرها** | 401d | 2008-09-21 | 2009-11-04 |  | 0d |  | 87/6/31 | 88/8/13 |  |  |  |
| 67 | 1.8.4.1 | آرماتوربندي تيرهاي زيرزمين دوم | 5d | 2008-09-21 | 2008-09-25 | 53 | 0d |  | 87/6/31 | 87/7/4 | تن |  |  |
| 68 | 1.8.4.2 | آرماتوربندي تيرهاي زيرزمين اول | 5d | 2008-10-24 | 2008-10-28 | 54 | 54d | 0d | 87/8/3 | 87/8/7 | تن |  |  |
| 69 | 1.8.4.3 | آرماتوربندي تيرهاي همكف | 5d | 2008-11-26 | 2008-11-30 | 55 | 54d | 0d | 87/9/6 | 87/9/10 | تن |  |  |
| 70 | 1.8.4.4 | آرماتوربندي تيرهاي طبقه اول | 5d | 2008-12-29 | 2009-01-02 | 56 | 61d | 0d | 87/10/9 | 87/10/13 | تن |  |  |
| 71 | 1.8.4.5 | آرماتوربندي تيرهاي طبقه دوم | 5d | 2009-01-31 | 2009-02-04 | 57 | 68d | 0d | 87/11/12 | 87/11/16 | تن | 87/07/25 | 87/08/04 |
| 72 | 1.8.4.6 | آرماتوربندي تيرها ي طبقه سوم | 5d | 2009-03-05 | 2009-03-09 | 58 | 75d | 0d | 87/12/15 | 87/12/19 | تن | 87/08/28 | 87/09/07 |
| 73 | 1.8.4.7 | آرماتوربندي تيرهاي طبقه چهارم | 5d | 2009-04-16 | 2009-04-20 | 59 | 82d | 0d | 88/1/27 | 88/1/31 | تن | 87/10/01 | 87/10/10 |
| 74 | 1.8.4.8 | آرماتوربندي تيرهاي طبقه پنجم | 5d | 2009-05-19 | 2009-05-23 | 60 | 88d | 0d | 88/2/29 | 88/3/2 | تن | 87/11/04 | 87/11/13 |
| 75 | 1.8.4.9 | آرماتوربندي تيرهاي طبقه ششم | 5d | 2009-06-21 | 2009-06-25 | 61 | 88d | 0d | 88/3/31 | 88/4/4 | تن | 87/12/07 | 87/12/16 |
| 76 | 1.8.4.10 | آرماتوربندي تيرهاي طبقه هفتم | 5d | 2009-07-24 | 2009-07-28 | 62 | 93d | 0d | 88/5/2 | 88/5/6 | تن | 88/01/10 | 88/01/19 |
| 77 | 1.8.4.11 | آرماتوربندي تيرهاي طبقه هشتم | 5d | 2009-08-26 | 2009-08-30 | 63 | 100d | 0d | 88/6/4 | 88/6/8 | تن | 88/02/12 | 88/02/21 |
| 78 | 1.8.4.12 | آرماتوربندي تيرهاي طبقه نهم | 5d | 2009-09-28 | 2009-10-02 | 64 | 107d | 0d | 88/7/6 | 88/7/10 | تن | 88/03/10 | 88/03/19 |
| 79 | 1.8.4.13 | آرماتوربندي تيرهاي طبقه دهم و خرپشته | 5d | 2009-10-31 | 2009-11-04 | 65 | 114d | 0d | 88/8/9 | 88/8/13 | تن | 88/04/12 | 88/04/21 |
| 80 | 1.8.5 | **قالب بندي تيرها** | 401d | 2008-09-22 | 2009-11-05 |  | 0d |  | 87/7/1 | 88/8/14 |  |  |  |
| 81 | 1.8.5.1 | قالب بندي تيرها زيرزمين دوم | 5d | 2008-09-22 | 2008-09-26 | 67SS+1d | 0d |  | 87/7/1 | 87/7/5 | مترمربع |  |  |
| 82 | 1.8.5.2 | قالب بندي تيرهاي زيرزمين اول | 5d | 2008-10-25 | 2008-10-29 | 68SS+1d | 54d | 0d | 87/8/4 | 87/8/8 | مترمربع |  |  |
| 83 | 1.8.5.3 | قالب بندي تيرهاي همكف | 5d | 2008-11-27 | 2008-12-01 | 69SS+1d | 54d | 0d | 87/9/7 | 87/9/11 | مترمربع |  |  |
| 84 | 1.8.5.4 | قالب بندي تيرهاي طبقه اول | 5d | 2008-12-30 | 2009-01-03 | 70SS+1d | 61d | 0d | 87/10/10 | 87/10/14 | مترمربع |  |  |
| 85 | 1.8.5.5 | قالب بندي تيرهاي طبقه دوم | 5d | 2009-02-01 | 2009-02-05 | 71SS+1d | 68d | 0d | 87/11/13 | 87/11/17 | مترمربع | 87/07/26 | 87/07/30 |
| 86 | 1.8.5.6 | قالب بندي تيرهاي طبقه سوم | 5d | 2009-03-06 | 2009-03-10 | 72SS+1d | 75d | 0d | 87/12/16 | 87/12/20 | مترمربع |  |  |
| 87 | 1.8.5.7 | قالب بندي تيرهاي طبقه چهارم | 5d | 2009-04-17 | 2009-04-21 | 73SS+1d | 82d | 0d | 88/1/28 | 88/2/1 | مترمربع | 87/10/02 | 87/10/06 |
| 88 | 1.8.5.8 | قالب بندي تيرهاي طبقه پنجم | 5d | 2009-05-20 | 2009-05-24 | 74SS+1d | 88d | 0d | 88/2/30 | 88/3/3 | مترمربع | 87/11/05 | 87/11/09 |
| 89 | 1.8.5.9 | قالب بندي تيرهاي طبقه ششم | 5d | 2009-06-22 | 2009-06-26 | 75SS+1d | 88d | 0d | 88/4/1 | 88/4/5 | مترمربع | 87/12/08 | 87/12/12 |
| 90 | 1.8.5.10 | قالب بندي تيرهاي طبقه هفتم | 5d | 2009-07-25 | 2009-07-29 | 76SS+1d | 93d | 0d | 88/5/3 | 88/5/7 | مترمربع | 88/01/11 | 88/01/15 |
| 91 | 1.8.5.11 | قالب بندي تيرهاي طبقه هشتم | 5d | 2009-08-27 | 2009-08-31 | 77SS+1d | 100d | 0d | 88/6/5 | 88/6/9 | مترمربع | 88/02/13 | 88/02/17 |
| 92 | 1.8.5.12 | قالب بندي تيرهاي طبقه نهم | 5d | 2009-09-29 | 2009-10-03 | 78SS+1d | 107d | 0d | 88/7/7 | 88/7/11 | مترمربع | 88/03/11 | 88/03/15 |
| 93 | 1.8.5.13 | قالب بندي تيرهاي طبقه دهم و خرپشته | 5d | 2009-11-01 | 2009-11-05 | 79SS+1d | 114d | 0d | 88/8/10 | 88/8/14 | مترمربع | 88/04/13 | 88/04/17 |

| ID | WBS | Task | Duration | Start | Finish | Predecessors | Total slack | Free slack | Plan Start | Plan Finish | واحد | Text1 | Text2 |
| --- | --- | --- | --- | --- | --- | --- | --- | --- | --- | --- | --- | --- | --- |
| 94 | 1.8.6 | **بتن ريزي تيرها** | 398d | 2008-09-27 | 2009-11-07 |  | 0d |  | 87/7/6 | 88/8/16 |  |  |  |
| 95 | 1.8.6.1 | بتن ريزي تيرهاي زيرزمين دوم | 2d | 2008-09-27 | 2008-09-28 | 81 | 0d |  | 87/7/6 | 87/7/7 | مترمکعب |  |  |
| 96 | 1.8.6.2 | بتن ريزي تيرهاي زيرزمين اول | 2d | 2008-10-30 | 2008-10-31 | 82 | 54d | 0d | 87/8/9 | 87/8/10 | مترمکعب |  |  |
| 97 | 1.8.6.3 | بتن ريزي تيرهاي همكف | 2d | 2008-12-02 | 2008-12-03 | 83 | 54d | 0d | 87/9/12 | 87/9/13 | مترمکعب |  |  |
| 98 | 1.8.6.4 | بتن ريزي تيرها طبقه اول | 2d | 2009-01-04 | 2009-01-05 | 84 | 61d | 0d | 87/10/15 | 87/10/16 | مترمکعب |  |  |
| 99 | 1.8.6.5 | بتن ريزي تيرهاي طبقه دوم | 2d | 2009-02-06 | 2009-02-07 | 85 | 68d | 0d | 87/11/18 | 87/11/19 | مترمکعب |  |  |
| 100 | 1.8.6.6 | بتن ريزي تيرهاي طبقه سوم | 2d | 2009-03-11 | 2009-03-12 | 86 | 75d | 0d | 87/12/21 | 87/12/22 | مترمکعب |  |  |
| 101 | 1.8.6.7 | بتن ريزي تيرهاي طبقه چهارم | 2d | 2009-04-22 | 2009-04-23 | 87 | 82d | 0d | 88/2/2 | 88/2/3 | مترمکعب |  |  |
| 102 | 1.8.6.8 | بتن ريزي تيرهاي طبقه پنجم | 2d | 2009-05-25 | 2009-05-26 | 88 | 88d | 0d | 88/3/4 | 88/3/5 | مترمکعب |  |  |
| 103 | 1.8.6.9 | بتن ريزي تيرهاي طبقه ششم | 2d | 2009-06-27 | 2009-06-28 | 89 | 88d | 0d | 88/4/6 | 88/4/7 | مترمکعب |  |  |
| 104 | 1.8.6.10 | بتن ريزي تيرهاي طبقه هفتم | 2d | 2009-07-30 | 2009-07-31 | 90 | 93d | 0d | 88/5/8 | 88/5/9 | مترمکعب |  |  |
| 105 | 1.8.6.11 | بتن ريزي تيرهاي طبقه هشتم | 2d | 2009-09-01 | 2009-09-02 | 91 | 100d | 0d | 88/6/10 | 88/6/11 | مترمکعب |  |  |
| 106 | 1.8.6.12 | بتن ريزي تيرهاي طبقه نهم | 2d | 2009-10-04 | 2009-10-05 | 92 | 107d | 0d | 88/7/12 | 88/7/13 | مترمکعب |  |  |
| 107 | 1.8.6.13 | بتن ريزي تيرهاي طبقه دهم و خرپشته | 2d | 2009-11-06 | 2009-11-07 | 93 | 114d | 0d | 88/8/15 | 88/8/16 | مترمکعب |  |  |
| 108 | 1.9 | **اجراي سقف سازه** | 406d | 2008-10-06 | 2009-11-24 |  | 0d |  | 87/7/15 | 88/9/3 | درصد |  |  |
| 109 | 1.9.1 | **ساخت تيرچه و تيرچه گذاري** | 399d | 2008-10-06 | 2009-11-17 |  | 0d |  | 87/7/15 | 88/8/26 |  |  |  |
| 110 | 1.9.1.1 | ساخت تيرچه و تيرچه گذاري زيرزمين دوم | 3d | 2008-10-06 | 2008-10-08 | 95FS+7d | 0d |  | 87/7/15 | 87/7/17 |  |  |  |
| 111 | 1.9.1.2 | ساخت تيرچه و تيرچه گذاري زيرزمين اول | 3d | 2008-11-08 | 2008-11-10 | 96FS+7d | 54d | 0d | 87/8/18 | 87/8/20 |  | 87/04/25 | 87/05/03 |
| 112 | 1.9.1.3 | ساخت تيرچه و تيرچه گذاري همكف | 3d | 2008-12-11 | 2008-12-13 | 97FS+7d | 54d | 0d | 87/9/21 | 87/9/23 |  | 87/05/27 | 87/06/05 |
| 113 | 1.9.1.4 | ساخت تيرچه و تيرچه گذاري طبقه اول | 3d | 2009-01-13 | 2009-01-15 | 98FS+7d | 61d | 0d | 87/10/24 | 87/10/26 |  | 87/06/29 | 87/07/07 |
| 114 | 1.9.1.5 | ساخت تيرچه و تيرچه گذاري طبقه دوم | 3d | 2009-02-15 | 2009-02-17 | 99FS+7d | 68d | 0d | 87/11/27 | 87/11/29 |  | 87/08/01 | 87/08/10 |
| 115 | 1.9.1.6 | ساخت تيرچه و تيرچه گذاري طبقه سوم | 3d | 2009-03-29 | 2009-03-31 | 100FS+7d | 75d | 0d | 88/1/9 | 88/1/11 |  | 87/09/04 | 87/09/13 |
| 116 | 1.9.1.7 | ساخت تيرچه و تيرچه گذاري طبقه چهارم | 3d | 2009-05-01 | 2009-05-03 | 101FS+7d | 82d | 0d | 88/2/11 | 88/2/13 |  | 87/10/07 | 87/10/16 |
| 117 | 1.9.1.8 | ساخت تيرچه و تيرچه گذاري طبقه پنجم | 3d | 2009-06-03 | 2009-06-05 | 102FS+7d | 88d | 0d | 88/3/13 | 88/3/15 |  | 87/11/10 | 87/11/19 |
| 118 | 1.9.1.9 | ساخت تيرچه و تيرچه گذاري طبقه ششم | 3d | 2009-07-06 | 2009-07-08 | 103FS+7d | 88d | 0d | 88/4/15 | 88/4/17 |  | 87/12/13 | 87/12/22 |
| 119 | 1.9.1.10 | ساخت تيرچه و تيرچه گذاري طبقه هفتم | 3d | 2009-08-08 | 2009-08-10 | 104FS+7d | 93d | 0d | 88/5/17 | 88/5/19 |  | 88/01/16 | 88/01/25 |
| 120 | 1.9.1.11 | ساخت تيرچه و تيرچه گذاري طبقه هشتم | 3d | 2009-09-10 | 2009-09-12 | 105FS+7d | 100d | 0d | 88/6/19 | 88/6/21 |  | 88/02/18 | 88/02/27 |
| 121 | 1.9.1.12 | ساخت تيرچه و تيرچه گذاري طبقه نهم | 3d | 2009-10-13 | 2009-10-15 | 106FS+7d | 107d | 0d | 88/7/21 | 88/7/23 |  | 88/03/16 | 88/03/25 |
| 122 | 1.9.1.13 | ساخت تيرچه و تيرچه گذاري طبقه دهم و خرپشته | 3d | 2009-11-15 | 2009-11-17 | 107FS+7d | 114d | 0d | 88/8/24 | 88/8/26 |  | 88/04/18 | 88/04/27 |

| ID | WBS | Task | Duration | Start | Finish | Predecessors | Total slack | Free slack | Plan Start | Plan Finish | واحد | Text1 | Text2 |
| --- | --- | --- | --- | --- | --- | --- | --- | --- | --- | --- | --- | --- | --- |
| 123 | 1.9.2 | **آرماتور بندي سقف و راه پله** | 402d | 2008-10-07 | 2009-11-21 |  | 0d |  | 87/7/16 | 88/8/30 |  |  |  |
| 124 | 1.9.2.1 | آرماتور بندي سقف و راه پله زيرزمين دوم | 6d | 2008-10-07 | 2008-10-12 | 110SS+1d | 0d |  | 87/7/16 | 87/7/21 | تن |  |  |
| 125 | 1.9.2.2 | آرماتور بندي سقف و راه پله زيرزمين اول | 6d | 2008-11-09 | 2008-11-14 | 111SS+1d | 54d | 0d | 87/8/19 | 87/8/24 | تن | 87/04/27 | 87/05/05 |
| 126 | 1.9.2.3 | آرماتور بندي سقف و راه پله همكف | 6d | 2008-12-12 | 2008-12-17 | 112SS+1d | 54d | 0d | 87/9/22 | 87/9/27 | تن | 87/05/29 | 87/06/07 |
| 127 | 1.9.2.4 | آرماتور بندي سقف و راه پله طبقه اول | 6d | 2009-01-14 | 2009-01-19 | 113SS+1d | 61d | 0d | 87/10/25 | 87/10/30 | تن | 87/06/31 | 87/07/09 |
| 128 | 1.9.2.5 | آرماتور بندي سقف و راه پله طبقه دوم | 6d | 2009-02-16 | 2009-02-21 | 114SS+1d | 68d | 0d | 87/11/28 | 87/12/3 | تن | 87/08/03 | 87/08/12 |
| 129 | 1.9.2.6 | آرماتور بندي سقف و راه پله طبقه سوم | 6d | 2009-03-30 | 2009-04-04 | 115SS+1d | 75d | 0d | 88/1/10 | 88/1/15 | تن | 87/09/06 | 87/09/15 |
| 130 | 1.9.2.7 | آرماتور بندي سقف و راه پله طبقه چهارم | 6d | 2009-05-02 | 2009-05-07 | 116SS+1d | 82d | 0d | 88/2/12 | 88/2/17 | تن | 87/10/09 | 87/10/18 |
| 131 | 1.9.2.8 | آرماتور بندي سقف و راه پله طبقه پنجم | 6d | 2009-06-04 | 2009-06-09 | 117SS+1d | 88d | 0d | 88/3/14 | 88/3/19 | تن | 87/11/12 | 87/11/21 |
| 132 | 1.9.2.9 | آرماتور بندي سقف و راه پله طبقه ششم | 6d | 2009-07-07 | 2009-07-12 | 118SS+1d | 88d | 0d | 88/4/16 | 88/4/21 | تن | 87/12/15 | 87/12/24 |
| 133 | 1.9.2.10 | آرماتور بندي سقف و راه پله طبقه هفتم | 6d | 2009-08-09 | 2009-08-14 | 119SS+1d | 93d | 0d | 88/5/18 | 88/5/23 | تن | 88/01/18 | 88/01/27 |
| 134 | 1.9.2.11 | آرماتور بندي سقف و راه پله طبقه هشتم | 6d | 2009-09-11 | 2009-09-16 | 120SS+1d | 100d | 0d | 88/6/20 | 88/6/25 | تن | 88/02/20 | 88/02/29 |
| 135 | 1.9.2.12 | آرماتور بندي سقف و راه پله طبقه نهم | 6d | 2009-10-14 | 2009-10-19 | 121SS+1d | 107d | 0d | 88/7/22 | 88/7/27 | تن | 88/03/18 | 88/03/27 |
| 136 | 1.9.2.13 | آرماتور بندي سقف و راه پله طبقه دهم | 6d | 2009-11-16 | 2009-11-21 | 122SS+1d | 114d | 0d | 88/8/25 | 88/8/30 | تن | 88/04/20 | 88/04/29 |
| 137 | 1.9.3 | **قالب بندي سقف و راه پله** | 401d | 2008-10-08 | 2009-11-21 |  | 0d |  | 87/7/17 | 88/8/30 |  |  |  |
| 138 | 1.9.3.1 | قالب بندي سقف و راه پله زيرزمين دوم | 5d | 2008-10-08 | 2008-10-12 | 124SS+1d | 0d |  | 87/7/17 | 87/7/21 | مترمربع |  |  |
| 139 | 1.9.3.2 | قالب بندي سقف و راه پله زيرزمين اول | 5d | 2008-11-10 | 2008-11-14 | 125SS+1d | 54d | 0d | 87/8/20 | 87/8/24 | مترمربع | 87/05/06 | 87/05/10 |
| 140 | 1.9.3.3 | قالب بندي سقف و راه پله همكف | 5d | 2008-12-13 | 2008-12-17 | 126SS+1d | 54d | 0d | 87/9/23 | 87/9/27 | مترمربع | 87/06/07 | 87/06/07 |
| 141 | 1.9.3.4 | قالب بندي سقف و راه پله طبقه اول | 5d | 2009-01-15 | 2009-01-19 | 127SS+1d | 61d | 0d | 87/10/26 | 87/10/30 | مترمربع | 87/07/09 | 87/07/09 |
| 142 | 1.9.3.5 | قالب بندي سقف و راه پله طبقه دوم | 5d | 2009-02-17 | 2009-02-21 | 128SS+1d | 68d | 0d | 87/11/29 | 87/12/3 | مترمربع | 87/08/12 | 87/08/12 |
| 143 | 1.9.3.6 | قالب بندي سقف و راه پله طبقه سوم | 5d | 2009-03-31 | 2009-04-04 | 129SS+1d | 75d | 0d | 88/1/11 | 88/1/15 | مترمربع | 87/09/15 | 87/09/15 |
| 144 | 1.9.3.7 | قالب بندي سقف و راه پله طبقه چهارم | 5d | 2009-05-03 | 2009-05-07 | 130SS+1d | 82d | 0d | 88/2/13 | 88/2/17 | مترمربع | 87/10/18 | 87/10/18 |
| 145 | 1.9.3.8 | قالب بندي سقف و راه پله طبقه پنجم | 5d | 2009-06-05 | 2009-06-09 | 131SS+1d | 88d | 0d | 88/3/15 | 88/3/19 | مترمربع | 87/11/21 | 87/11/21 |
| 146 | 1.9.3.9 | قالب بندي سقف و راه پله طبقه ششم | 5d | 2009-07-08 | 2009-07-12 | 132SS+1d | 88d | 0d | 88/4/17 | 88/4/21 | مترمربع | 87/12/24 | 87/12/24 |
| 147 | 1.9.3.10 | قالب بندي سقف و راه پله طبقه هفتم | 5d | 2009-08-10 | 2009-08-14 | 133SS+1d | 93d | 0d | 88/5/19 | 88/5/23 | مترمربع | 88/01/27 | 88/01/27 |
| 148 | 1.9.3.11 | قالب بندي سقف و راه پله طبقه هشتم | 5d | 2009-09-12 | 2009-09-16 | 134SS+1d | 100d | 0d | 88/6/21 | 88/6/25 | مترمربع | 88/02/30 | 88/02/30 |
| 149 | 1.9.3.12 | قالب بندي سقف و راه پله طبقه نهم | 5d | 2009-10-15 | 2009-10-19 | 135SS+1d | 107d | 0d | 88/7/23 | 88/7/27 | مترمربع | 88/03/27 | 88/03/27 |
| 150 | 1.9.3.13 | قالب بندي سقف و راه پله طبقه دهم | 5d | 2009-11-17 | 2009-11-21 | 136SS+1d | 114d | 0d | 88/8/26 | 88/8/30 | مترمربع | 88/04/29 | 88/04/29 |

| ID | WBS | Task | Duration | Start | Finish | Predecessors | Total slack | Free slack | Plan Start | Plan Finish | واحد | Text1 | Text2 |
| --- | --- | --- | --- | --- | --- | --- | --- | --- | --- | --- | --- | --- | --- |
| 151 | 1.9.4 | **بتن ريزي سقف و راه پله** | 399d | 2008-10-13 | 2009-11-24 |  | 0d |  | 87/7/22 | 88/9/3 |  |  |  |
| 152 | 1.9.4.1 | بتن ريزي سقف و راه پله زيرزمين دوم | 3d | 2008-10-13 | 2008-10-15 | 138 | 0d |  | 87/7/22 | 87/7/24 | مترمکعب |  |  |
| 153 | 1.9.4.2 | بتن ريزي سقف و راه پله زيرزمين اول | 3d | 2008-11-15 | 2008-11-17 | 139 | 54d | 0d | 87/8/25 | 87/8/27 | مترمکعب |  |  |
| 154 | 1.9.4.3 | بتن ريزي سقف و راه پله همكف | 3d | 2008-12-18 | 2008-12-20 | 140 | 54d | 0d | 87/9/28 | 87/9/30 | مترمکعب | 87/06/08 | 87/06/12 |
| 155 | 1.9.4.4 | بتن ريزي سقف و راه پله طبقه اول | 3d | 2009-01-20 | 2009-01-22 | 141 | 61d | 0d | 87/11/1 | 87/11/3 | مترمکعب | 87/07/10 | 87/07/14 |
| 156 | 1.9.4.5 | بتن ريزي سقف و راه پله طبقه دوم | 3d | 2009-02-22 | 2009-02-24 | 142 | 68d | 0d | 87/12/4 | 87/12/6 | مترمکعب | 87/08/13 | 87/08/17 |
| 157 | 1.9.4.6 | بتن ريزي سقف و راه پله طبقه سوم | 3d | 2009-04-05 | 2009-04-07 | 143 | 75d | 0d | 88/1/16 | 88/1/18 | مترمکعب | 87/09/16 | 87/09/20 |
| 158 | 1.9.4.7 | بتن ريزي سقف و راه پله طبقه چهارم | 3d | 2009-05-08 | 2009-05-10 | 144 | 82d | 0d | 88/2/18 | 88/2/20 | مترمکعب | 87/10/19 | 87/10/23 |
| 159 | 1.9.4.8 | بتن ريزي سقف و راه پله طبقه پنجم | 3d | 2009-06-10 | 2009-06-12 | 145 | 88d | 0d | 88/3/20 | 88/3/22 | مترمکعب | 87/11/22 | 87/11/26 |
| 160 | 1.9.4.9 | بتن ريزي سقف و راه پله طبقه ششم | 3d | 2009-07-13 | 2009-07-15 | 146 | 88d | 0d | 88/4/22 | 88/4/24 | مترمکعب | 87/12/25 | 87/12/29 |
| 161 | 1.9.4.10 | بتن ريزي سقف و راه پله طبقه هفتم | 3d | 2009-08-15 | 2009-08-17 | 147 | 93d | 0d | 88/5/24 | 88/5/26 | مترمکعب | 88/01/28 | 88/02/01 |
| 162 | 1.9.4.11 | بتن ريزي سقف و راه پله طبقه هشتم | 3d | 2009-09-17 | 2009-09-19 | 148 | 100d | 0d | 88/6/26 | 88/6/28 | مترمکعب | 88/02/26 | 88/02/30 |
| 163 | 1.9.4.12 | بتن ريزي سقف و راه پله طبقه نهم | 3d | 2009-10-20 | 2009-10-22 | 149 | 107d | 0d | 88/7/28 | 88/7/30 | مترمکعب | 88/03/28 | 88/04/01 |
| 164 | 1.9.4.13 | بتن ريزي سقف و راه پله طبقه دهم | 3d | 2009-11-22 | 2009-11-24 | 150 | 114d | 0d | 88/9/1 | 88/9/3 | مترمکعب |  |  |
| 165 | 1.10 | **سفت كاري** | 729d | 2008-10-23 | 2010-11-07 |  | 0d |  | 87/8/2 | 89/8/16 | درصد | 87/07/30 | 88/07/04 |
| 166 | 1.10.1 | **نبشي كشي نما** | 333d | 2008-12-28 | 2009-12-04 |  | 240d | 18d | 87/10/8 | 88/9/13 |  |  |  |
| 167 | 1.10.1.1 | نبشي كشي نماي همكف | 3d | 2008-12-28 | 2008-12-30 | 154FS+7d | 570d |  | 87/10/8 | 87/10/10 |  |  |  |
| 168 | 1.10.1.2 | نبشي كشي نماي طبقه اول | 3d | 2009-01-30 | 2009-02-01 | 155FS+7d | 537d |  | 87/11/11 | 87/11/13 |  |  |  |
| 169 | 1.10.1.3 | نبشي كشي نماي طبقه دوم | 3d | 2009-03-04 | 2009-03-06 | 156FS+7d | 504d |  | 87/12/14 | 87/12/16 |  |  |  |
| 170 | 1.10.1.4 | نبشي كشي نماي طبقه سوم | 3d | 2009-04-15 | 2009-04-17 | 157FS+7d | 471d |  | 88/1/26 | 88/1/28 |  |  |  |
| 171 | 1.10.1.5 | نبشي كشي نماي طبقه چهارم | 3d | 2009-05-18 | 2009-05-20 | 158FS+7d | 438d |  | 88/2/28 | 88/2/30 |  |  |  |
| 172 | 1.10.1.6 | نبشي كشي نماي طبقه پنجم | 3d | 2009-06-20 | 2009-06-22 | 159FS+7d | 405d |  | 88/3/30 | 88/4/1 |  |  |  |
| 173 | 1.10.1.7 | نبشي كشي نماي طبقه ششم | 3d | 2009-07-23 | 2009-07-25 | 160FS+7d | 372d |  | 88/5/1 | 88/5/3 |  |  |  |
| 174 | 1.10.1.8 | نبشي كشي نماي طبقه هفتم | 3d | 2009-08-25 | 2009-08-27 | 161FS+7d | 339d |  | 88/6/3 | 88/6/5 |  |  |  |
| 175 | 1.10.1.9 | نبشي كشي نماي طبقه هشتم | 3d | 2009-09-27 | 2009-09-29 | 162FS+7d | 306d |  | 88/7/5 | 88/7/7 |  |  |  |
| 176 | 1.10.1.10 | نبشي كشي نماي طبقه نهم | 3d | 2009-10-30 | 2009-11-01 | 163FS+7d | 273d |  | 88/8/8 | 88/8/10 |  |  |  |
| 177 | 1.10.1.11 | نبشي كشي نماي طبقه دهم و خرپشته | 3d | 2009-12-02 | 2009-12-04 | 164FS+7d | 240d |  | 88/9/11 | 88/9/13 |  |  |  |

| ID | WBS | Task | Duration | Start | Finish | Predecessors | Total slack | Free slack | Text1 | Text2 | واحد | Plan Start | Plan Finish |
| --- | --- | --- | --- | --- | --- | --- | --- | --- | --- | --- | --- | --- | --- |
| 178 | 1.10.2 | **اجراي ديوارهاي طبقات** | 410d | 2008-10-23 | 2009-12-15 |  | 0d |  | 87/11/16 | 88/07/04 | درصد | 87/8/2 | 88/9/24 |
| 179 | 1.10.2.1 | اجراي ديوارهاي طبقه زيرزمين دوم | 14d | 2008-10-23 | 2008-11-05 | 152FS+7d | 0d |  |  |  | مترمربع | 87/8/2 | 87/8/15 |
| 180 | 1.10.2.2 | اجراي ديوارهاي طبقه زيرزمين اول | 14d | 2008-11-25 | 2008-12-08 | 179, 153FS+7d | 57d | 0d | 87/11/16 | 87/12/05 | مترمربع | 87/9/5 | 87/9/18 |
| 181 | 1.10.2.3 | اجراي ديوارهاي طبقه همكف | 14d | 2008-12-28 | 2009-01-10 | 180, 154FS+7d | 54d | 0d | 87/12/06 | 87/12/25 | مترمربع | 87/10/8 | 87/10/21 |
| 182 | 1.10.2.4 | اجراي ديوارهاي طبقه اول | 14d | 2009-01-30 | 2009-02-12 | 181, 155FS+7d | 61d | 0d | 87/12/26 | 88/01/15 | مترمربع | 87/11/11 | 87/11/24 |
| 183 | 1.10.2.5 | اجراي ديوارهاي طبقه دوم | 14d | 2009-03-04 | 2009-03-17 | 182, 156FS+7d | 68d | 0d | 88/01/16 | 88/02/04 | مترمربع | 87/12/14 | 87/12/27 |
| 184 | 1.10.2.6 | اجراي ديوارهاي طبقه سوم | 14d | 2009-04-15 | 2009-04-28 | 183, 157FS+7d | 75d | 0d | 88/02/05 | 88/02/24 | مترمربع | 88/1/26 | 88/2/8 |
| 185 | 1.10.2.7 | اجراي ديوارهاي طبقه چهارم | 14d | 2009-05-18 | 2009-05-31 | 184, 158FS+7d | 82d | 0d | 88/02/25 | 88/03/13 | مترمربع | 88/2/28 | 88/3/10 |
| 186 | 1.10.2.8 | اجراي ديوارهاي طبقه پنجم | 14d | 2009-06-20 | 2009-07-03 | 185, 159FS+7d | 89d | 0d | 88/03/14 | 88/04/02 | مترمربع | 88/3/30 | 88/4/12 |
| 187 | 1.10.2.9 | اجراي ديوارهاي طبقه ششم | 14d | 2009-07-23 | 2009-08-05 | 186, 160FS+7d | 88d | 0d | 88/04/03 | 88/04/22 | مترمربع | 88/5/1 | 88/5/14 |
| 188 | 1.10.2.10 | اجراي ديوارهاي طبقه هفتم | 14d | 2009-08-25 | 2009-09-07 | 187, 161FS+7d | 93d | 0d | 88/04/23 | 88/05/11 | مترمربع | 88/6/3 | 88/6/16 |
| 189 | 1.10.2.11 | اجراي ديوارهاي طبقه هشتم | 14d | 2009-09-27 | 2009-10-10 | 188, 162FS+7d | 100d | 0d | 88/05/12 | 88/05/31 | مترمربع | 88/7/5 | 88/7/18 |
| 190 | 1.10.2.12 | اجراي ديوارهاي طبقه نهم | 14d | 2009-10-30 | 2009-11-12 | 189, 163FS+7d | 107d | 0d | 88/06/01 | 88/06/20 | مترمربع | 88/8/8 | 88/8/21 |
| 191 | 1.10.2.13 | اجراي ديوارهاي طبقه دهم | 14d | 2009-12-02 | 2009-12-15 | 190, 164FS+7d | 114d | 0d | 88/06/21 | 88/07/04 | مترمربع | 88/9/11 | 88/9/24 |
| 192 | 1.10.3 | **ساخت و نصب چهارجوب درب ها و نعل درگاهها** | 400d | 2008-11-03 | 2009-12-16 |  | 322d |  |  |  |  | 87/8/13 | 88/9/25 |
| 193 | 1.10.3.1 | ساخت و نصب چهارجوب درب ها و نعل درگاههاي طبقه زير زمين دوم | 4d | 2008-11-03 | 2008-11-06 | 179FF+1d | 718d |  |  |  |  | 87/8/13 | 87/8/16 |
| 194 | 1.10.3.2 | ساخت و نصب چهارجوب درب ها و نعل درگاههاي طبقه زيرزمين اول | 4d | 2008-12-06 | 2008-12-09 | 180FF+1d | 685d |  |  |  |  | 87/9/16 | 87/9/19 |
| 195 | 1.10.3.3 | ساخت و نصب چهارجوب درب ها و نعل درگاههاي طبقه همكف | 4d | 2009-01-08 | 2009-01-11 | 181FF+1d | 652d |  |  |  |  | 87/10/19 | 87/10/22 |
| 196 | 1.10.3.4 | ساخت و نصب چهارجوب درب ها و نعل درگاههاي طبقه اول | 4d | 2009-02-10 | 2009-02-13 | 182FF+1d | 619d |  |  |  |  | 87/11/22 | 87/11/25 |
| 197 | 1.10.3.5 | ساخت و نصب چهارجوب درب ها و نعل درگاههاي طبقه دوم | 4d | 2009-03-15 | 2009-03-18 | 183FF+1d | 586d |  |  |  |  | 87/12/25 | 87/12/28 |
| 198 | 1.10.3.6 | ساخت و نصب چهارجوب درب ها و نعل درگاههاي طبقه سوم | 4d | 2009-04-26 | 2009-04-29 | 184FF+1d | 553d |  |  |  |  | 88/2/6 | 88/2/9 |
| 199 | 1.10.3.7 | ساخت و نصب چهارجوب درب ها و نعل درگاههاي طبقه چهارم | 4d | 2009-05-29 | 2009-06-01 | 185FF+1d | 520d |  |  |  |  | 88/3/8 | 88/3/11 |
| 200 | 1.10.3.8 | ساخت و نصب چهارجوب درب ها و نعل درگاههاي طبقه پنجم | 4d | 2009-07-01 | 2009-07-04 | 186FF+1d | 487d |  |  |  |  | 88/4/10 | 88/4/13 |
| 201 | 1.10.3.9 | ساخت و نصب چهارجوب درب ها و نعل درگاههاي طبقه ششم | 4d | 2009-08-03 | 2009-08-06 | 187FF+1d | 454d |  |  |  |  | 88/5/12 | 88/5/15 |
| 202 | 1.10.3.10 | ساخت و نصب چهارجوب درب ها و نعل درگاههاي طبقه هفتم | 4d | 2009-09-05 | 2009-09-08 | 188FF+1d | 421d |  |  |  |  | 88/6/14 | 88/6/17 |
| 203 | 1.10.3.11 | ساخت و نصب چهارجوب درب ها و نعل درگاههاي طبقه هشتم | 4d | 2009-10-08 | 2009-10-11 | 189FF+1d | 388d |  |  |  |  | 88/7/16 | 88/7/19 |
| 204 | 1.10.3.12 | ساخت و نصب چهارجوب درب ها و نعل درگاههاي طبقه نهم | 4d | 2009-11-10 | 2009-11-13 | 190FF+1d | 355d |  |  |  |  | 88/8/19 | 88/8/22 |
| 205 | 1.10.3.13 | ساخت و نصب چهارجوب درب ها و نعل درگاههاي طبقه دهم و خرپشته | 4d | 2009-12-13 | 2009-12-16 | 191FF+1d | 322d |  |  |  |  | 88/9/22 | 88/9/25 |

| ID | WBS | Task | Duration | Start | Finish | Predecessors | Total slack | Free slack | Text1 | Text2 | واحد | Plan Start | Plan Finish |
| --- | --- | --- | --- | --- | --- | --- | --- | --- | --- | --- | --- | --- | --- |
| 206 | 1.10.4 | **اجراي گچ و خاك طبقات** | 396d | 2009-01-11 | 2010-02-19 |  | 54d |  | 87/12/06 | 88/08/09 | درصد | 87/10/22 | 88/11/30 |
| 207 | 1.10.4.1 | اجراي گچ و خاك طبقه همكف | 30d | 2009-01-11 | 2009-02-09 | 181, 363 | 54d | 0d | 88/01/06 | 88/01/25 | مترمربع | 87/10/22 | 87/11/21 |
| 208 | 1.10.4.2 | اجراي گچ و خاك طبقه اول | 30d | 2009-02-13 | 2009-03-14 | 182, 207 | 61d | 0d | 88/01/26 | 88/02/14 | مترمربع | 87/11/25 | 87/12/24 |
| 209 | 1.10.4.3 | اجراي گچ و خاك طبقه دوم | 30d | 2009-03-18 | 2009-04-25 | 183, 208 | 68d | 0d | 88/02/15 | 88/03/03 | مترمربع | 87/12/28 | 88/2/5 |
| 210 | 1.10.4.4 | اجراي گچ و خاك طبقه سوم | 30d | 2009-04-29 | 2009-05-28 | 184, 209 | 75d | 0d | 88/03/04 | 88/03/23 | مترمربع | 88/2/9 | 88/3/7 |
| 211 | 1.10.4.5 | اجراي گچ و خاك طبقه چهارم | 30d | 2009-06-01 | 2009-06-30 | 185, 210 | 82d | 0d | 88/03/24 | 88/04/12 | مترمربع | 88/3/11 | 88/4/9 |
| 212 | 1.10.4.6 | اجراي گچ و خاك طبقه پنجم | 30d | 2009-07-04 | 2009-08-02 | 186, 211 | 89d | 0d | 88/04/13 | 88/05/01 | مترمربع | 88/4/13 | 88/5/11 |
| 213 | 1.10.4.7 | اجراي گچ و خاك طبقه ششم | 38d | 2009-08-06 | 2009-09-12 | 187, 212 | 88d | 0d | 88/05/02 | 88/05/21 | مترمربع | 88/5/15 | 88/6/21 |
| 214 | 1.10.4.8 | اجراي گچ و خاك طبقه هفتم | 40d | 2009-09-13 | 2009-10-22 | 188, 213 | 88d | 0d | 88/05/22 | 88/06/10 | مترمربع | 88/6/22 | 88/7/30 |
| 215 | 1.10.4.9 | اجراي گچ و خاك طبقه هشتم | 40d | 2009-10-23 | 2009-12-01 | 189, 214 | 88d | 0d | 88/06/11 | 88/06/30 | مترمربع | 88/8/1 | 88/9/10 |
| 216 | 1.10.4.10 | اجراي گچ و خاك طبقه نهم | 40d | 2009-12-02 | 2010-01-10 | 190, 215 | 88d | 0d | 88/06/31 | 88/07/19 | مترمربع | 88/9/11 | 88/10/20 |
| 217 | 1.10.4.11 | اجراي گچ و خاك طبقه دهم و خرپشته | 40d | 2010-01-11 | 2010-02-19 | 191, 216 | 88d | 0d | 88/07/20 | 88/08/09 | مترمربع | 88/10/21 | 88/11/30 |
| 218 | 1.10.5 | **اجراي سقف كاذب طبقات** | 163d | 2010-05-29 | 2010-11-07 |  | 0d |  | 88/02/15 | 88/09/19 | درصد | 89/3/8 | 89/8/16 |
| 219 | 1.10.5.1 | اجراي سقف كاذب همکف | 20d | 2010-05-29 | 2010-06-17 | 414, 442, 454 | 0d |  | 88/02/15 | 88/03/03 | مترمربع | 89/3/8 | 89/3/27 |
| 220 | 1.10.5.2 | اجراي سقف كاذب طبقه 1 | 20d | 2010-06-05 | 2010-06-24 | 415, 443, 455 | 140d |  | 88/03/04 | 88/03/23 | مترمربع | 89/3/15 | 89/4/3 |
| 221 | 1.10.5.3 | اجراي سقف كاذب طبقه 2 | 20d | 2010-06-17 | 2010-07-06 | 416, 444, 456 | 128d |  | 88/03/24 | 88/04/12 | مترمربع | 89/3/27 | 89/4/15 |
| 222 | 1.10.5.4 | اجراي سقف كاذب طبقه 3 | 20d | 2010-07-02 | 2010-07-21 | 417, 445, 457 | 113d |  | 88/04/13 | 88/05/01 | مترمربع | 89/4/11 | 89/4/30 |
| 223 | 1.10.5.5 | اجراي سقف كاذب طبقه 4 | 20d | 2010-07-17 | 2010-08-05 | 418, 446, 458 | 98d |  | 88/05/02 | 88/05/21 | مترمربع | 89/4/26 | 89/5/14 |
| 224 | 1.10.5.6 | اجراي سقف كاذب طبقه 5 | 20d | 2010-08-01 | 2010-08-20 | 419, 447, 459 | 83d |  | 88/05/22 | 88/06/10 | مترمربع | 89/5/10 | 89/5/29 |
| 225 | 1.10.5.7 | اجراي سقف كاذب طبقه 6 | 20d | 2010-08-16 | 2010-09-04 | 420, 448, 460 | 68d |  | 88/06/11 | 88/06/30 | مترمربع | 89/5/25 | 89/6/13 |
| 226 | 1.10.5.8 | اجراي سقف كاذب طبقه 7 | 20d | 2010-08-31 | 2010-09-19 | 421, 449, 461 | 53d |  | 88/06/31 | 88/07/19 | مترمربع | 89/6/9 | 89/6/28 |
| 227 | 1.10.5.9 | اجراي سقف كاذب طبقه 8 | 20d | 2010-09-15 | 2010-10-04 | 422, 450, 462 | 38d |  | 88/07/20 | 88/08/09 | مترمربع | 89/6/24 | 89/7/12 |
| 228 | 1.10.5.10 | اجراي سقف كاذب طبقه 9 | 20d | 2010-09-30 | 2010-10-19 | 423, 451, 463 | 23d |  | 88/08/10 | 88/08/29 | مترمربع | 89/7/8 | 89/7/27 |
| 229 | 1.10.5.11 | اجراي سقف كاذب طبقه10 | 22d | 2010-10-17 | 2010-11-07 | 424, 452, 464 | 4d |  | 88/08/30 | 88/09/19 | مترمربع | 89/7/25 | 89/8/16 |

| ID | WBS | Task | Duration | Start | Finish | Predecessors | Total slack | Free slack | Text1 | Text2 | واحد | Plan Start | Plan Finish |
| --- | --- | --- | --- | --- | --- | --- | --- | --- | --- | --- | --- | --- | --- |
| 230 | 1.10.6 | **اجراي كف سازي نهائی طبقات** | 222d | 2010-02-14 | 2010-10-01 |  | 0d |  | 87/10/06 | 88/10/24 | درصد | 88/11/25 | 89/7/9 |
| 231 | 1.10.6.1 | اجراي كف سازي طبقه زيرزمين دوم | 20d | 2010-02-14 | 2010-03-05 | 289 | 0d |  | 88/01/16 | 88/02/04 | مترمربع | 88/11/25 | 88/12/14 |
| 232 | 1.10.6.2 | اجراي كف سازي طبقه زيرزمين اول | 20d | 2010-03-01 | 2010-03-28 | 290, 333 | 218d | 0d | 88/01/16 | 88/02/04 | مترمربع | 88/12/10 | 89/1/8 |
| 233 | 1.10.6.3 | اجراي كف سازي طبقه همكف | 20d | 2010-04-04 | 2010-04-23 | 365SS, 291 | 0d |  | 88/03/24 | 88/04/02 | مترمربع | 89/1/15 | 89/2/3 |
| 234 | 1.10.6.4 | اجراي كف سازي طبقه اول | 20d | 2010-04-11 | 2010-04-30 | 366SS, 291 | 44d | 0d | 88/04/13 | 88/04/22 | مترمربع | 89/1/22 | 89/2/10 |
| 235 | 1.10.6.5 | اجراي كف سازي طبقه 2 | 20d | 2010-04-23 | 2010-05-12 | 367SS, 292 | 42d | 0d | 88/05/02 | 88/05/11 | مترمربع | 89/2/3 | 89/2/22 |
| 236 | 1.10.6.6 | اجراي كف سازي طبقه 3 | 20d | 2010-05-08 | 2010-05-27 | 368SS, 293 | 37d | 0d | 88/05/22 | 88/05/31 | مترمربع | 89/2/18 | 89/3/6 |
| 237 | 1.10.6.7 | اجراي كف سازي طبقه 4 | 20d | 2010-05-23 | 2010-06-11 | 369SS, 294 | 32d | 0d | 88/06/11 | 88/06/20 | مترمربع | 89/3/2 | 89/3/21 |
| 238 | 1.10.6.8 | اجراي كف سازي طبقه 5 | 20d | 2010-06-07 | 2010-06-26 | 370SS, 295 | 27d | 0d | 88/06/31 | 88/07/09 | مترمربع | 89/3/17 | 89/4/5 |
| 239 | 1.10.6.9 | اجراي كف سازي طبقه 6 | 20d | 2010-06-22 | 2010-07-11 | 371SS, 296 | 22d | 0d | 88/07/20 | 88/07/29 | مترمربع | 89/4/1 | 89/4/20 |
| 240 | 1.10.6.10 | اجراي كف سازي طبقه 7 | 20d | 2010-07-07 | 2010-07-26 | 372SS, 297 | 17d | 0d | 88/08/10 | 88/08/19 | مترمربع | 89/4/16 | 89/5/4 |
| 241 | 1.10.6.11 | اجراي كف سازي طبقه 8 | 20d | 2010-07-22 | 2010-08-10 | 373SS, 298 | 12d | 0d | 88/08/30 | 88/09/09 | مترمربع | 89/4/31 | 89/5/19 |
| 242 | 1.10.6.12 | اجراي كف سازي طبقه 9 | 20d | 2010-08-06 | 2010-08-25 | 374SS, 299 | 7d | 0d | 88/09/20 | 88/09/29 | مترمربع | 89/5/15 | 89/6/3 |
| 243 | 1.10.6.13 | اجراي كف سازي طبقه 10 و خرپشته | 20d | 2010-08-23 | 2010-09-11 | 375SS, 300 | 0d |  |  |  | مترمربع | 89/6/1 | 89/6/20 |
| 244 | 1.10.6.14 | اجراي كف سازي بام | 20d | 2010-09-12 | 2010-10-01 | 243 | 41d |  | 88/10/10 | 88/10/24 | درصد | 89/6/21 | 89/7/9 |
| 245 | 1.11 | **فاز اول تاسيسات مكانيكي طبقات** | 558d | 2009-01-25 | 2010-08-22 |  | 0d |  | 87/12/06 | 88/08/19 | درصد | 87/11/6 | 89/5/31 |
| 246 | 1.11.1 | **لوله كشي فاضلاب ، آب باران ، ونت** | 511d | 2009-01-25 | 2010-07-06 |  | 0d |  | 87/12/06 | 88/07/29 | درصد | 87/11/6 | 89/4/15 |
| 247 | 1.11.1.1 | لوله كشي زيرزمين دوم | 30d | 2009-01-25 | 2009-02-23 | 362FS+60d | 0d |  |  |  | مترطول | 87/11/6 | 87/12/5 |
| 248 | 1.11.1.2 | لوله كشي زيرزمين اول | 30d | 2009-03-06 | 2009-04-13 | 247FS+10d, 363FS+10d | 0d |  | 87/12/06 | 87/12/25 | مترطول | 87/12/16 | 88/1/24 |
| 249 | 1.11.1.3 | لوله كشي طبقه همكف | 30d | 2009-04-24 | 2009-05-23 | 248FS+10d, 207FS+10d | 0d |  | 87/12/26 | 88/01/15 | مترطول | 88/2/4 | 88/3/2 |
| 250 | 1.11.1.4 | لوله كشي طبقه اول | 30d | 2009-06-03 | 2009-07-02 | 208FS+10d, 249FS+10d | 0d |  | 88/01/16 | 88/02/04 | مترطول | 88/3/13 | 88/4/11 |
| 251 | 1.11.1.5 | لوله كشي طبقه دوم | 30d | 2009-07-13 | 2009-08-11 | 250FS+10d, 209FS+10d | 0d |  | 88/02/05 | 88/02/24 | مترطول | 88/4/22 | 88/5/20 |
| 252 | 1.11.1.6 | لوله كشي طبقه سوم | 30d | 2009-08-22 | 2009-09-20 | 251FS+10d, 210FS+10d | 0d |  | 88/02/25 | 88/03/13 | مترطول | 88/5/31 | 88/6/29 |
| 253 | 1.11.1.7 | لوله كشي طبقه چهارم | 30d | 2009-10-01 | 2009-10-30 | 252FS+10d, 211FS+10d | 0d |  | 88/03/14 | 88/04/02 | مترطول | 88/7/9 | 88/8/8 |
| 254 | 1.11.1.8 | لوله كشي طبقه پنجم | 30d | 2009-11-10 | 2009-12-09 | 253FS+10d, 212FS+10d | 0d |  | 88/04/03 | 88/04/22 | مترطول | 88/8/19 | 88/9/18 |
| 255 | 1.11.1.9 | لوله كشي طبقه ششم | 30d | 2009-12-20 | 2010-01-18 | 254FS+10d, 213FS+10d | 0d |  | 88/04/23 | 88/05/11 | مترطول | 88/9/29 | 88/10/28 |
| 256 | 1.11.1.10 | لوله كشي طبقه هفتم | 30d | 2010-01-29 | 2010-02-27 | 255FS+10d, 214FS+10d | 0d |  | 88/05/12 | 88/05/31 | مترطول | 88/11/9 | 88/12/8 |
| 257 | 1.11.1.11 | لوله كشي طبقه هشتم | 30d | 2010-03-10 | 2010-04-16 | 256FS+10d, 215FS+10d | 0d |  | 88/06/01 | 88/06/20 | مترطول | 88/12/19 | 89/1/27 |
| 258 | 1.11.1.12 | لوله كشي طبقه نهم | 30d | 2010-04-27 | 2010-05-26 | 257FS+10d, 216FS+10d | 0d |  | 88/06/21 | 88/07/09 | مترطول | 89/2/7 | 89/3/5 |
| 259 | 1.11.1.13 | لوله كشي طبقه دهم | 31d | 2010-06-06 | 2010-07-06 | 258FS+10d, 217FS+10d | 0d |  | 88/07/10 | 88/07/29 | درصد | 89/3/16 | 89/4/15 |

| ID | WBS | Task | Duration | Start | Finish | Predecessors | Total slack | Free slack | Text1 | Text2 | واحد | Plan Start | Plan Finish |
| --- | --- | --- | --- | --- | --- | --- | --- | --- | --- | --- | --- | --- | --- |
| 260 | 1.11.2 | **لوله كشي تهويه طبقات** | 516d | 2009-01-30 | 2010-07-16 |  | 118d |  | 87/12/06 | 88/07/29 | درصد | 87/11/11 | 89/4/25 |
| 261 | 1.11.2.1 | لوله كشي تهويه طبقه زيرزمين دوم | 30d | 2009-01-30 | 2009-02-28 | 247SS+5d | 604d |  |  |  | مترطول | 87/11/11 | 87/12/10 |
| 262 | 1.11.2.2 | لوله كشي تهويه طبقه زيرزمين اول | 30d | 2009-03-16 | 2009-04-23 | 248SS+10d | 559d |  | 87/12/06 | 87/12/25 | مترطول | 87/12/26 | 88/2/3 |
| 263 | 1.11.2.3 | لوله كشي تهويه طبقه همكف | 30d | 2009-05-04 | 2009-06-02 | 249SS+10d | 297d |  | 87/12/26 | 88/01/15 | مترطول | 88/2/14 | 88/3/12 |
| 264 | 1.11.2.4 | لوله كشي تهويه طبقه اول | 30d | 2009-06-13 | 2009-07-12 | 250SS+10d | 308d | 264d | 88/01/16 | 88/02/04 | مترطول | 88/3/23 | 88/4/21 |
| 265 | 1.11.2.5 | لوله كشي تهويه طبقه دوم | 30d | 2009-07-23 | 2009-08-21 | 251SS+10d | 278d | 236d | 88/02/05 | 88/02/24 | مترطول | 88/5/1 | 88/5/30 |
| 266 | 1.11.2.6 | لوله كشي تهويه طبقه سوم | 30d | 2009-09-01 | 2009-09-30 | 252SS+10d | 248d | 211d | 88/02/25 | 88/03/13 | مترطول | 88/6/10 | 88/7/8 |
| 267 | 1.11.2.7 | لوله كشي تهويه طبقه چهارم | 30d | 2009-10-11 | 2009-11-09 | 253SS+10d | 218d | 186d | 88/03/14 | 88/04/02 | مترطول | 88/7/19 | 88/8/18 |
| 268 | 1.11.2.8 | لوله كشي تهويه طبقه پنجم | 30d | 2009-11-20 | 2009-12-19 | 254SS+10d | 188d | 161d | 88/04/03 | 88/04/22 | مترطول | 88/8/29 | 88/9/28 |
| 269 | 1.11.2.9 | لوله كشي تهويه طبقه ششم | 30d | 2009-12-30 | 2010-01-28 | 255SS+10d | 158d | 136d | 88/04/23 | 88/05/11 | مترطول | 88/10/9 | 88/11/8 |
| 270 | 1.11.2.10 | لوله كشي تهويه طبقه هفتم | 30d | 2010-02-08 | 2010-03-09 | 256SS+10d | 128d | 111d | 88/05/12 | 88/05/31 | مترطول | 88/11/19 | 88/12/18 |
| 271 | 1.11.2.11 | لوله كشي تهويه طبقه هشتم | 30d | 2010-03-28 | 2010-04-26 | 257SS+10d | 98d | 86d | 88/06/01 | 88/06/20 | مترطول | 89/1/8 | 89/2/6 |
| 272 | 1.11.2.12 | لوله كشي تهويه طبقه نهم | 30d | 2010-05-07 | 2010-06-05 | 258SS+10d | 68d | 61d | 88/06/21 | 88/07/09 | مترطول | 89/2/17 | 89/3/15 |
| 273 | 1.11.2.13 | لوله كشي تهويه طبقه دهم | 31d | 2010-06-16 | 2010-07-16 | 259SS+10d | 37d |  | 88/07/10 | 88/07/29 | درصد | 89/3/26 | 89/4/25 |
| 274 | 1.11.3 | **اجراي لوله كشي آتش نشاني و نصب جعبه ها** | 91d | 2010-03-06 | 2010-06-12 |  | 0d |  | 87/12/06 | 88/07/29 | درصد | 88/12/15 | 89/3/22 |
| 275 | 1.11.3.1 | اجراي لوله آتش نشاني و نصب جعبه هاي زيرزمين دوم | 7d | 2010-03-06 | 2010-03-12 | 231 | 0d |  |  |  | درصد | 88/12/15 | 88/12/21 |
| 276 | 1.11.3.2 | اجراي لوله آتش نشاني و نصب جعبه هاي زيرزمين اول | 7d | 2010-03-13 | 2010-03-27 | 275, 363 | 0d |  | 87/12/06 | 87/12/25 | درصد | 88/12/22 | 89/1/7 |
| 277 | 1.11.3.3 | اجراي لوله آتش نشاني و نصب جعبه هاي طبقه همكف | 7d | 2010-03-28 | 2010-04-03 | 276, 207 | 0d |  | 87/12/26 | 88/01/15 | درصد | 89/1/8 | 89/1/14 |
| 278 | 1.11.3.4 | اجراي لوله آتش نشاني و نصب جعبه هاي طبقه اول | 7d | 2010-04-04 | 2010-04-10 | 277, 208 | 44d | 0d | 88/01/16 | 88/02/04 | درصد | 89/1/15 | 89/1/21 |
| 279 | 1.11.3.5 | اجراي لوله آتش نشاني و نصب جعبه هاي طبقه دوم | 7d | 2010-04-11 | 2010-04-17 | 278, 209 | 47d | 0d | 88/02/05 | 88/02/24 | درصد | 89/1/22 | 89/1/28 |
| 280 | 1.11.3.6 | اجراي لوله آتش نشاني و نصب جعبه هاي طبقه سوم | 7d | 2010-04-18 | 2010-04-24 | 279, 210 | 50d | 0d | 88/02/25 | 88/03/13 | درصد | 89/1/29 | 89/2/4 |
| 281 | 1.11.3.7 | اجراي لوله آتش نشاني و نصب جعبه هاي طبقه جهارم | 7d | 2010-04-25 | 2010-05-01 | 280, 211 | 53d | 0d | 88/03/14 | 88/04/02 | درصد | 89/2/5 | 89/2/11 |
| 282 | 1.11.3.8 | اجراي لوله آتش نشاني و نصب جعبه هاي طبقه پنجم | 7d | 2010-05-02 | 2010-05-08 | 281, 212 | 56d | 0d | 88/04/03 | 88/04/22 | درصد | 89/2/12 | 89/2/18 |
| 283 | 1.11.3.9 | اجراي لوله آتش نشاني و نصب جعبه هاي طبقه ششم | 7d | 2010-05-09 | 2010-05-15 | 282, 213 | 59d | 0d | 88/04/23 | 88/05/11 | درصد | 89/2/19 | 89/2/25 |
| 284 | 1.11.3.10 | اجراي لوله آتش نشاني و نصب جعبه هاي طبقه هفتم | 7d | 2010-05-16 | 2010-05-22 | 283, 214 | 62d | 0d | 88/05/12 | 88/05/31 | درصد | 89/2/26 | 89/3/1 |
| 285 | 1.11.3.11 | اجراي لوله آتش نشاني و نصب جعبه هاي طبقه هشتم | 7d | 2010-05-23 | 2010-05-29 | 284, 215 | 65d | 0d | 88/06/01 | 88/06/20 | درصد | 89/3/2 | 89/3/8 |
| 286 | 1.11.3.12 | اجراي لوله آتش نشاني و نصب جعبه هاي طبقه نهم | 7d | 2010-05-30 | 2010-06-05 | 285, 216 | 68d | 0d | 88/06/21 | 88/07/09 | درصد | 89/3/9 | 89/3/15 |
| 287 | 1.11.3.13 | اجراي لوله آتش نشاني و نصب جعبه هاي طبقه دهم | 7d | 2010-06-06 | 2010-06-12 | 286, 217 | 71d |  | 88/07/10 | 88/07/29 | درصد | 89/3/16 | 89/3/22 |

| ID | WBS | Task | Duration | Start | Finish | Predecessors | Total slack | Text1 | Text2 | واحد | Plan Start | Plan Finish |
| --- | --- | --- | --- | --- | --- | --- | --- | --- | --- | --- | --- | --- |
| 288 | 1.11.4 | **لوله كشي سرد و گرم طبقات** | 197d | 2010-01-30 | 2010-08-22 |  | 0d | 87/12/06 | 88/07/29 | درصد | 88/11/10 | 89/5/31 |
| 289 | 1.11.4.1 | لوله كشي سرد و گرم زيرزمين دوم | 15d | 2010-01-30 | 2010-02-14 | 362, 346, 290SF | 0d |  |  | مترطول | 88/11/10 | 88/11/25 |
| 290 | 1.11.4.2 | لوله كشي سرد و گرم زيرزمين اول | 15d | 2010-02-14 | 2010-03-01 | 363, 347, 291SF | 0d | 87/12/06 | 87/12/25 | مترطول | 88/11/25 | 88/12/10 |
| 291 | 1.11.4.3 | لوله كشي سرد و گرم طبقه همكف | 15d | 2010-03-01 | 2010-03-16 | 207, 348, 292SF | 0d | 87/12/26 | 88/01/15 | مترطول | 88/12/10 | 88/12/25 |
| 292 | 1.11.4.4 | لوله كشي سرد و گرم طبقه اول | 15d | 2010-03-16 | 2010-04-08 | 208, 349, 293SF | 0d | 88/01/16 | 88/02/04 | مترطول | 88/12/25 | 89/1/19 |
| 293 | 1.11.4.5 | لوله كشي سرد و گرم طبقه دوم | 15d | 2010-04-08 | 2010-04-23 | 209, 350, 294SF | 0d | 88/02/05 | 88/02/24 | مترطول | 89/1/19 | 89/2/3 |
| 294 | 1.11.4.6 | لوله كشي سرد و گرم طبقه سوم | 15d | 2010-04-23 | 2010-05-08 | 210, 351, 295SF | 0d | 88/02/25 | 88/03/13 | مترطول | 89/2/3 | 89/2/18 |
| 295 | 1.11.4.7 | لوله كشي سرد و گرم طبقه چهارم | 15d | 2010-05-08 | 2010-05-23 | 211, 352, 296SF | 0d | 88/03/14 | 88/04/02 | مترطول | 89/2/18 | 89/3/2 |
| 296 | 1.11.4.8 | لوله كشي سرد و گرم طبقه پنجم | 15d | 2010-05-23 | 2010-06-07 | 212, 353, 297SF | 0d | 88/04/03 | 88/04/22 | مترطول | 89/3/2 | 89/3/17 |
| 297 | 1.11.4.9 | لوله كشي سرد و گرم طبقه ششم | 15d | 2010-06-07 | 2010-06-22 | 213, 354, 298SF | 0d | 88/04/23 | 88/05/11 | مترطول | 89/3/17 | 89/4/1 |
| 298 | 1.11.4.10 | لوله كشي سرد و گرم طبقه هفتم | 15d | 2010-06-22 | 2010-07-07 | 214, 355, 299SF | 0d | 88/05/12 | 88/05/31 | مترطول | 89/4/1 | 89/4/16 |
| 299 | 1.11.4.11 | لوله كشي سرد و گرم طبقه هشتم | 15d | 2010-07-07 | 2010-07-22 | 215, 356, 300SF | 0d | 88/06/01 | 88/06/20 | مترطول | 89/4/16 | 89/4/31 |
| 300 | 1.11.4.12 | لوله كشي سرد و گرم طبقه نهم | 15d | 2010-07-22 | 2010-08-06 | 216, 357, 301SF | 0d | 88/06/21 | 88/07/09 | مترطول | 89/4/31 | 89/5/15 |
| 301 | 1.11.4.13 | لوله كشي سرد و گرم طبقه دهم | 17d | 2010-08-06 | 2010-08-22 | 217, 358 | 0d | 88/07/10 | 88/07/29 | مترطول | 89/5/15 | 89/5/31 |
| 302 | 1.11.5 | **لوله كشي گرمايش طبقات** | 197d | 2010-01-30 | 2010-08-22 |  | 0d | 87/12/06 | 88/07/29 | درصد | 88/11/10 | 89/5/31 |
| 303 | 1.11.5.1 | لوله كشي گرمايش زيرزمين دوم | 15d | 2010-01-30 | 2010-02-13 | 289SS | 0d |  |  | مترطول | 88/11/10 | 88/11/24 |
| 304 | 1.11.5.2 | لوله كشي گرمايش زيرزمين اول | 15d | 2010-02-14 | 2010-02-28 | 303, 363, 290SS | 0d | 87/12/06 | 87/12/25 | مترطول | 88/11/25 | 88/12/9 |
| 305 | 1.11.5.3 | لوله كشي گرمايش طبقه همكف | 15d | 2010-03-01 | 2010-03-15 | 304, 207, 291SS | 0d | 87/12/26 | 88/01/15 | مترطول | 88/12/10 | 88/12/24 |
| 306 | 1.11.5.4 | لوله كشي گرمايش طبقه اول | 15d | 2010-03-16 | 2010-04-07 | 305, 208, 292SS | 0d | 88/01/16 | 88/02/04 | مترطول | 88/12/25 | 89/1/18 |
| 307 | 1.11.5.5 | لوله كشي گرمايش طبقه دوم | 15d | 2010-04-08 | 2010-04-22 | 306, 209, 293SS | 0d | 88/02/05 | 88/02/24 | مترطول | 89/1/19 | 89/2/2 |
| 308 | 1.11.5.6 | لوله كشي گرمايش طبقه سوم | 15d | 2010-04-23 | 2010-05-07 | 307, 210, 294SS | 0d | 88/02/25 | 88/03/13 | مترطول | 89/2/3 | 89/2/17 |
| 309 | 1.11.5.7 | لوله كشي گرمايش طبقه چهارم | 15d | 2010-05-08 | 2010-05-22 | 308, 211, 295SS | 0d | 88/03/14 | 88/04/02 | مترطول | 89/2/18 | 89/3/1 |
| 310 | 1.11.5.8 | لوله كشي گرمايش طبقه پنجم | 15d | 2010-05-23 | 2010-06-06 | 309, 212, 296SS | 0d | 88/04/03 | 88/04/22 | مترطول | 89/3/2 | 89/3/16 |
| 311 | 1.11.5.9 | لوله كشي گرمايش طبقه ششم | 15d | 2010-06-07 | 2010-06-21 | 310, 213, 297SS | 0d | 88/04/23 | 88/05/11 | مترطول | 89/3/17 | 89/3/31 |
| 312 | 1.11.5.10 | لوله كشي گرمايش طبقه هفتم | 15d | 2010-06-22 | 2010-07-06 | 311, 214, 298SS | 0d | 88/05/12 | 88/05/31 | مترطول | 89/4/1 | 89/4/15 |
| 313 | 1.11.5.11 | لوله كشي گرمايش طبقه هشتم | 15d | 2010-07-07 | 2010-07-21 | 312, 215, 299SS | 0d | 88/06/01 | 88/06/20 | مترطول | 89/4/16 | 89/4/30 |
| 314 | 1.11.5.12 | لوله كشي گرمايش طبقه نهم | 15d | 2010-07-22 | 2010-08-05 | 216, 313, 300SS | 0d | 88/06/21 | 88/07/09 | مترطول | 89/4/31 | 89/5/14 |
| 315 | 1.11.5.13 | لوله كشي گرمايش طبقه دهم | 17d | 2010-08-06 | 2010-08-22 | 217, 314, 301SS | 0d | 88/07/10 | 88/07/29 | مترطول | 89/5/15 | 89/5/31 |

| ID | WBS | Task | Duration | Start | Finish | Predecessors | Total slack | Free slack | Text1 | Text2 | واحد | Plan Start | Plan Finish |
| --- | --- | --- | --- | --- | --- | --- | --- | --- | --- | --- | --- | --- | --- |
| 316 | 1.11.6 | **لوله كشي سرمايش(سيستم اسپليت) طبقات** | 197d | 2010-01-30 | 2010-08-22 |  | 0d |  | 87/12/06 | 88/07/29 | درصد | 88/11/10 | 89/5/31 |
| 317 | 1.11.6.1 | لوله كشي سرمايش(سيستم اسپليت) زيرزمين دوم | 15d | 2010-01-30 | 2010-02-13 | 362, 303SS | 0d |  |  |  | مترطول | 88/11/10 | 88/11/24 |
| 318 | 1.11.6.2 | لوله كشي سرمايش(سيستم اسپليت )زيرزمين اول | 15d | 2010-02-14 | 2010-02-28 | 317, 363 | 0d |  | 87/12/06 | 87/12/25 | مترطول | 88/11/25 | 88/12/9 |
| 319 | 1.11.6.3 | لوله كشي سرمايش(سيستم اسپليت ) طبقه همكف | 15d | 2010-03-01 | 2010-03-15 | 318, 207 | 0d |  | 87/12/26 | 88/01/15 | مترطول | 88/12/10 | 88/12/24 |
| 320 | 1.11.6.4 | لوله كشي سرمايش(سيستم اسپليت )طبقه اول | 15d | 2010-03-16 | 2010-04-07 | 319, 208 | 0d |  | 88/01/16 | 88/02/04 | مترطول | 88/12/25 | 89/1/18 |
| 321 | 1.11.6.5 | لوله كشي سرمايش(سيستم اسپليت ) طبقه دوم | 15d | 2010-04-08 | 2010-04-22 | 320, 209 | 0d |  | 88/02/05 | 88/02/24 | مترطول | 89/1/19 | 89/2/2 |
| 322 | 1.11.6.6 | لوله كشي سرمايش(سيستم اسپليت ) طبقه سوم | 15d | 2010-04-23 | 2010-05-07 | 321, 210 | 0d |  | 88/02/25 | 88/03/13 | مترطول | 89/2/3 | 89/2/17 |
| 323 | 1.11.6.7 | لوله كشي سرمايش(سيستم اسپليت ) طبقه چهارم | 15d | 2010-05-08 | 2010-05-22 | 322, 211 | 0d |  | 88/03/14 | 88/04/02 | مترطول | 89/2/18 | 89/3/1 |
| 324 | 1.11.6.8 | لوله كشي سرمايش(سيستم اسپليت )طبقه پنجم | 15d | 2010-05-23 | 2010-06-06 | 323, 212 | 0d |  | 88/04/03 | 88/04/22 | مترطول | 89/3/2 | 89/3/16 |
| 325 | 1.11.6.9 | لوله كشي سرمايش(سيستم اسپليت ) طبقه ششم | 15d | 2010-06-07 | 2010-06-21 | 324, 213 | 0d |  | 88/04/23 | 88/05/11 | مترطول | 89/3/17 | 89/3/31 |
| 326 | 1.11.6.10 | لوله كشي سرمايش(سيستم اسپليت ) طبقه هفتم | 15d | 2010-06-22 | 2010-07-06 | 325, 214 | 0d |  | 88/05/12 | 88/05/31 | مترطول | 89/4/1 | 89/4/15 |
| 327 | 1.11.6.11 | لوله كشي سرمايش(سيستم اسپليت )طبقه هشتم | 15d | 2010-07-07 | 2010-07-21 | 326, 215 | 0d |  | 88/06/01 | 88/06/20 | مترطول | 89/4/16 | 89/4/30 |
| 328 | 1.11.6.12 | لوله كشي سرمايش(سيستم اسپليت )طبقه نهم | 15d | 2010-07-22 | 2010-08-05 | 327, 216 | 0d |  | 88/06/21 | 88/07/09 | مترطول | 89/4/31 | 89/5/14 |
| 329 | 1.11.6.13 | لوله كشي سرمايش(سيستم اسپليت )طبقه دهم | 17d | 2010-08-06 | 2010-08-22 | 328, 217 | 0d |  | 88/07/10 | 88/07/29 | مترطول | 89/5/15 | 89/5/31 |
| 330 | 1.12 | **فاز اول تاسيسات برقي طبقات** | 601d | 2008-11-26 | 2010-08-05 |  | 17d |  | 87/12/06 | 88/07/29 | درصد | 87/9/6 | 89/5/14 |
| 331 | 1.12.1 | **اجراي سيستم ارت بندي طبقات** | 457d | 2008-11-26 | 2010-03-06 |  | 161d |  |  |  |  | 87/9/6 | 88/12/15 |
| 332 | 1.12.1.1 | اجراي سيستم ارت بندي( زيرزمين دوم ) | 15d | 2008-11-26 | 2008-12-10 | 362 | 423d | 18d |  |  | درصد | 87/9/6 | 87/9/20 |
| 333 | 1.12.1.2 | اجراي سيستم ارت بندي( زيرزمين اول ) | 15d | 2008-12-29 | 2009-01-12 | 363, 332 | 405d | 28d | 87/12/06 | 87/12/25 | درصد | 87/10/9 | 87/10/23 |
| 334 | 1.12.1.3 | اجراي سيستم ارت بندي( همكف ) | 15d | 2009-02-10 | 2009-02-24 | 207, 333 | 377d | 18d | 87/12/26 | 88/01/15 | درصد | 87/11/22 | 87/12/6 |
| 335 | 1.12.1.4 | اجراي سيستم ارت بندي طبقه اول | 15d | 2009-03-15 | 2009-04-07 | 208, 334 | 359d | 18d | 88/01/16 | 88/02/04 | درصد | 87/12/25 | 88/1/18 |
| 336 | 1.12.1.5 | اجراي سيستم ارت بندي طبقه دوم | 15d | 2009-04-26 | 2009-05-10 | 209, 335 | 341d | 18d | 88/02/05 | 88/02/24 | درصد | 88/2/6 | 88/2/20 |
| 337 | 1.12.1.6 | اجراي سيستم ارت بندي طبقه سوم | 15d | 2009-05-29 | 2009-06-12 | 210, 336 | 323d | 18d | 88/02/25 | 88/03/13 | درصد | 88/3/8 | 88/3/22 |
| 338 | 1.12.1.7 | اجراي سيستم ارت بندي طبقه چهارم | 15d | 2009-07-01 | 2009-07-15 | 211, 337 | 305d | 18d | 88/03/14 | 88/04/02 | درصد | 88/4/10 | 88/4/24 |
| 339 | 1.12.1.8 | اجراي سيستم ارت بندي طبقه پنجم | 15d | 2009-08-03 | 2009-08-17 | 212, 338 | 287d | 26d | 88/04/03 | 88/04/22 | درصد | 88/5/12 | 88/5/26 |
| 340 | 1.12.1.9 | اجراي سيستم ارت بندي طبقه ششم | 15d | 2009-09-13 | 2009-09-27 | 213, 339 | 261d | 25d | 88/04/23 | 88/05/11 | درصد | 88/6/22 | 88/7/5 |
| 341 | 1.12.1.10 | اجراي سيستم ارت بندي طبقه هفتم | 15d | 2009-10-23 | 2009-11-06 | 214, 340 | 236d | 25d | 88/05/12 | 88/05/31 | درصد | 88/8/1 | 88/8/15 |
| 342 | 1.12.1.11 | اجراي سيستم ارت بندي طبقه هشتم | 15d | 2009-12-02 | 2009-12-16 | 215, 341 | 211d | 25d | 88/06/01 | 88/06/20 | درصد | 88/9/11 | 88/9/25 |
| 343 | 1.12.1.12 | اجراي سيستم ارت بندي طبقه نهم | 15d | 2010-01-11 | 2010-01-25 | 216, 342 | 186d | 25d | 88/06/21 | 88/07/09 | درصد | 88/10/21 | 88/11/5 |
| 344 | 1.12.1.13 | اجراي سيستم ارت بندي طبقه دهم | 15d | 2010-02-20 | 2010-03-06 | 217, 343 | 161d |  | 88/07/10 | 88/07/29 | درصد | 88/12/1 | 88/12/15 |

| ID | WBS | Task | Duration | Start | Finish | Predecessors | Total slack | Free slack | Plan Start | Plan Finish | واحد | Text1 | Text2 |
| --- | --- | --- | --- | --- | --- | --- | --- | --- | --- | --- | --- | --- | --- |
| 345 | 1.12.2 | **لوله گذاري و نصب قوطي كليد و پريز طبقات** | 481d | 2009-04-04 | 2010-08-05 |  | 0d |  | 88/1/15 | 89/5/14 |  |  |  |
| 346 | 1.12.2.1 | لوله گذاري و نصب قوطي كليد و پريز( زيرزمين دوم ) | 30d | 2009-04-04 | 2009-05-03 | 362FS+120d, 247 | 91d | 0d | 88/1/15 | 88/2/13 | درصد |  |  |
| 347 | 1.12.2.2 | لوله گذاري و نصب قوطي كليد و پريز( زيرزمين اول ) | 30d | 2009-05-04 | 2009-06-02 | 363FS+10d, 346, 248 | 91d | 0d | 88/2/14 | 88/3/12 | درصد | 87/12/06 | 87/12/25 |
| 348 | 1.12.2.3 | لوله گذاري و نصب قوطي كليد و پريز( همكف ) | 30d | 2009-06-03 | 2009-07-02 | 207FS+10d, 347, 249 | 91d | 0d | 88/3/13 | 88/4/11 | درصد | 87/12/26 | 88/01/15 |
| 349 | 1.12.2.4 | لوله گذاري و نصب قوطي كليد و پريز 1 | 30d | 2009-07-03 | 2009-08-01 | 208FS+10d, 348, 250 | 91d | 10d | 88/4/12 | 88/5/10 | درصد | 88/01/16 | 88/02/04 |
| 350 | 1.12.2.5 | لوله گذاري و نصب قوطي كليد و پريز 2 | 30d | 2009-08-12 | 2009-09-10 | 209FS+10d, 349, 251 | 81d | 10d | 88/5/21 | 88/6/19 | درصد | 88/02/05 | 88/02/24 |
| 351 | 1.12.2.6 | لوله گذاري و نصب قوطي كليد و پريز 3 | 30d | 2009-09-21 | 2009-10-20 | 210FS+10d, 350, 252 | 71d | 10d | 88/6/30 | 88/7/28 | درصد | 88/02/25 | 88/03/13 |
| 352 | 1.12.2.7 | لوله گذاري و نصب قوطي كليد و پريز 4 | 30d | 2009-10-31 | 2009-11-29 | 211FS+10d, 351, 253 | 61d | 10d | 88/8/9 | 88/9/8 | درصد | 88/03/14 | 88/04/02 |
| 353 | 1.12.2.8 | لوله گذاري و نصب قوطي كليد و پريز 5 | 30d | 2009-12-10 | 2010-01-08 | 212FS+10d, 352, 254 | 51d | 10d | 88/9/19 | 88/10/18 | درصد | 88/04/03 | 88/04/22 |
| 354 | 1.12.2.9 | لوله گذاري و نصب قوطي كليد و پريز 6 | 30d | 2010-01-19 | 2010-02-17 | 213FS+10d, 353, 255 | 41d | 10d | 88/10/29 | 88/11/28 | درصد | 88/04/23 | 88/05/11 |
| 355 | 1.12.2.10 | لوله گذاري و نصب قوطي كليد و پريز 7 | 30d | 2010-02-28 | 2010-04-06 | 214FS+10d, 354, 256 | 31d | 10d | 88/12/9 | 89/1/17 | درصد | 88/05/12 | 88/05/31 |
| 356 | 1.12.2.11 | لوله گذاري و نصب قوطي كليد و پريز 8 | 30d | 2010-04-17 | 2010-05-16 | 215FS+10d, 355, 257 | 21d | 10d | 89/1/28 | 89/2/26 | درصد | 88/06/01 | 88/06/20 |
| 357 | 1.12.2.12 | لوله گذاري و نصب قوطي كليد و پريز 9 | 30d | 2010-05-27 | 2010-06-25 | 216FS+10d, 356, 258 | 11d |  | 89/3/6 | 89/4/4 | درصد | 88/06/21 | 88/07/09 |
| 358 | 1.12.2.13 | لوله گذاري و نصب قوطي كليد و پريز 10 | 30d | 2010-07-07 | 2010-08-05 | 217FS+10d, 357, 259 | 0d |  | 89/4/16 | 89/5/14 | درصد | 88/07/10 | 88/07/29 |
| 359 | 1.13 | **نازك كاري** | 711d | 2008-11-06 | 2010-11-03 |  | 0d |  | 87/8/16 | 89/8/12 | درصد | 87/10/06 | 88/12/04 |
| 360 | 1.13.1 | اجراي بتن كف پاركينگ و كفسازي | 10d | 2010-02-14 | 2010-02-23 | 289, 332 | 233d | 0d | 88/11/25 | 88/12/4 | درصد | 87/10/06 | 88/02/04 |
| 361 | 1.13.2 | **سيمانكاري آستر و رويه زيرزمين پاركينگ** | 53d | 2008-11-06 | 2008-12-28 |  | 0d |  | 87/8/16 | 87/10/8 |  |  |  |
| 362 | 1.13.2.1 | سيمانكاري آستر و رويه زيرزمين دوم | 20d | 2008-11-06 | 2008-11-25 | 179 | 0d |  | 87/8/16 | 87/9/5 | مترمربع |  |  |
| 363 | 1.13.2.2 | سيمانكاري آستر و رويه زيرزمين اول | 20d | 2008-12-09 | 2008-12-28 | 180, 362 | 57d | 0d | 87/9/19 | 87/10/8 | مترمربع | 87/12/06 | 87/12/25 |
| 364 | 1.13.3 | **پلاستر سيمان سرويسها،آشپزخانه ها،،بالكن هاو…** | 151d | 2010-04-04 | 2010-09-01 |  | 0d |  | 89/1/15 | 89/6/10 |  |  |  |
| 365 | 1.13.3.1 | پلاستر سيمان سرويسها،آشپزخانه هاو،بالكن هاي طبقه همكف | 10d | 2010-04-04 | 2010-04-13 | 291, 334, 249, 263, 277, 305, 319, 348 | 0d |  | 89/1/15 | 89/1/24 | متر مربع |  |  |
| 366 | 1.13.3.2 | پلاستر سيمان سرويسها،آشپزخانه هاو،بالكن هاي طبقه اول | 10d | 2010-04-11 | 2010-04-20 | 292, 335, 250, 264, 278, 306, 320, 349 | 44d | 0d | 89/1/22 | 89/1/31 | متر مربع |  |  |
| 367 | 1.13.3.3 | پلاستر سيمان سرويسها،آشپزخانه هاو،بالكن هاي طبقه دوم | 10d | 2010-04-23 | 2010-05-02 | 293, 336, 251, 265, 279, 321, 350, 307 | 42d | 0d | 89/2/3 | 89/2/12 | متر مربع |  |  |
| 368 | 1.13.3.4 | پلاستر سيمان سرويسها،آشپزخانه هاو،بالكن هاي طبقه سوم | 10d | 2010-05-08 | 2010-05-17 | 294, 337, 252, 266, 280, 322, 351, 308 | 37d | 0d | 89/2/18 | 89/2/27 | متر مربع |  |  |
| 369 | 1.13.3.5 | پلاستر سيمان سرويسها،آشپزخانه هاو،بالكن هاي طبقه چهارم | 10d | 2010-05-23 | 2010-06-01 | 295, 338, 253, 267, 281, 323, 352, 309 | 32d | 0d | 89/3/2 | 89/3/11 | متر مربع |  |  |
| 370 | 1.13.3.6 | پلاستر سيمان سرويسها،آشپزخانه هاو،بالكن هاي طبقه پنجم | 10d | 2010-06-07 | 2010-06-16 | 296, 339, 254, 268, 282, 324, 353, 310 | 27d | 0d | 89/3/17 | 89/3/26 | متر مربع |  |  |
| 371 | 1.13.3.7 | پلاستر سيمان سرويسها،آشپزخانه هاو،بالكن هاي طبقه ششم | 10d | 2010-06-22 | 2010-07-01 | 297, 340, 255, 269, 283, 325, 354, 311 | 22d | 0d | 89/4/1 | 89/4/10 | متر مربع |  |  |
| 372 | 1.13.3.8 | پلاستر سيمان سرويسها،آشپزخانه هاو،بالكن هاي طبقه هفتم | 10d | 2010-07-07 | 2010-07-16 | 298, 341, 256, 270, 284, 326, 312, 355 | 17d | 0d | 89/4/16 | 89/4/25 | متر مربع |  |  |
| 373 | 1.13.3.9 | پلاستر سيمان سرويسها،آشپزخانه هاو،بالكن هاي طبقه هشتم | 10d | 2010-07-22 | 2010-07-31 | 299, 342, 257, 271, 285, 327, 313, 356 | 12d | 0d | 89/4/31 | 89/5/9 | متر مربع |  |  |
| 374 | 1.13.3.10 | پلاستر سيمان سرويسها،آشپزخانه هاو،بالكن هاي طبقه نهم | 10d | 2010-08-06 | 2010-08-15 | 300, 343, 258, 272, 286, 328, 314, 357 | 7d | 0d | 89/5/15 | 89/5/24 | متر مربع |  |  |
| 375 | 1.13.3.11 | پلاستر سيمان سرويسها،آشپزخانه هاو،بالكن هاي طبقه دهم | 10d | 2010-08-23 | 2010-09-01 | 301, 344, 259, 273, 287, 329, 315, 358 | 0d |  | 89/6/1 | 89/6/10 | متر مربع |  |  |

| ID | WBS | Task | Duration | Start | Finish | Predecessors | Total slack | Free slack | Plan Start | Plan Finish | Text1 | Text2 | واحد |
| --- | --- | --- | --- | --- | --- | --- | --- | --- | --- | --- | --- | --- | --- |
| 376 | 1.13.4 | **نصب پنجره ها و شيشه هاي طبقات** | 146d | 2010-04-04 | 2010-08-27 |  | 76d | 0d | 89/1/15 | 89/6/5 |  |  |  |
| 377 | 1.13.4.1 | نصب پنجره ها و شيشه هاي طبقه همكف | 5d | 2010-04-04 | 2010-04-08 | 365SS | 217d |  | 89/1/15 | 89/1/19 |  |  |  |
| 378 | 1.13.4.2 | نصب پنجره ها و شيشه هاي طبقه اول | 5d | 2010-04-11 | 2010-04-15 | 366SS | 210d |  | 89/1/22 | 89/1/26 |  |  |  |
| 379 | 1.13.4.3 | نصب پنجره ها و شيشه هاي طبقه دوم | 5d | 2010-04-23 | 2010-04-27 | 367SS | 198d |  | 89/2/3 | 89/2/7 |  |  |  |
| 380 | 1.13.4.4 | نصب پنجره ها و شيشه هاي طبقه سوم | 5d | 2010-05-08 | 2010-05-12 | 368SS | 183d |  | 89/2/18 | 89/2/22 |  |  |  |
| 381 | 1.13.4.5 | نصب پنجره ها و شيشه هاي طبقه چهارم | 5d | 2010-05-23 | 2010-05-27 | 369SS | 168d |  | 89/3/2 | 89/3/6 |  |  |  |
| 382 | 1.13.4.6 | نصب پنجره ها و شيشه هاي طبقه پنجم | 5d | 2010-06-07 | 2010-06-11 | 370SS | 153d |  | 89/3/17 | 89/3/21 |  |  |  |
| 383 | 1.13.4.7 | نصب پنجره ها و شيشه هاي طبقه ششم | 5d | 2010-06-22 | 2010-06-26 | 371SS | 138d |  | 89/4/1 | 89/4/5 |  |  |  |
| 384 | 1.13.4.8 | نصب پنجره ها و شيشه هاي طبقه هفتم | 5d | 2010-07-07 | 2010-07-11 | 372SS | 123d |  | 89/4/16 | 89/4/20 |  |  |  |
| 385 | 1.13.4.9 | نصب پنجره ها و شيشه هاي طبقه هشتم | 5d | 2010-07-22 | 2010-07-26 | 373SS | 108d |  | 89/4/31 | 89/5/4 |  |  |  |
| 386 | 1.13.4.10 | نصب پنجره ها و شيشه هاي طبقه نهم | 5d | 2010-08-06 | 2010-08-10 | 374SS | 93d |  | 89/5/15 | 89/5/19 |  |  |  |
| 387 | 1.13.4.11 | نصب پنجره ها و شيشه هاي طبقه دهم | 5d | 2010-08-23 | 2010-08-27 | 375SS | 76d |  | 89/6/1 | 89/6/5 |  |  |  |
| 388 | 1.13.5 | نماسازي | 94d | 2009-12-23 | 2010-04-04 | 376SF, 166 | 222d |  | 88/10/2 | 89/1/15 | 88/05/14 | 88/12/01 | مترمربع |
| 389 | 1.13.6 | **عايق كاري سرويسها،آشپزخانه ها،بالكن ها و پشت بام** | 146d | 2010-04-24 | 2010-09-16 |  | 0d |  | 89/2/4 | 89/6/25 |  |  |  |
| 390 | 1.13.6.1 | عايق كاري سرويسها،آشپزخانه هاو،بالكن هاي طبقه همكف | 5d | 2010-04-24 | 2010-04-28 | 365, 233 | 0d |  | 89/2/4 | 89/2/8 |  |  | مترمربع |
| 391 | 1.13.6.2 | عايق كاري سرويسها،آشپزخانه هاو،بالكن هاي طبقه اول | 5d | 2010-05-01 | 2010-05-05 | 366, 234 | 44d | 0d | 89/2/11 | 89/2/15 |  |  | مترمربع |
| 392 | 1.13.6.3 | عايق كاري سرويسها،آشپزخانه هاو،بالكن هاي طبقه دوم | 5d | 2010-05-13 | 2010-05-17 | 367, 235 | 42d | 0d | 89/2/23 | 89/2/27 |  |  | مترمربع |
| 393 | 1.13.6.4 | عايق كاري سرويسها،آشپزخانه هاو،بالكن هاي طبقه سوم | 5d | 2010-05-28 | 2010-06-01 | 368, 236 | 37d | 0d | 89/3/7 | 89/3/11 |  |  | مترمربع |
| 394 | 1.13.6.5 | عايق كاري سرويسها،آشپزخانه هاو،بالكن هاي طبقه چهارم | 5d | 2010-06-12 | 2010-06-16 | 369, 237 | 32d | 0d | 89/3/22 | 89/3/26 |  |  | مترمربع |
| 395 | 1.13.6.6 | عايق كاري سرويسها،آشپزخانه هاو،بالكن هاي طبقه پنجم | 5d | 2010-06-27 | 2010-07-01 | 370, 238 | 27d | 0d | 89/4/6 | 89/4/10 |  |  | مترمربع |
| 396 | 1.13.6.7 | عايق كاري سرويسها،آشپزخانه هاو،بالكن هاي طبقه ششم | 5d | 2010-07-12 | 2010-07-16 | 371, 239 | 22d | 0d | 89/4/21 | 89/4/25 |  |  | مترمربع |
| 397 | 1.13.6.8 | عايق كاري سرويسها،آشپزخانه هاو،بالكن هاي طبقه هفتم | 5d | 2010-07-27 | 2010-07-31 | 372, 240 | 17d | 0d | 89/5/5 | 89/5/9 |  |  | مترمربع |
| 398 | 1.13.6.9 | عايق كاري سرويسها،آشپزخانه هاو،بالكن هاي طبقه هشتم | 5d | 2010-08-11 | 2010-08-15 | 373, 241 | 12d | 0d | 89/5/20 | 89/5/24 |  |  | مترمربع |
| 399 | 1.13.6.10 | عايق كاري سرويسها،آشپزخانه هاو،بالكن هاي طبقه نهم | 5d | 2010-08-26 | 2010-08-30 | 374, 242 | 7d | 0d | 89/6/4 | 89/6/8 |  |  | مترمربع |
| 400 | 1.13.6.11 | عايق كاري سرويسها،آشپزخانه هاو،بالكن هاي طبقه دهم | 5d | 2010-09-12 | 2010-09-16 | 375, 243 | 0d |  | 89/6/21 | 89/6/25 |  |  | مترمربع |

| ID | WBS | Task | Duration | Start | Finish | Predecessors | Total slack | Free slack | Plan Start | Plan Finish | واحد | Text1 | Text2 |
| --- | --- | --- | --- | --- | --- | --- | --- | --- | --- | --- | --- | --- | --- |
| 401 | 1.13.7 | **سراميك كاري سرويسها و آشپزخانه هاوپذيرايي و اتاق خوابها** | 161d | 2010-04-29 | 2010-10-06 |  | 0d |  | 89/2/9 | 89/7/14 |  |  |  |
| 402 | 1.13.7.1 | سراميك كاري سرويسها و آشپزخانه هاوپذيرايي و اتاق خوابهاي همكف | 20d | 2010-04-29 | 2010-05-18 | 390 | 0d |  | 89/2/9 | 89/2/28 | مترمربع |  |  |
| 403 | 1.13.7.2 | سراميك كاري سرويسها و آشپزخانه هاوپذيرايي و اتاق خوابهاي طبقه اول | 20d | 2010-05-06 | 2010-05-25 | 391 | 44d | 0d | 89/2/16 | 89/3/4 | مترمربع |  |  |
| 404 | 1.13.7.3 | سراميك كاري سرويسها و آشپزخانه هاوپذيرايي و اتاق خوابهاي طبقه دوم | 20d | 2010-05-18 | 2010-06-06 | 392 | 42d | 0d | 89/2/28 | 89/3/16 | مترمربع |  |  |
| 405 | 1.13.7.4 | سراميك كاري سرويسها و آشپزخانه هاوپذيرايي و اتاق خوابهاي طبقه سوم | 20d | 2010-06-02 | 2010-06-21 | 393 | 37d | 0d | 89/3/12 | 89/3/31 | مترمربع |  |  |
| 406 | 1.13.7.5 | سراميك كاري سرويسها و آشپزخانه هاوپذيرايي و اتاق خوابهاي طبقه چهارم | 20d | 2010-06-17 | 2010-07-06 | 394 | 32d | 0d | 89/3/27 | 89/4/15 | مترمربع |  |  |
| 407 | 1.13.7.6 | سراميك كاري سرويسها و آشپزخانه هاوپذيرايي و اتاق خوابهاي طبقه پنجم | 20d | 2010-07-02 | 2010-07-21 | 395 | 27d | 0d | 89/4/11 | 89/4/30 | مترمربع |  |  |
| 408 | 1.13.7.7 | سراميك كاري سرويسها و آشپزخانه هاوپذيرايي و اتاق خوابهاي طبقه ششم | 20d | 2010-07-17 | 2010-08-05 | 396 | 22d | 0d | 89/4/26 | 89/5/14 | مترمربع |  |  |
| 409 | 1.13.7.8 | سراميك كاري سرويسها و آشپزخانه هاوپذيرايي و اتاق خوابهاي طبقه هفتم | 20d | 2010-08-01 | 2010-08-20 | 397 | 17d | 0d | 89/5/10 | 89/5/29 | مترمربع |  |  |
| 410 | 1.13.7.9 | سراميك كاري سرويسها و آشپزخانه هاوپذيرايي و اتاق خوابهاي طبقه هشتم | 20d | 2010-08-16 | 2010-09-04 | 398 | 12d | 0d | 89/5/25 | 89/6/13 | مترمربع |  |  |
| 411 | 1.13.7.10 | سراميك كاري سرويسها و آشپزخانه هاوپذيرايي و اتاق خوابهاي طبقه نهم | 20d | 2010-08-31 | 2010-09-19 | 399 | 7d | 0d | 89/6/9 | 89/6/28 | مترمربع |  |  |
| 412 | 1.13.7.11 | سراميك كاري سرويسها و آشپزخانه هاوپذيرايي و اتاق خوابهاي طبقه دهم | 20d | 2010-09-17 | 2010-10-06 | 400 | 0d |  | 89/6/26 | 89/7/14 | مترمربع |  |  |
| 413 | 1.13.8 | **كاشيكاري سرويسها و آشپزخانه ها** | 161d | 2010-05-09 | 2010-10-16 |  | 0d |  | 89/2/19 | 89/7/24 |  | 87/12/06 | 88/08/10 |
| 414 | 1.13.8.1 | كاشيكاري سرويسها و آشپزخانه هاي طبقه همكف | 20d | 2010-05-09 | 2010-05-28 | 402SS+10d | 0d |  | 89/2/19 | 89/3/7 | مترمربع |  |  |
| 415 | 1.13.8.2 | كاشيكاري سرويسها و آشپزخانه هاي طبقه اول | 20d | 2010-05-16 | 2010-06-04 | 403SS+10d | 140d | 0d | 89/2/26 | 89/3/14 | مترمربع | 87/12/06 | 87/12/25 |
| 416 | 1.13.8.3 | كاشيكاري سرويسها و آشپزخانه هاي طبقه دوم | 20d | 2010-05-28 | 2010-06-16 | 404SS+10d | 128d | 0d | 89/3/7 | 89/3/26 | مترمربع | 88/01/26 | 88/02/14 |
| 417 | 1.13.8.4 | كاشيكاري سرويسها و آشپزخانه هاي طبقه سوم | 20d | 2010-06-12 | 2010-07-01 | 405SS+10d | 113d | 0d | 89/3/22 | 89/4/10 | مترمربع | 88/02/15 | 88/03/03 |
| 418 | 1.13.8.5 | كاشيكاري سرويسها و آشپزخانه هاي طبقه چهارم | 20d | 2010-06-27 | 2010-07-16 | 406SS+10d | 98d | 0d | 89/4/6 | 89/4/25 | مترمربع | 88/03/04 | 88/03/23 |
| 419 | 1.13.8.6 | كاشيكاري سرويسها و آشپزخانه هاي طبقه پنجم | 20d | 2010-07-12 | 2010-07-31 | 407SS+10d | 83d | 0d | 89/4/21 | 89/5/9 | مترمربع | 88/03/24 | 88/04/12 |
| 420 | 1.13.8.7 | كاشيكاري سرويسها و آشپزخانه هاي طبقه ششم | 20d | 2010-07-27 | 2010-08-15 | 408SS+10d | 68d | 0d | 89/5/5 | 89/5/24 | مترمربع | 88/04/13 | 88/05/01 |
| 421 | 1.13.8.8 | كاشيكاري سرويسها و آشپزخانه هاي طبقه هفتم | 20d | 2010-08-11 | 2010-08-30 | 409SS+10d | 53d | 0d | 89/5/20 | 89/6/8 | مترمربع | 88/05/02 | 88/05/21 |
| 422 | 1.13.8.9 | كاشيكاري سرويسها و آشپزخانه هاي طبقه هشتم | 20d | 2010-08-26 | 2010-09-14 | 410SS+10d | 38d | 0d | 89/6/4 | 89/6/23 | مترمربع | 88/05/22 | 88/06/10 |
| 423 | 1.13.8.10 | كاشيكاري سرويسها و آشپزخانه هاي طبقه نهم | 20d | 2010-09-10 | 2010-09-29 | 411SS+10d | 23d | 0d | 89/6/19 | 89/7/7 | مترمربع | 88/06/11 | 88/06/30 |
| 424 | 1.13.8.11 | كاشيكاري سرويسها و آشپزخانه هاي طبقه دهم | 20d | 2010-09-27 | 2010-10-16 | 412SS+10d | 4d | 0d | 89/7/5 | 89/7/24 | مترمربع | 88/06/31 | 88/07/19 |

| ID | WBS | Task | Duration | Start | Finish | Predecessors | Total slack | Free slack | Plan Start | Plan Finish | واحد |
| --- | --- | --- | --- | --- | --- | --- | --- | --- | --- | --- | --- |
| 425 | 1.13.9 | **اجراي سنگ كف و اجراي پله ها** | 187d | 2010-02-14 | 2010-08-27 |  | 66d |  | 88/11/25 | 89/6/5 |  |
| 426 | 1.13.9.1 | اجراي سنگ كف و اجراي پله هاي طبقه زيرزمين دوم | 5d | 2010-02-14 | 2010-02-18 | 289, 332 | 238d | 5d | 88/11/25 | 88/11/29 | مترمربع |
| 427 | 1.13.9.2 | اجراي سنگ كف و اجراي پله هاي طبقه زيرزمين اول | 5d | 2010-03-01 | 2010-03-05 | 290, 333 | 233d | 15d | 88/12/10 | 88/12/14 | مترمربع |
| 428 | 1.13.9.3 | اجراي سنگ كف و اجراي پله هاي طبقه همكف | 5d | 2010-04-04 | 2010-04-08 | 365SS | 40d | 15d | 89/1/15 | 89/1/19 | مترمربع |
| 429 | 1.13.9.4 | اجراي سنگ كف و اجراي پله هاي طبقه اول | 5d | 2010-04-11 | 2010-04-15 | 366SS | 180d | 15d | 89/1/22 | 89/1/26 | مترمربع |
| 430 | 1.13.9.5 | اجراي سنگ كف و اجراي پله هاي طبقه دوم | 5d | 2010-04-23 | 2010-04-27 | 367SS | 168d | 15d | 89/2/3 | 89/2/7 | مترمربع |
| 431 | 1.13.9.6 | اجراي سنگ كف و اجراي پله هاي طبقه سوم | 5d | 2010-05-08 | 2010-05-12 | 368SS | 153d | 15d | 89/2/18 | 89/2/22 | مترمربع |
| 432 | 1.13.9.7 | اجراي سنگ كف و اجراي پله هاي طبقه چهارم | 5d | 2010-05-23 | 2010-05-27 | 369SS | 138d | 15d | 89/3/2 | 89/3/6 | مترمربع |
| 433 | 1.13.9.8 | اجراي سنگ كف و اجراي پله هاي طبقه پنجم | 5d | 2010-06-07 | 2010-06-11 | 370SS | 123d | 15d | 89/3/17 | 89/3/21 | مترمربع |
| 434 | 1.13.9.9 | اجراي سنگ كف و اجراي پله هاي طبقه ششم | 5d | 2010-06-22 | 2010-06-26 | 371SS | 108d | 15d | 89/4/1 | 89/4/5 | مترمربع |
| 435 | 1.13.9.10 | اجراي سنگ كف و اجراي پله هاي طبقه هفتم | 5d | 2010-07-07 | 2010-07-11 | 372SS | 93d | 15d | 89/4/16 | 89/4/20 | مترمربع |
| 436 | 1.13.9.11 | اجراي سنگ كف و اجراي پله هاي طبقه هشتم | 5d | 2010-07-22 | 2010-07-26 | 373SS | 78d | 15d | 89/4/31 | 89/5/4 | مترمربع |
| 437 | 1.13.9.12 | اجراي سنگ كف و اجراي پله هاي طبقه نهم | 5d | 2010-08-06 | 2010-08-10 | 374SS | 63d | 15d | 89/5/15 | 89/5/19 | مترمربع |
| 438 | 1.13.9.13 | اجراي سنگ كف و اجراي پله هاي طبقه دهم | 5d | 2010-08-23 | 2010-08-27 | 375SS | 44d | 15d | 89/6/1 | 89/6/5 | مترمربع |
| 439 | 1.13.10 | **اجراي سنگ بدنه در راهروها و راه پله ها** | 202d | 2010-02-24 | 2010-09-21 |  | 51d |  | 88/12/5 | 89/6/30 |  |
| 440 | 1.13.10.1 | اجراي سنگ بدنه در راهروها و راه پله هاي طبقه زيرزمين دوم | 10d | 2010-02-24 | 2010-03-05 | 426, 360 | 233d | 0d | 88/12/5 | 88/12/14 | مترمربع |
| 441 | 1.13.10.2 | اجراي سنگ بدنه در راهروها و راه پله هاي طبقه زيرزمين اول | 10d | 2010-03-29 | 2010-04-07 | 427, 232 | 218d |  | 89/1/9 | 89/1/18 | مترمربع |
| 442 | 1.13.10.3 | اجراي سنگ بدنه در راهروها و راه پله هاي طبقه همكف | 10d | 2010-04-24 | 2010-05-03 | 428, 233 | 25d |  | 89/2/4 | 89/2/13 | مترمربع |
| 443 | 1.13.10.4 | اجراي سنگ بدنه در راهروها و راه پله هاي طبقه اول | 10d | 2010-05-01 | 2010-05-10 | 429, 234 | 165d | 25d | 89/2/11 | 89/2/20 | مترمربع |
| 444 | 1.13.10.5 | اجراي سنگ بدنه در راهروها و راه پله هاي طبقه دوم | 10d | 2010-05-13 | 2010-05-22 | 430, 235 | 153d | 25d | 89/2/23 | 89/3/1 | مترمربع |
| 445 | 1.13.10.6 | اجراي سنگ بدنه در راهروها و راه پله هاي طبقه سوم | 10d | 2010-05-28 | 2010-06-06 | 431, 236 | 138d | 25d | 89/3/7 | 89/3/16 | مترمربع |
| 446 | 1.13.10.7 | اجراي سنگ بدنه در راهروها و راه پله هاي طبقه چهارم | 10d | 2010-06-12 | 2010-06-21 | 432, 237 | 123d | 25d | 89/3/22 | 89/3/31 | مترمربع |
| 447 | 1.13.10.8 | اجراي سنگ بدنه در راهروها و راه پله هاي طبقه پنجم | 10d | 2010-06-27 | 2010-07-06 | 433, 238 | 108d | 25d | 89/4/6 | 89/4/15 | مترمربع |
| 448 | 1.13.10.9 | اجراي سنگ بدنه در راهروها و راه پله هاي طبقه ششم | 10d | 2010-07-12 | 2010-07-21 | 434, 239 | 93d | 25d | 89/4/21 | 89/4/30 | مترمربع |
| 449 | 1.13.10.10 | اجراي سنگ بدنه در راهروها و راه پله هاي طبقه هفتم | 10d | 2010-07-27 | 2010-08-05 | 435, 240 | 78d | 25d | 89/5/5 | 89/5/14 | مترمربع |
| 450 | 1.13.10.11 | اجراي سنگ بدنه در راهروها و راه پله هاي طبقه هشتم | 10d | 2010-08-11 | 2010-08-20 | 436, 241 | 63d | 25d | 89/5/20 | 89/5/29 | مترمربع |
| 451 | 1.13.10.12 | اجراي سنگ بدنه در راهروها و راه پله هاي طبقه نهم | 10d | 2010-08-26 | 2010-09-04 | 437, 242 | 48d | 25d | 89/6/4 | 89/6/13 | مترمربع |
| 452 | 1.13.10.13 | اجراي سنگ بدنه در راهروها و راه پله هاي طبقه دهم | 10d | 2010-09-12 | 2010-09-21 | 438, 243 | 29d | 25d | 89/6/21 | 89/6/30 | مترمربع |

| ID | WBS | Task | Duration | Start | Finish | Predecessors | Total slack | Free slack | Plan Start | Plan Finish | واحد |
| --- | --- | --- | --- | --- | --- | --- | --- | --- | --- | --- | --- |
| 453 | 1.13.11 | **اجراي موزاييك و قرنيز ديوارها** | 151d | 2010-04-24 | 2010-09-21 |  | 25d |  | 89/2/4 | 89/6/30 |  |
| 454 | 1.13.11.1 | اجراي موزاييك و قرنيز ديوارها طبقه همكف | 10d | 2010-04-24 | 2010-05-03 | 428, 233 | 25d |  | 89/2/4 | 89/2/13 | مترمربع |
| 455 | 1.13.11.2 | اجراي موزاييك و قرنيز ديوارهاي طبقه اول | 10d | 2010-05-01 | 2010-05-10 | 429, 234 | 165d | 25d | 89/2/11 | 89/2/20 | مترمربع |
| 456 | 1.13.11.3 | اجراي موزاييك و قرنيز ديوارهاي طبقه دوم | 10d | 2010-05-13 | 2010-05-22 | 430, 235 | 153d | 25d | 89/2/23 | 89/3/1 | مترمربع |
| 457 | 1.13.11.4 | اجراي موزاييك و قرنيز ديوارهاي طبقه سوم | 10d | 2010-05-28 | 2010-06-06 | 431, 236 | 138d | 25d | 89/3/7 | 89/3/16 | مترمربع |
| 458 | 1.13.11.5 | اجراي موزاييك و قرنيز ديوارهاي طبقه چهارم | 10d | 2010-06-12 | 2010-06-21 | 432, 237 | 123d | 25d | 89/3/22 | 89/3/31 | مترمربع |
| 459 | 1.13.11.6 | اجراي موزاييك و قرنيز ديوارهاي طبقه پنجم | 10d | 2010-06-27 | 2010-07-06 | 433, 238 | 108d | 25d | 89/4/6 | 89/4/15 | مترمربع |
| 460 | 1.13.11.7 | اجراي موزاييك و قرنيز ديوارهاي طبقه ششم | 10d | 2010-07-12 | 2010-07-21 | 434, 239 | 93d | 25d | 89/4/21 | 89/4/30 | مترمربع |
| 461 | 1.13.11.8 | اجراي موزاييك و قرنيز ديوارهاي طبقه هفتم | 10d | 2010-07-27 | 2010-08-05 | 435, 240 | 78d | 25d | 89/5/5 | 89/5/14 | مترمربع |
| 462 | 1.13.11.9 | اجراي موزاييك و قرنيز ديوارهاي طبقه هشتم | 10d | 2010-08-11 | 2010-08-20 | 436, 241 | 63d | 25d | 89/5/20 | 89/5/29 | مترمربع |
| 463 | 1.13.11.10 | اجراي موزاييك و قرنيز ديوارهاي طبقه نهم | 10d | 2010-08-26 | 2010-09-04 | 437, 242 | 48d | 25d | 89/6/4 | 89/6/13 | مترمربع |
| 464 | 1.13.11.11 | اجراي موزاييك و قرنيز ديوارهاي طبقه دهم | 10d | 2010-09-12 | 2010-09-21 | 438, 243 | 29d | 25d | 89/6/21 | 89/6/30 | مترمربع |
| 465 | 1.13.12 | **اجراي كارهاي چوبي درهاي ورودي وادها،اتاق خوابها و …** | 110d | 2010-06-28 | 2010-10-15 |  | 1d |  | 89/4/7 | 89/7/23 |  |
| 466 | 1.13.12.1 | اجراي كارهاي چوبي درهاي ورودي وادها،اتاق خوابهاي طبقه همكف | 10d | 2010-06-28 | 2010-07-07 | 490 | 99d | 0d | 89/4/7 | 89/4/16 |  |
| 467 | 1.13.12.2 | اجراي كارهاي چوبي درهاي ورودي وادها،اتاق خوابهاي طبقه اول | 10d | 2010-07-08 | 2010-07-17 | 491 | 89d | 0d | 89/4/17 | 89/4/26 |  |
| 468 | 1.13.12.3 | اجراي كارهاي چوبي درهاي ورودي وادها،اتاق خوابهاي طبقه دوم | 10d | 2010-07-18 | 2010-07-27 | 492 | 79d | 0d | 89/4/27 | 89/5/5 |  |
| 469 | 1.13.12.4 | اجراي كارهاي چوبي درهاي ورودي وادها،اتاق خوابهاي طبقه سوم | 10d | 2010-07-28 | 2010-08-06 | 493 | 69d | 0d | 89/5/6 | 89/5/15 |  |
| 470 | 1.13.12.5 | اجراي كارهاي چوبي درهاي ورودي وادها،اتاق خوابهاي طبقه چهارم | 10d | 2010-08-07 | 2010-08-16 | 494 | 59d | 0d | 89/5/16 | 89/5/25 |  |
| 471 | 1.13.12.6 | اجراي كارهاي چوبي درهاي ورودي وادها،اتاق خوابهاي طبقه پنجم | 10d | 2010-08-17 | 2010-08-26 | 495 | 49d | 0d | 89/5/26 | 89/6/4 |  |
| 472 | 1.13.12.7 | اجراي كارهاي چوبي درهاي ورودي وادها،اتاق خوابهاي طبقه ششم | 10d | 2010-08-27 | 2010-09-05 | 496 | 39d | 0d | 89/6/5 | 89/6/14 |  |
| 473 | 1.13.12.8 | اجراي كارهاي چوبي درهاي ورودي وادها،اتاق خوابهاي طبقه هفتم | 10d | 2010-09-06 | 2010-09-15 | 497 | 29d | 0d | 89/6/15 | 89/6/24 |  |
| 474 | 1.13.12.9 | اجراي كارهاي چوبي درهاي ورودي وادها،اتاق خوابهاي طبقه هشتم | 10d | 2010-09-16 | 2010-09-25 | 498 | 19d | 0d | 89/6/25 | 89/7/3 |  |
| 475 | 1.13.12.10 | اجراي كارهاي چوبي درهاي ورودي وادها،اتاق خوابهاي طبقه نهم | 10d | 2010-09-26 | 2010-10-05 | 499 | 9d | 0d | 89/7/4 | 89/7/13 |  |
| 476 | 1.13.12.11 | اجراي كارهاي چوبي درهاي ورودي وادها،اتاق خوابهاي طبقه دهم | 10d | 2010-10-06 | 2010-10-15 | 500 | 1d |  | 89/7/14 | 89/7/23 |  |

| ID | WBS | Task | Duration | Start | Finish | Predecessors | Total slack | Text1 | Text2 | واحد | Plan Start | Plan Finish |
| --- | --- | --- | --- | --- | --- | --- | --- | --- | --- | --- | --- | --- |
| 477 | 1.13.13 | **اجراي سقف كاذب سرويسهاي طبقات** | 156d | 2010-05-29 | 2010-10-31 |  | 11d | 88/02/15 | 88/09/19 | درصد | 89/3/8 | 89/8/9 |
| 478 | 1.13.13.1 | اجراي سقف كاذب سرويسهاي طبقه همكف | 15d | 2010-05-29 | 2010-06-12 | 414 | 152d | 88/02/15 | 88/03/03 | مترمربع | 89/3/8 | 89/3/22 |
| 479 | 1.13.13.2 | اجراي سقف كاذب سرويسهاي طبقه اول | 15d | 2010-06-05 | 2010-06-19 | 415 | 145d | 88/03/04 | 88/03/23 | مترمربع | 89/3/15 | 89/3/29 |
| 480 | 1.13.13.3 | اجراي سقف كاذب سرويسهاي طبقه دوم | 15d | 2010-06-17 | 2010-07-01 | 416 | 133d | 88/03/24 | 88/04/12 | مترمربع | 89/3/27 | 89/4/10 |
| 481 | 1.13.13.4 | اجراي سقف كاذب سرويسهاي طبقه سوم | 15d | 2010-07-02 | 2010-07-16 | 417 | 118d | 88/04/13 | 88/05/01 | مترمربع | 89/4/11 | 89/4/25 |
| 482 | 1.13.13.5 | اجراي سقف كاذب سرويسهاي طبقه چهارم | 15d | 2010-07-17 | 2010-07-31 | 418 | 103d | 88/05/02 | 88/05/21 | مترمربع | 89/4/26 | 89/5/9 |
| 483 | 1.13.13.6 | اجراي سقف كاذب سرويسهاي طبقه پنجم | 15d | 2010-08-01 | 2010-08-15 | 419 | 88d | 88/05/22 | 88/06/10 | مترمربع | 89/5/10 | 89/5/24 |
| 484 | 1.13.13.7 | اجراي سقف كاذب سرويسهاي طبقه ششم | 15d | 2010-08-16 | 2010-08-30 | 420 | 73d | 88/06/11 | 88/06/30 | مترمربع | 89/5/25 | 89/6/8 |
| 485 | 1.13.13.8 | اجراي سقف كاذب سرويسهاي طبقه هفتم | 15d | 2010-08-31 | 2010-09-14 | 421 | 58d | 88/06/31 | 88/07/19 | مترمربع | 89/6/9 | 89/6/23 |
| 486 | 1.13.13.9 | اجراي سقف كاذب سرويسهاي طبقه هشتم | 15d | 2010-09-15 | 2010-09-29 | 422 | 43d | 88/07/20 | 88/08/09 | مترمربع | 89/6/24 | 89/7/7 |
| 487 | 1.13.13.10 | اجراي سقف كاذب سرويسهاي طبقه نهم | 15d | 2010-09-30 | 2010-10-14 | 423 | 28d | 88/08/10 | 88/08/29 | مترمربع | 89/7/8 | 89/7/22 |
| 488 | 1.13.13.11 | اجراي سقف كاذب سرويسهاي طبقه دهم | 15d | 2010-10-17 | 2010-10-31 | 424 | 11d | 88/08/30 | 88/09/19 | مترمربع | 89/7/25 | 89/8/9 |
| 489 | 1.13.14 | **اجراي سفيدكاري** | 110d | 2010-06-18 | 2010-10-05 |  | 0d | 87/12/26 | 88/10/09 | درصد | 89/3/28 | 89/7/13 |
| 490 | 1.13.14.1 | اجراي سفيدکاري همکف | 10d | 2010-06-18 | 2010-06-27 | 219, 207 | 0d | 88/03/04 | 88/03/23 | مترمربع | 89/3/28 | 89/4/6 |
| 491 | 1.13.14.2 | اجراي سفيدكاري طبقه 1 | 10d | 2010-06-28 | 2010-07-07 | 490 | 0d | 88/03/24 | 88/04/12 | مترمربع | 89/4/7 | 89/4/16 |
| 492 | 1.13.14.3 | اجراي سفيدكاري طبقه 2 | 10d | 2010-07-08 | 2010-07-17 | 491 | 0d | 88/04/13 | 88/05/01 | مترمربع | 89/4/17 | 89/4/26 |
| 493 | 1.13.14.4 | اجراي سفيدكاري طبقه 3 | 10d | 2010-07-18 | 2010-07-27 | 492 | 0d | 88/05/02 | 88/05/21 | مترمربع | 89/4/27 | 89/5/5 |
| 494 | 1.13.14.5 | اجراي سفيدكاري طبقه 4 | 10d | 2010-07-28 | 2010-08-06 | 493 | 0d | 88/05/22 | 88/06/10 | مترمربع | 89/5/6 | 89/5/15 |
| 495 | 1.13.14.6 | اجراي سفيدكاري طبقه 5 | 10d | 2010-08-07 | 2010-08-16 | 494 | 0d | 88/06/11 | 88/06/30 | مترمربع | 89/5/16 | 89/5/25 |
| 496 | 1.13.14.7 | اجراي سفيدكاري طبقه 6 | 10d | 2010-08-17 | 2010-08-26 | 495 | 0d | 88/06/31 | 88/07/19 | مترمربع | 89/5/26 | 89/6/4 |
| 497 | 1.13.14.8 | اجراي سفيدكاري طبقه 7 | 10d | 2010-08-27 | 2010-09-05 | 496 | 0d | 88/07/20 | 88/08/09 | مترمربع | 89/6/5 | 89/6/14 |
| 498 | 1.13.14.9 | اجراي سفيدكاري طبقه 8 | 10d | 2010-09-06 | 2010-09-15 | 497 | 0d | 88/08/10 | 88/08/29 | مترمربع | 89/6/15 | 89/6/24 |
| 499 | 1.13.14.10 | اجراي سفيدكاري طبقه 9 | 10d | 2010-09-16 | 2010-09-25 | 498 | 0d | 88/08/30 | 88/09/19 | مترمربع | 89/6/25 | 89/7/3 |
| 500 | 1.13.14.11 | اجراي سفيدكاري طبقه 10 وخرپشته | 10d | 2010-09-26 | 2010-10-05 | 499 | 0d | 88/09/20 | 88/10/09 | مترمربع | 89/7/4 | 89/7/13 |

| ID | WBS | Task | Duration | Start | Finish | Predecessors | Total slack | Free slack | Plan Start | Plan Finish |
| --- | --- | --- | --- | --- | --- | --- | --- | --- | --- | --- |
| 501 | 1.13.15 | **نصب دربهاي اصلي ساختمان** | 105d | 2010-06-28 | 2010-10-10 |  | 4d |  | 89/4/7 | 89/7/18 |
| 502 | 1.13.15.1 | نصب دربهاي اصلي ساختمان طبقه همكف | 5d | 2010-06-28 | 2010-07-02 | 490 | 104d | 5d | 89/4/7 | 89/4/11 |
| 503 | 1.13.15.2 | نصب دربهاي اصلي طبقه اول | 5d | 2010-07-08 | 2010-07-12 | 491 | 94d | 5d | 89/4/17 | 89/4/21 |
| 504 | 1.13.15.3 | نصب دربهاي اصلي طبقه دوم | 5d | 2010-07-18 | 2010-07-22 | 492 | 84d | 5d | 89/4/27 | 89/4/31 |
| 505 | 1.13.15.4 | نصب دربهاي اصلي طبقه سوم | 5d | 2010-07-28 | 2010-08-01 | 493 | 74d | 5d | 89/5/6 | 89/5/10 |
| 506 | 1.13.15.5 | نصب دربهاي اصلي طبقه چهارم | 5d | 2010-08-07 | 2010-08-11 | 494 | 64d | 5d | 89/5/16 | 89/5/20 |
| 507 | 1.13.15.6 | نصب دربهاي اصلي طبقه پنجم | 5d | 2010-08-17 | 2010-08-21 | 495 | 54d | 5d | 89/5/26 | 89/5/30 |
| 508 | 1.13.15.7 | نصب دربهاي اصلي طبقه ششم | 5d | 2010-08-27 | 2010-08-31 | 496 | 44d | 5d | 89/6/5 | 89/6/9 |
| 509 | 1.13.15.8 | نصب دربهاي اصلي طبقه هفتم | 5d | 2010-09-06 | 2010-09-10 | 497 | 34d | 5d | 89/6/15 | 89/6/19 |
| 510 | 1.13.15.9 | نصب دربهاي اصلي طبقه هشتم | 5d | 2010-09-16 | 2010-09-20 | 498 | 24d | 5d | 89/6/25 | 89/6/29 |
| 511 | 1.13.15.10 | نصب دربهاي اصلي طبقه نهم | 5d | 2010-09-26 | 2010-09-30 | 499 | 14d | 5d | 89/7/4 | 89/7/8 |
| 512 | 1.13.15.11 | نصب دربهاي اصلي طبقه دهم | 5d | 2010-10-06 | 2010-10-10 | 500 | 0d |  | 89/7/14 | 89/7/18 |
| 513 | 1.13.16 | **نصب كابينت طبقات** | 110d | 2010-06-28 | 2010-10-15 |  | 1d |  | 89/4/7 | 89/7/23 |
| 514 | 1.13.16.1 | نصب كابينت طبقه همكف | 10d | 2010-06-28 | 2010-07-07 | 490 | 99d | 0d | 89/4/7 | 89/4/16 |
| 515 | 1.13.16.2 | نصب كابينت طبقه اول | 10d | 2010-07-08 | 2010-07-17 | 491 | 89d | 0d | 89/4/17 | 89/4/26 |
| 516 | 1.13.16.3 | نصب كابينت طبقه دوم | 10d | 2010-07-18 | 2010-07-27 | 492 | 79d | 0d | 89/4/27 | 89/5/5 |
| 517 | 1.13.16.4 | نصب كابينت طبقه سوم | 10d | 2010-07-28 | 2010-08-06 | 493 | 69d | 0d | 89/5/6 | 89/5/15 |
| 518 | 1.13.16.5 | نصب كابينت طبقه چهارم | 10d | 2010-08-07 | 2010-08-16 | 494 | 59d | 0d | 89/5/16 | 89/5/25 |
| 519 | 1.13.16.6 | نصب كابينت طبقه پنجم | 10d | 2010-08-17 | 2010-08-26 | 495 | 49d | 0d | 89/5/26 | 89/6/4 |
| 520 | 1.13.16.7 | نصب كابينت طبقه ششم | 10d | 2010-08-27 | 2010-09-05 | 496 | 39d | 0d | 89/6/5 | 89/6/14 |
| 521 | 1.13.16.8 | نصب كابينت طبقه هفتم | 10d | 2010-09-06 | 2010-09-15 | 497 | 29d | 0d | 89/6/15 | 89/6/24 |
| 522 | 1.13.16.9 | نصب كابينت طبقه هشتم | 10d | 2010-09-16 | 2010-09-25 | 498 | 19d | 0d | 89/6/25 | 89/7/3 |
| 523 | 1.13.16.10 | نصب كابينت طبقه نهم | 10d | 2010-09-26 | 2010-10-05 | 499 | 9d | 0d | 89/7/4 | 89/7/13 |
| 524 | 1.13.16.11 | نصب كابينت طبقه دهم | 10d | 2010-10-06 | 2010-10-15 | 500 | 1d |  | 89/7/14 | 89/7/23 |

| ID | WBS | Task | Duration | Start | Finish | Predecessors | Total slack | Free slack | Plan Start | Plan Finish | Text1 | Text2 | واحد |
| --- | --- | --- | --- | --- | --- | --- | --- | --- | --- | --- | --- | --- | --- |
| 525 | 1.13.17 | **نصب نرده طبقات** | 105d | 2010-06-28 | 2010-10-10 |  | 6d |  | 89/4/7 | 89/7/18 |  |  |  |
| 526 | 1.13.17.1 | نصب نرده طبقه همكف | 5d | 2010-06-28 | 2010-07-02 | 490 | 104d | 5d | 89/4/7 | 89/4/11 |  |  |  |
| 527 | 1.13.17.2 | نصب نرده طبقه اول | 5d | 2010-07-08 | 2010-07-12 | 491 | 94d | 5d | 89/4/17 | 89/4/21 |  |  |  |
| 528 | 1.13.17.3 | نصب نرده طبقه دوم | 5d | 2010-07-18 | 2010-07-22 | 492 | 84d | 5d | 89/4/27 | 89/4/31 |  |  |  |
| 529 | 1.13.17.4 | نصب نرده طبقه سوم | 5d | 2010-07-28 | 2010-08-01 | 493 | 74d | 5d | 89/5/6 | 89/5/10 |  |  |  |
| 530 | 1.13.17.5 | نصب نرده طبقه چهارم | 5d | 2010-08-07 | 2010-08-11 | 494 | 64d | 5d | 89/5/16 | 89/5/20 |  |  |  |
| 531 | 1.13.17.6 | نصب نرده طبقه پنجم | 5d | 2010-08-17 | 2010-08-21 | 495 | 54d | 5d | 89/5/26 | 89/5/30 |  |  |  |
| 532 | 1.13.17.7 | نصب نرده طبقه ششم | 5d | 2010-08-27 | 2010-08-31 | 496 | 44d | 5d | 89/6/5 | 89/6/9 |  |  |  |
| 533 | 1.13.17.8 | نصب نرده طبقه هفتم | 5d | 2010-09-06 | 2010-09-10 | 497 | 34d | 5d | 89/6/15 | 89/6/19 |  |  |  |
| 534 | 1.13.17.9 | نصب نرده طبقه هشتم | 5d | 2010-09-16 | 2010-09-20 | 498 | 24d | 5d | 89/6/25 | 89/6/29 |  |  |  |
| 535 | 1.13.17.10 | نصب نرده طبقه نهم | 5d | 2010-09-26 | 2010-09-30 | 499 | 14d | 5d | 89/7/4 | 89/7/8 |  |  |  |
| 536 | 1.13.17.11 | نصب نرده طبقه دهم | 5d | 2010-10-06 | 2010-10-10 | 500 | 6d |  | 89/7/14 | 89/7/18 |  |  |  |
| 537 | 1.13.18 | **نقاشي** | 119d | 2010-07-08 | 2010-11-03 |  | 0d |  | 89/4/17 | 89/8/12 | 88/02/05 | 88/11/14 | درصد |
| 538 | 1.13.18.1 | نقاشي طبفه همكف | 18d | 2010-07-08 | 2010-07-25 | 552, 502, 514, 526, 591, 466 | 99d | 0d | 89/4/17 | 89/5/3 | 88/04/03 | 88/04/22 | مترمربع |
| 539 | 1.13.18.2 | نقاشي طبقه 1 | 18d | 2010-07-18 | 2010-08-04 | 553, 503, 515, 527, 592, 467 | 89d | 0d | 89/4/27 | 89/5/13 | 88/04/23 | 88/05/11 | مترمربع |
| 540 | 1.13.18.3 | نقاشي طبقه 2 | 18d | 2010-07-28 | 2010-08-14 | 504, 516, 593, 468, 553, 528 | 79d | 0d | 89/5/6 | 89/5/23 | 88/05/12 | 88/05/31 | مترمربع |
| 541 | 1.13.18.4 | نقاشي طبقه 3 | 18d | 2010-08-07 | 2010-08-24 | 505, 517, 594, 469, 554, 529 | 69d | 0d | 89/5/16 | 89/6/2 | 88/06/01 | 88/06/20 | مترمربع |
| 542 | 1.13.18.5 | نقاشي طبقه 4 | 18d | 2010-08-17 | 2010-09-03 | 506, 518, 595, 470, 555, 530 | 59d | 0d | 89/5/26 | 89/6/12 | 88/06/21 | 88/07/09 | مترمربع |
| 543 | 1.13.18.6 | نقاشي طبقه 5 | 18d | 2010-08-27 | 2010-09-13 | 507, 519, 471, 596, 556, 531 | 49d | 0d | 89/6/5 | 89/6/22 | 88/07/10 | 88/07/29 | مترمربع |
| 544 | 1.13.18.7 | نقاشي طبقه 6 | 18d | 2010-09-06 | 2010-09-23 | 508, 520, 557, 472, 597, 532 | 39d | 0d | 89/6/15 | 89/7/1 | 88/07/30 | 88/08/19 | مترمربع |
| 545 | 1.13.18.8 | نقاشي طبقه 7 | 18d | 2010-09-16 | 2010-10-03 | 509, 521, 558, 473, 598, 533 | 29d | 0d | 89/6/25 | 89/7/11 | 88/08/20 | 88/09/09 | مترمربع |
| 546 | 1.13.18.9 | نقاشي طبقه 8 | 18d | 2010-09-26 | 2010-10-13 | 510, 522, 559, 474, 599, 534 | 19d | 0d | 89/7/4 | 89/7/21 | 88/09/10 | 88/09/29 | مترمربع |
| 547 | 1.13.18.10 | نقاشي طبقه 9 | 18d | 2010-10-06 | 2010-10-23 | 511, 523, 560, 475, 600, 535 | 9d | 0d | 89/7/14 | 89/8/1 | 88/09/30 | 88/10/19 | مترمربع |
| 548 | 1.13.18.11 | نقاشي طبقه 10 | 18d | 2010-10-17 | 2010-11-03 | 512, 524, 561, 476, 601, 536 | 0d |  | 89/7/25 | 89/8/12 | 88/10/25 | 88/11/14 | مترمربع |

| ID | WBS | Task | Duration | Start | Finish | Predecessors | Total slack | Free slack | Plan Start | Plan Finish | Text1 | Text2 | واحد |
| --- | --- | --- | --- | --- | --- | --- | --- | --- | --- | --- | --- | --- | --- |
| 549 | 1.14 | **فاز دوم تاسيسات مكانيكي** | 243d | 2010-03-06 | 2010-11-11 |  | 0d |  | 88/12/15 | 89/8/20 |  |  |  |
| 550 | 1.14.1 | نصب سيستم آتشنشاني در موتورخانه | 10d | 2010-03-06 | 2010-03-15 | 440 | 233d |  | 88/12/15 | 88/12/24 |  |  |  |
| 551 | 1.14.2 | **اجراي لوله گاز** | 110d | 2010-06-20 | 2010-10-07 |  | 19d |  | 89/3/30 | 89/7/15 | 87/12/26 | 88/08/19 | درصد |
| 552 | 1.14.2.1 | لوله كشي گاز طبقه همکف | 10d | 2010-06-20 | 2010-06-29 | 490SS+2d | 19d | 0d | 89/3/30 | 89/4/8 | 88/01/16 | 88/02/04 | درصد |
| 553 | 1.14.2.2 | لوله كشي گاز طبقه اول | 10d | 2010-06-30 | 2010-07-09 | 491SS+2d, 552 | 19d | 0d | 89/4/9 | 89/4/18 | 88/02/05 | 88/02/24 | درصد |
| 554 | 1.14.2.3 | لوله كشي گاز طبقه دوم | 10d | 2010-07-10 | 2010-07-19 | 492SS+2d, 553 | 19d | 0d | 89/4/19 | 89/4/28 | 88/02/25 | 88/03/13 | درصد |
| 555 | 1.14.2.4 | لوله كشي گاز طبقه سوم | 10d | 2010-07-20 | 2010-07-29 | 493SS+2d, 554 | 19d | 0d | 89/4/29 | 89/5/7 | 88/03/14 | 88/04/02 | درصد |
| 556 | 1.14.2.5 | لوله كشي گاز طبقه چهارم | 10d | 2010-07-30 | 2010-08-08 | 494SS+2d, 555 | 19d | 0d | 89/5/8 | 89/5/17 | 88/04/03 | 88/04/22 | درصد |
| 557 | 1.14.2.6 | لوله كشي گاز طبقه پنجم | 10d | 2010-08-09 | 2010-08-18 | 495SS+2d, 556 | 19d | 0d | 89/5/18 | 89/5/27 | 88/04/23 | 88/05/11 | درصد |
| 558 | 1.14.2.7 | لوله كشي گاز طبقه ششم | 10d | 2010-08-19 | 2010-08-28 | 496SS+2d, 557 | 19d | 0d | 89/5/28 | 89/6/6 | 88/05/12 | 88/05/31 | درصد |
| 559 | 1.14.2.8 | لوله كشي گاز طبقه هفتم | 10d | 2010-08-29 | 2010-09-07 | 558, 497SS+2d | 19d | 0d | 89/6/7 | 89/6/16 | 88/06/01 | 88/06/20 | درصد |
| 560 | 1.14.2.9 | لوله كشي گاز طبقه هشتم | 10d | 2010-09-08 | 2010-09-17 | 559, 498SS+2d | 19d | 0d | 89/6/17 | 89/6/26 | 88/06/21 | 88/07/09 | درصد |
| 561 | 1.14.2.10 | لوله كشي گاز طبقه نهم | 10d | 2010-09-18 | 2010-09-27 | 560, 499SS+2d | 19d | 0d | 89/6/27 | 89/7/5 | 88/07/10 | 88/07/29 | درصد |
| 562 | 1.14.2.11 | لوله كشي گاز طبقه 10 و بام | 10d | 2010-09-28 | 2010-10-07 | 561, 500SS+2d | 35d |  | 89/7/6 | 89/7/15 | 88/07/30 | 88/08/19 | درصد |
| 563 | 1.14.3 | **نصب شيرآلات و رادياتورهاي طبقات** | 109d | 2010-07-26 | 2010-11-11 |  | 0d |  | 89/5/4 | 89/8/20 |  |  |  |
| 564 | 1.14.3.1 | نصب شيرآلات و رادياتورهاي طبقه همكف | 8d | 2010-07-26 | 2010-08-02 | 538 | 101d |  | 89/5/4 | 89/5/11 |  |  |  |
| 565 | 1.14.3.2 | نصب شيرآلات و رادياتورهاي طبقه اول | 8d | 2010-08-05 | 2010-08-12 | 539 | 91d |  | 89/5/14 | 89/5/21 |  |  |  |
| 566 | 1.14.3.3 | نصب شيرآلات و رادياتورهاي طبقه دوم | 8d | 2010-08-15 | 2010-08-22 | 540 | 81d |  | 89/5/24 | 89/5/31 |  |  |  |
| 567 | 1.14.3.4 | نصب شيرآلات و رادياتورهاي طبقه سوم | 8d | 2010-08-25 | 2010-09-01 | 541 | 71d |  | 89/6/3 | 89/6/10 |  |  |  |
| 568 | 1.14.3.5 | نصب شيرآلات و رادياتورهاي طبقه چهارم | 8d | 2010-09-04 | 2010-09-11 | 542 | 61d |  | 89/6/13 | 89/6/20 |  |  |  |
| 569 | 1.14.3.6 | نصب شيرآلات و رادياتورهاي طبقه پنجم | 8d | 2010-09-14 | 2010-09-21 | 543 | 51d |  | 89/6/23 | 89/6/30 |  |  |  |
| 570 | 1.14.3.7 | نصب شيرآلات و رادياتورهاي طبقه ششم | 8d | 2010-09-24 | 2010-10-01 | 544 | 41d |  | 89/7/2 | 89/7/9 |  |  |  |
| 571 | 1.14.3.8 | نصب شيرآلات و رادياتورهاي طبقه هفتم | 8d | 2010-10-04 | 2010-10-11 | 545 | 31d |  | 89/7/12 | 89/7/19 |  |  |  |
| 572 | 1.14.3.9 | نصب شيرآلات و رادياتورهاي طبقه هشتم | 8d | 2010-10-14 | 2010-10-21 | 546 | 21d |  | 89/7/22 | 89/7/29 |  |  |  |
| 573 | 1.14.3.10 | نصب شيرآلات و رادياتورهاي طبقه نهم | 8d | 2010-10-24 | 2010-10-31 | 547 | 11d |  | 89/8/2 | 89/8/9 |  |  |  |
| 574 | 1.14.3.11 | نصب شيرآلات و رادياتورهاي طبقه دهم | 8d | 2010-11-04 | 2010-11-11 | 548 | 0d |  | 89/8/13 | 89/8/20 |  |  |  |

| ID | WBS | Task | Duration | Start | Finish | Predecessors | Total slack | Free slack | Plan Start | Plan Finish |
| --- | --- | --- | --- | --- | --- | --- | --- | --- | --- | --- |
| 575 | 1.14.4 | **نصب پكيج هاي طبقات** | 109d | 2010-07-26 | 2010-11-11 |  | 0d |  | 89/5/4 | 89/8/20 |
| 576 | 1.14.4.1 | نصب پكيج هاي طبقه همكف | 10d | 2010-07-26 | 2010-08-04 | 538 | 99d |  | 89/5/4 | 89/5/13 |
| 577 | 1.14.4.2 | نصب پكيج هاي طبقه اول | 10d | 2010-08-05 | 2010-08-14 | 539 | 89d |  | 89/5/14 | 89/5/23 |
| 578 | 1.14.4.3 | نصب پكيج هاي طبقه دوم | 10d | 2010-08-15 | 2010-08-24 | 540 | 79d |  | 89/5/24 | 89/6/2 |
| 579 | 1.14.4.4 | نصب پكيج هاي طبقه سوم | 10d | 2010-08-25 | 2010-09-03 | 541 | 69d |  | 89/6/3 | 89/6/12 |
| 580 | 1.14.4.5 | نصب پكيج هاي طبقه چهارم | 10d | 2010-09-04 | 2010-09-13 | 542 | 59d |  | 89/6/13 | 89/6/22 |
| 581 | 1.14.4.6 | نصب پكيج هاي طبقه پنجم | 10d | 2010-09-14 | 2010-09-23 | 543 | 49d |  | 89/6/23 | 89/7/1 |
| 582 | 1.14.4.7 | نصب پكيج هاي طبقه ششم | 10d | 2010-09-24 | 2010-10-03 | 544 | 39d |  | 89/7/2 | 89/7/11 |
| 583 | 1.14.4.8 | نصب پكيج هاي طبقه هفتم | 10d | 2010-10-04 | 2010-10-13 | 545 | 29d |  | 89/7/12 | 89/7/21 |
| 584 | 1.14.4.9 | نصب پكيج هاي طبقه هشتم | 10d | 2010-10-14 | 2010-10-23 | 546 | 19d |  | 89/7/22 | 89/8/1 |
| 585 | 1.14.4.10 | نصب پكيج هاي طبقه نهم | 10d | 2010-10-24 | 2010-11-02 | 547 | 9d |  | 89/8/2 | 89/8/11 |
| 586 | 1.14.4.11 | نصب پكيج هاي طبقه دهم | 8d | 2010-11-04 | 2010-11-11 | 548 | 0d |  | 89/8/13 | 89/8/20 |
| 587 | 1.15 | **فاز دوم تاسيسات برقي** | 177d | 2010-05-19 | 2010-11-11 |  | 0d |  | 89/2/29 | 89/8/20 |
| 588 | 1.15.1 | **سيم كشي طبقات** | 171d | 2010-05-19 | 2010-11-05 |  | 0d |  | 89/2/29 | 89/8/14 |
| 589 | 1.15.1.1 | سيم كشي زيرزمين دوم | 10d | 2010-10-27 | 2010-11-05 | 590 | 0d |  | 89/8/5 | 89/8/14 |
| 590 | 1.15.1.2 | سيم كشي زيرزمين اول | 10d | 2010-10-17 | 2010-10-26 | 601 | 0d |  | 89/7/25 | 89/8/4 |
| 591 | 1.15.1.3 | سيم كشي طبقه همكف | 10d | 2010-05-19 | 2010-05-28 | 402 | 41d | 0d | 89/2/29 | 89/3/7 |
| 592 | 1.15.1.4 | سيم كشي طبقه اول | 10d | 2010-05-29 | 2010-06-07 | 403, 591 | 41d | 0d | 89/3/8 | 89/3/17 |
| 593 | 1.15.1.5 | سيم كشي طبقه دوم | 10d | 2010-06-08 | 2010-06-17 | 404, 592 | 41d | 4d | 89/3/18 | 89/3/27 |
| 594 | 1.15.1.6 | سيم كشي طبقه سوم | 10d | 2010-06-22 | 2010-07-01 | 405, 593 | 37d | 5d | 89/4/1 | 89/4/10 |
| 595 | 1.15.1.7 | سيم كشي طبقه چهارم | 10d | 2010-07-07 | 2010-07-16 | 406, 594 | 32d | 5d | 89/4/16 | 89/4/25 |
| 596 | 1.15.1.8 | سيم كشي طبقه پنجم | 10d | 2010-07-22 | 2010-07-31 | 407, 595 | 27d | 5d | 89/4/31 | 89/5/9 |
| 597 | 1.15.1.9 | سيم كشي طبقه ششم | 10d | 2010-08-06 | 2010-08-15 | 408, 596 | 22d | 5d | 89/5/15 | 89/5/24 |
| 598 | 1.15.1.10 | سيم كشي طبقه هفتم | 10d | 2010-08-21 | 2010-08-30 | 409, 597 | 17d | 5d | 89/5/30 | 89/6/8 |
| 599 | 1.15.1.11 | سيم كشي طبقه هشتم | 10d | 2010-09-05 | 2010-09-14 | 410, 598 | 12d | 5d | 89/6/14 | 89/6/23 |
| 600 | 1.15.1.12 | سيم كشي طبقه نهم | 10d | 2010-09-20 | 2010-09-29 | 411, 599 | 7d | 6d | 89/6/29 | 89/7/7 |
| 601 | 1.15.1.13 | سيم كشي طبقه دهم و خرپشته | 10d | 2010-10-07 | 2010-10-16 | 412, 600 | 0d |  | 89/7/15 | 89/7/24 |

| ID | WBS | Task | Duration | Start | Finish | Predecessors | Total slack | Plan Start | Plan Finish |
| --- | --- | --- | --- | --- | --- | --- | --- | --- | --- |
| 602 | 1.15.2 | **نصب كليد و پريز لوازم برقي و هواكش** | 109d | 2010-07-26 | 2010-11-11 |  | 0d | 89/5/4 | 89/8/20 |
| 603 | 1.15.2.1 | نصب كليد و پريز لوازم برقي و هواكش زيرزمين دوم | 6d | 2010-11-06 | 2010-11-11 | 589 | 0d | 89/8/15 | 89/8/20 |
| 604 | 1.15.2.2 | نصب كليد و پريز لوازم برقي و هواكش زيرزمين اول | 10d | 2010-10-27 | 2010-11-05 | 590 | 6d | 89/8/5 | 89/8/14 |
| 605 | 1.15.2.3 | نصب كليد و پريز لوازم برقي و هواكش طبقه همكف | 10d | 2010-07-26 | 2010-08-04 | 538 | 99d | 89/5/4 | 89/5/13 |
| 606 | 1.15.2.4 | نصب كليد و پريز لوازم برقي و هواكش طبقه اول | 10d | 2010-08-05 | 2010-08-14 | 539 | 89d | 89/5/14 | 89/5/23 |
| 607 | 1.15.2.5 | نصب كليد و پريز لوازم برقي و هواكش طبقه دوم | 10d | 2010-08-15 | 2010-08-24 | 540 | 79d | 89/5/24 | 89/6/2 |
| 608 | 1.15.2.6 | نصب كليد و پريز لوازم برقي و هواكش طبقه سوم | 10d | 2010-08-25 | 2010-09-03 | 541 | 69d | 89/6/3 | 89/6/12 |
| 609 | 1.15.2.7 | نصب كليد و پريز لوازم برقي و هواكش طبقه چهارم | 10d | 2010-09-04 | 2010-09-13 | 542 | 59d | 89/6/13 | 89/6/22 |
| 610 | 1.15.2.8 | نصب كليد و پريز لوازم برقي و هواكش طبقه پنجم | 10d | 2010-09-14 | 2010-09-23 | 543 | 49d | 89/6/23 | 89/7/1 |
| 611 | 1.15.2.9 | نصب كليد و پريز لوازم برقي و هواكش طبقه ششم | 10d | 2010-09-24 | 2010-10-03 | 544 | 39d | 89/7/2 | 89/7/11 |
| 612 | 1.15.2.10 | نصب كليد و پريز لوازم برقي و هواكش طبقه هفتم | 10d | 2010-10-04 | 2010-10-13 | 545 | 29d | 89/7/12 | 89/7/21 |
| 613 | 1.15.2.11 | نصب كليد و پريز لوازم برقي و هواكش طبقه هشتم | 10d | 2010-10-14 | 2010-10-23 | 546 | 19d | 89/7/22 | 89/8/1 |
| 614 | 1.15.2.12 | نصب كليد و پريز لوازم برقي و هواكش طبقه نهم | 10d | 2010-10-24 | 2010-11-02 | 547 | 9d | 89/8/2 | 89/8/11 |
| 615 | 1.15.2.13 | نصب كليد و پريز لوازم برقي و هواكش طبقه دهم | 6d | 2010-11-04 | 2010-11-09 | 548 | 2d | 89/8/13 | 89/8/18 |
| 616 | 1.15.3 | **ساخت و نصب تابلوهاي برقي** | 109d | 2010-07-26 | 2010-11-11 |  | 0d | 89/5/4 | 89/8/20 |
| 617 | 1.15.3.1 | ساخت و نصب تابلوهاي برقي زيرزمين دوم | 6d | 2010-11-06 | 2010-11-11 | 589 | 0d | 89/8/15 | 89/8/20 |
| 618 | 1.15.3.2 | ساخت و نصب تابلوهاي برقي زيرزمين اول | 10d | 2010-10-27 | 2010-11-05 | 590 | 6d | 89/8/5 | 89/8/14 |
| 619 | 1.15.3.3 | ساخت و نصب تابلوهاي برقي طبقه همكف | 10d | 2010-07-26 | 2010-08-04 | 538 | 99d | 89/5/4 | 89/5/13 |
| 620 | 1.15.3.4 | ساخت و نصب تابلوهاي برقي طبقه اول | 10d | 2010-08-05 | 2010-08-14 | 539 | 89d | 89/5/14 | 89/5/23 |
| 621 | 1.15.3.5 | ساخت و نصب تابلوهاي برقي طبقه دوم | 10d | 2010-08-15 | 2010-08-24 | 540 | 79d | 89/5/24 | 89/6/2 |
| 622 | 1.15.3.6 | ساخت و نصب تابلوهاي برقي طبقه سوم | 10d | 2010-08-25 | 2010-09-03 | 541 | 69d | 89/6/3 | 89/6/12 |
| 623 | 1.15.3.7 | ساخت و نصب تابلوهاي برقي طبقه چهارم | 10d | 2010-09-04 | 2010-09-13 | 542 | 59d | 89/6/13 | 89/6/22 |
| 624 | 1.15.3.8 | ساخت و نصب تابلوهاي برقي طبقه پنجم | 10d | 2010-09-14 | 2010-09-23 | 543 | 49d | 89/6/23 | 89/7/1 |
| 625 | 1.15.3.9 | ساخت و نصب تابلوهاي برقي طبقه ششم | 10d | 2010-09-24 | 2010-10-03 | 544 | 39d | 89/7/2 | 89/7/11 |
| 626 | 1.15.3.10 | ساخت و نصب تابلوهاي برقي طبقه هفتم | 10d | 2010-10-04 | 2010-10-13 | 545 | 29d | 89/7/12 | 89/7/21 |
| 627 | 1.15.3.11 | ساخت و نصب تابلوهاي برقي طبقه هشتم | 10d | 2010-10-14 | 2010-10-23 | 546 | 19d | 89/7/22 | 89/8/1 |
| 628 | 1.15.3.12 | ساخت و نصب تابلوهاي برقي طبقه نهم | 10d | 2010-10-24 | 2010-11-02 | 547 | 9d | 89/8/2 | 89/8/11 |
| 629 | 1.15.3.13 | ساخت و نصب تابلوهاي برقي طبقه دهم | 8d | 2010-11-04 | 2010-11-11 | 548 | 0d | 89/8/13 | 89/8/20 |

| ID | WBS | Task | Type | Duration | Start | Finish | Predecessors | Total slack | Free slack | Plan Start | Plan Finish |
| --- | --- | --- | --- | --- | --- | --- | --- | --- | --- | --- | --- |
| 630 | 1.15.4 | **نصب و راه اندازي سيستم اعلام حريق و درب بازكن** |  | 109d | 2010-07-26 | 2010-11-11 |  | 0d |  | 89/5/4 | 89/8/20 |
| 631 | 1.15.4.1 | نصب و راه اندازي سيستم اعلام حريق و درب بازكن زيرزمين دوم |  | 6d | 2010-11-06 | 2010-11-11 | 589 | 0d |  | 89/8/15 | 89/8/20 |
| 632 | 1.15.4.2 | نصب و راه اندازي سيستم اعلام حريق و درب بازكن زيرزمين اول |  | 10d | 2010-10-27 | 2010-11-05 | 590 | 6d |  | 89/8/5 | 89/8/14 |
| 633 | 1.15.4.3 | نصب و راه اندازي سيستم اعلام حريق و درب بازكن طبقه همكف |  | 10d | 2010-07-26 | 2010-08-04 | 538 | 99d |  | 89/5/4 | 89/5/13 |
| 634 | 1.15.4.4 | نصب و راه اندازي سيستم اعلام حريق و درب بازكن طبقه اول |  | 10d | 2010-08-05 | 2010-08-14 | 539 | 89d |  | 89/5/14 | 89/5/23 |
| 635 | 1.15.4.5 | نصب و راه اندازي سيستم اعلام حريق و درب بازكن طبقه دوم |  | 10d | 2010-08-15 | 2010-08-24 | 540 | 79d |  | 89/5/24 | 89/6/2 |
| 636 | 1.15.4.6 | نصب و راه اندازي سيستم اعلام حريق و درب بازكن طبقه سوم |  | 10d | 2010-08-25 | 2010-09-03 | 541 | 69d |  | 89/6/3 | 89/6/12 |
| 637 | 1.15.4.7 | نصب و راه اندازي سيستم اعلام حريق و درب بازكن طبقه چهارم |  | 10d | 2010-09-04 | 2010-09-13 | 542 | 59d |  | 89/6/13 | 89/6/22 |
| 638 | 1.15.4.8 | نصب و راه اندازي سيستم اعلام حريق و درب بازكن طبقه پنجم |  | 10d | 2010-09-14 | 2010-09-23 | 543 | 49d |  | 89/6/23 | 89/7/1 |
| 639 | 1.15.4.9 | نصب و راه اندازي سيستم اعلام حريق و درب بازكن طبقه ششم |  | 10d | 2010-09-24 | 2010-10-03 | 544 | 39d |  | 89/7/2 | 89/7/11 |
| 640 | 1.15.4.10 | نصب و راه اندازي سيستم اعلام حريق و درب بازكن طبقه هفتم |  | 10d | 2010-10-04 | 2010-10-13 | 545 | 29d |  | 89/7/12 | 89/7/21 |
| 641 | 1.15.4.11 | نصب و راه اندازي سيستم اعلام حريق و درب بازكن طبقه هشتم |  | 10d | 2010-10-14 | 2010-10-23 | 546 | 19d |  | 89/7/22 | 89/8/1 |
| 642 | 1.15.4.12 | نصب و راه اندازي سيستم اعلام حريق و درب بازكن طبقه نهم |  | 10d | 2010-10-24 | 2010-11-02 | 547 | 9d |  | 89/8/2 | 89/8/11 |
| 643 | 1.15.4.13 | نصب و راه اندازي سيستم اعلام حريق و درب بازكن طبقه دهم |  | 8d | 2010-11-04 | 2010-11-11 | 548 | 0d |  | 89/8/13 | 89/8/20 |
| 644 | 1.16 | **نصب و راه اندازي آسانسور و ژنراتور** |  | 70d | 2010-09-01 | 2010-11-09 |  | 0d |  | 89/6/10 | 89/8/18 |
| 645 | 1.16.1 | آهن كشي آسانسور |  | 20d | 2010-09-01 | 2010-09-20 | 646FF-20d | 50d |  | 89/6/10 | 89/6/29 |
| 646 | 1.16.2 | نصب درب و ريل |  | 20d | 2010-09-21 | 2010-10-10 | 512FF | 0d |  | 89/6/30 | 89/7/18 |
| 647 | 1.16.3 | نصب و راه اندازي كامل آسانسور |  | 20d | 2010-10-11 | 2010-10-30 | 646 | 0d |  | 89/7/19 | 89/8/8 |
| 648 | 1.16.4 | نصب و راه اندازي ژنراتور |  | 10d | 2010-10-31 | 2010-11-09 | 647 | 0d |  | 89/8/9 | 89/8/18 |
| 649 | 1.17 | **محوطه سازي** |  | 215d | 2010-03-04 | 2010-10-12 |  | 30d |  | 88/12/13 | 89/7/20 |
| 650 | 1.17.1 | ديواركشي پيرامون |  | 40d | 2010-05-11 | 2010-06-19 | 651FF-70d | 145d | 0d | 89/2/21 | 89/3/29 |
| 651 | 1.17.2 | محوطه سازي مجتمع |  | 60d | 2010-06-30 | 2010-08-28 | 652FF-45d | 75d | 0d | 89/4/9 | 89/6/6 |
| 652 | 1.17.3 | اجراي تاسيسات محوطه |  | 35d | 2010-09-08 | 2010-10-12 | 654FF-30d | 30d | 0d | 89/6/17 | 89/7/20 |
| 653 | 1.17.4 | اجرا ساختمان نگهباني و سردرب |  | 50d | 2010-03-04 | 2010-04-30 | 650FF-50d | 195d |  | 88/12/13 | 89/2/10 |
| 654 | 1.18 | برچيدن كارگاه بلوك 1 |  | 10d | 2010-11-02 | 2010-11-11 | 644FS-8d | 0d |  | 89/8/11 | 89/8/20 |
| 655 | 1.19 | اتمام بلوك 1 | milestone | 0d | 2010-11-11 | 2010-11-11 | 654 | 0d |  | 89/8/20 | 89/8/20 |

| ID | WBS | Task | Duration | Start | Finish | Predecessors | Total slack | Free slack | Plan Start | Plan Finish | Text1 | Text2 | واحد |
| --- | --- | --- | --- | --- | --- | --- | --- | --- | --- | --- | --- | --- | --- |
| 656 | 2 | **بلوك 2** | 900d | 2008-05-09 | 2010-11-11 |  | 0d |  | 87/2/20 | 89/8/20 |  |  |  |
| 657 | 2.1 | **طراحي پروژه** | 70d | 2008-05-09 | 2008-07-17 |  | 0d |  | 87/2/20 | 87/4/27 |  |  |  |
| 658 | 2.1.1 | طراحي فاز 1 و تاييد شهرداري | 35d | 2008-05-09 | 2008-06-12 |  | 0d |  | 87/2/20 | 87/3/23 |  |  |  |
| 659 | 2.1.2 | طراحي كامل (فاز 2) و تاييد شهرداري | 35d | 2008-06-13 | 2008-07-17 | 658 | 0d |  | 87/3/24 | 87/4/27 |  |  |  |
| 660 | 2.2 | اخذ پروانه | 5d | 2008-07-18 | 2008-07-22 | 659 | 0d |  | 87/4/28 | 87/5/1 |  |  |  |
| 661 | 2.3 | **آزمايشگاه مكانيك خاك و نقشه برداري** | 10d | 2008-07-23 | 2008-08-01 |  | 4d |  | 87/5/2 | 87/5/11 |  |  |  |
| 662 | 2.3.1 | آزمايشگاه مكانيك خاك | 5d | 2008-07-23 | 2008-07-27 | 660 | 820d |  | 87/5/2 | 87/5/6 |  |  |  |
| 663 | 2.3.2 | نقشه برداري | 10d | 2008-07-23 | 2008-08-01 | 660 | 4d |  | 87/5/2 | 87/5/11 |  |  |  |
| 664 | 2.4 | **انشعابات** | 14d | 2008-07-23 | 2008-08-05 |  | 0d |  | 87/5/2 | 87/5/15 |  |  |  |
| 665 | 2.4.1 | انشعاب آب و فاضلاب | 14d | 2008-07-23 | 2008-08-05 | 660 | 0d |  | 87/5/2 | 87/5/15 |  |  |  |
| 666 | 2.4.2 | انشعاب برق | 14d | 2008-07-23 | 2008-08-05 | 660 | 0d |  | 87/5/2 | 87/5/15 |  |  |  |
| 667 | 2.4.3 | انشعاب گاز | 14d | 2008-07-23 | 2008-08-05 | 660 | 0d |  | 87/5/2 | 87/5/15 |  |  |  |
| 668 | 2.4.4 | انشعاب تلفن | 14d | 2008-07-23 | 2008-08-05 | 660 | 0d |  | 87/5/2 | 87/5/15 |  |  |  |
| 669 | 2.5 | تجهيز كارگاه | 14d | 2008-07-23 | 2008-08-05 | 660 | 0d |  | 87/5/2 | 87/5/15 | 86/11/16 | 86/12/25 | درصد |
| 670 | 2.6 | **خاكبرداري** | 15d | 2008-08-06 | 2008-08-20 |  | 0d |  | 87/5/16 | 87/5/30 | 86/12/26 | 87/02/05 | درصد |
| 671 | 2.6.1 | خاکبرداري با ماشين | 15d | 2008-08-06 | 2008-08-20 | 663, 664, 669 | 0d |  | 87/5/16 | 87/5/30 | 86/12/26 | 87/01/16 | مترمکعب |
| 672 | 2.6.2 | خاكبرداري دستي و رگلاژ | 15d | 2008-08-06 | 2008-08-20 | 671FF | 0d |  | 87/5/16 | 87/5/30 | 87/01/17 | 87/02/05 |  |
| 673 | 2.7 | **اجراي فونداسيون** | 21d | 2008-08-21 | 2008-09-10 |  | 0d |  | 87/5/31 | 87/6/20 | 87/03/05 | 87/04/08 | درصد |
| 674 | 2.7.1 | بتن مگر | 5d | 2008-08-21 | 2008-08-25 | 670 | 0d |  | 87/5/31 | 87/6/4 | 87/03/06 | 87/03/10 | مترمکعب |
| 675 | 2.7.2 | آرماتور بندي فونداسيون | 10d | 2008-08-26 | 2008-09-04 | 674 | 0d |  | 87/6/5 | 87/6/14 | 87/03/11 | 87/03/20 | تن |
| 676 | 2.7.3 | قالب بندي فونداسيون | 10d | 2008-08-27 | 2008-09-05 | 675SS+1d | 0d |  | 87/6/6 | 87/6/15 | 87/03/07 | 87/03/21 | مترمربع |
| 677 | 2.7.4 | بتن ريزي فونداسيون | 5d | 2008-09-06 | 2008-09-10 | 676 | 0d |  | 87/6/16 | 87/6/20 | 87/03/22 | 87/04/08 | مترمکعب |
| 678 | 2.8 | **اجراي اسكلت سازه** | 412d | 2008-09-13 | 2009-11-07 |  | 0d |  | 87/6/23 | 88/8/16 |  |  | درصد |
| 679 | 2.8.1 | **آرماتوربندي ستونها و ديوارها** | 401d | 2008-09-13 | 2009-10-27 |  | 0d |  | 87/6/23 | 88/8/5 |  |  |  |
| 680 | 2.8.1.1 | آرماتور بندي ستونها و ديوارهاي زيرزمين دوم | 5d | 2008-09-13 | 2008-09-17 | 673FS+2d | 0d |  | 87/6/23 | 87/6/27 |  |  | تن |
| 681 | 2.8.1.2 | آرماتور بندي ستونها و ديوارهاي زيرزمين اول | 5d | 2008-10-16 | 2008-10-20 | 807 | 54d | 0d | 87/7/25 | 87/7/29 | 87/04/09 | 87/04/18 | تن |
| 682 | 2.8.1.3 | آرماتور بندي ستونها و ديوارهاي همكف | 5d | 2008-11-18 | 2008-11-22 | 808 | 54d | 0d | 87/8/28 | 87/9/2 | 87/05/11 | 87/05/20 | تن |
| 683 | 2.8.1.4 | آرماتور بندي ستونها و ديوارهاي طبقه اول | 5d | 2008-12-21 | 2008-12-25 | 809 | 61d | 0d | 87/10/1 | 87/10/5 | 87/06/13 | 87/06/22 | تن |
| 684 | 2.8.1.5 | آرماتور بندي ستونها و ديوارهاي طبقه دوم | 5d | 2009-01-23 | 2009-01-27 | 810 | 68d | 0d | 87/11/4 | 87/11/8 | 87/07/15 | 87/07/24 | تن |
| 685 | 2.8.1.6 | آرماتور بندي ستونها و ديوارهاي طبقه سوم | 5d | 2009-02-25 | 2009-03-01 | 811 | 75d | 0d | 87/12/7 | 87/12/11 | 87/08/18 | 87/08/27 | تن |
| 686 | 2.8.1.7 | آرماتور بندي ستونها وديوارهاي طبقه چهارم | 5d | 2009-04-08 | 2009-04-12 | 812 | 82d | 0d | 88/1/19 | 88/1/23 | 87/09/21 | 87/09/30 | تن |
| 687 | 2.8.1.8 | آرماتور بندي ستونها و ديوارهاي طبقه پنجم | 5d | 2009-05-11 | 2009-05-15 | 813 | 88d | 0d | 88/2/21 | 88/2/25 | 87/10/24 | 87/11/03 | تن |
| 688 | 2.8.1.9 | آرماتور بندي ستونها و ديوارهاي طبقه ششم | 5d | 2009-06-13 | 2009-06-17 | 814 | 88d | 0d | 88/3/23 | 88/3/27 | 87/11/27 | 87/12/06 | تن |
| 689 | 2.8.1.10 | آرماتور بندي ستونها و ديوارهاي طبقه هفتم | 5d | 2009-07-16 | 2009-07-20 | 815 | 93d | 0d | 88/4/25 | 88/4/29 | 87/12/30 | 88/01/09 | تن |
| 690 | 2.8.1.11 | آرماتور بندي ستونها و ديوارهاي طبقه هشتم | 5d | 2009-08-18 | 2009-08-22 | 816 | 100d | 0d | 88/5/27 | 88/5/31 | 88/02/02 | 88/02/11 | تن |
| 691 | 2.8.1.12 | آرماتور بندي ستونها و ديوارهاي طبقه نهم | 5d | 2009-09-20 | 2009-09-24 | 817 | 107d | 0d | 88/6/29 | 88/7/2 | 88/02/31 | 88/03/09 | تن |
| 692 | 2.8.1.13 | آرماتور بندي ستونها و ديوارهاي طبقه دهم و خرپشته | 5d | 2009-10-23 | 2009-10-27 | 818 | 114d | 0d | 88/8/1 | 88/8/5 | 88/04/02 | 88/04/11 | تن |

| ID | WBS | Task | Duration | Start | Finish | Predecessors | Total slack | Free slack | Plan Start | Plan Finish | واحد | Text1 | Text2 |
| --- | --- | --- | --- | --- | --- | --- | --- | --- | --- | --- | --- | --- | --- |
| 693 | 2.8.2 | **قالب بندي ستونها و ديوارها** | 401d | 2008-09-14 | 2009-10-28 |  | 0d |  | 87/6/24 | 88/8/6 |  |  |  |
| 694 | 2.8.2.1 | قالب بندي ستونها و ديوارهاي زيرزمين دوم | 5d | 2008-09-14 | 2008-09-18 | 680SS+1d | 0d |  | 87/6/24 | 87/6/28 | مترمربع |  |  |
| 695 | 2.8.2.2 | قالب بندي ستونها و ديوارها ي زيرزمين اول | 5d | 2008-10-17 | 2008-10-21 | 681SS+1d | 54d | 0d | 87/7/26 | 87/7/30 | مترمربع | 87/04/10 | 87/04/19 |
| 696 | 2.8.2.3 | قالب بندي ستونها و ديوارهاي همكف | 5d | 2008-11-19 | 2008-11-23 | 682SS+1d | 54d | 0d | 87/8/29 | 87/9/3 | مترمربع | 87/05/12 | 87/05/21 |
| 697 | 2.8.2.4 | قالب بندي ستونها و ديوارهاي طبقه اول | 5d | 2008-12-22 | 2008-12-26 | 683SS+1d | 61d | 0d | 87/10/2 | 87/10/6 | مترمربع | 87/06/14 | 87/06/23 |
| 698 | 2.8.2.5 | قالب بندي ستونها و ديوارهاي طبقه دوم | 5d | 2009-01-24 | 2009-01-28 | 684SS+1d | 68d | 0d | 87/11/5 | 87/11/9 | مترمربع | 87/07/16 | 87/07/25 |
| 699 | 2.8.2.6 | قالب بندي ستونها و ديوارهاي طبقه سوم | 5d | 2009-02-26 | 2009-03-02 | 685SS+1d | 75d | 0d | 87/12/8 | 87/12/12 | مترمربع | 87/08/19 | 87/08/28 |
| 700 | 2.8.2.7 | قالب بندي ستونها و ديوارهاي طبقه چهارم | 5d | 2009-04-09 | 2009-04-13 | 686SS+1d | 82d | 0d | 88/1/20 | 88/1/24 | مترمربع | 87/09/22 | 87/10/01 |
| 701 | 2.8.2.8 | قالب بندي ستونها و ديوارهاي طبقه پنجم | 5d | 2009-05-12 | 2009-05-16 | 687SS+1d | 88d | 0d | 88/2/22 | 88/2/26 | مترمربع | 87/10/25 | 87/11/04 |
| 702 | 2.8.2.9 | قالب بندي ستونها و ديوارهاي طبقه ششم | 5d | 2009-06-14 | 2009-06-18 | 688SS+1d | 88d | 0d | 88/3/24 | 88/3/28 | مترمربع | 87/11/28 | 87/12/07 |
| 703 | 2.8.2.10 | قالب بندي ستونها و ديوارهاي طبقه هفتم | 5d | 2009-07-17 | 2009-07-21 | 689SS+1d | 93d | 0d | 88/4/26 | 88/4/30 | مترمربع | 88/01/01 | 88/01/10 |
| 704 | 2.8.2.11 | قالب بندي ستونها و ديوارهاي طبقه هشتم | 5d | 2009-08-19 | 2009-08-23 | 690SS+1d | 100d | 0d | 88/5/28 | 88/6/1 | مترمربع | 88/02/03 | 88/02/12 |
| 705 | 2.8.2.12 | قالب بندي ستونها و ديوارهاي طبقه نهم | 5d | 2009-09-21 | 2009-09-25 | 691SS+1d | 107d | 0d | 88/6/30 | 88/7/3 | مترمربع | 88/03/01 | 88/03/10 |
| 706 | 2.8.2.13 | قالب بندي ستونها و ديوارهاي طبقه دهم و خرپشته | 5d | 2009-10-24 | 2009-10-28 | 692SS+1d | 114d | 0d | 88/8/2 | 88/8/6 | مترمربع | 88/04/03 | 88/04/12 |
| 707 | 2.8.3 | **بتن ريزي ستونها و ديوارها** | 398d | 2008-09-19 | 2009-10-30 |  | 0d |  | 87/6/29 | 88/8/8 |  |  |  |
| 708 | 2.8.3.1 | بتن ريزي ستونها و ديوارهاي زيرزمين دوم | 2d | 2008-09-19 | 2008-09-20 | 694 | 0d |  | 87/6/29 | 87/6/30 | مترمکعب |  |  |
| 709 | 2.8.3.2 | بتن ريزي ستونها و ديوارهاي زيرزمين اول | 2d | 2008-10-22 | 2008-10-23 | 695 | 54d | 0d | 87/8/1 | 87/8/2 | مترمکعب | 87/04/19 | 87/04/28 |
| 710 | 2.8.3.3 | بتن ريزي ستونها و ديوارهاي همكف | 2d | 2008-11-24 | 2008-11-25 | 696 | 54d | 0d | 87/9/4 | 87/9/5 | مترمکعب | 87/05/21 | 87/05/30 |
| 711 | 2.8.3.4 | بتن ريزي ستونها و ديوارهاي طبقه اول | 2d | 2008-12-27 | 2008-12-28 | 697 | 61d | 0d | 87/10/7 | 87/10/8 | مترمکعب | 87/06/23 | 87/07/01 |
| 712 | 2.8.3.5 | بتن ريزي ستونها و ديوارهاي طبقه دوم | 2d | 2009-01-29 | 2009-01-30 | 698 | 68d | 0d | 87/11/10 | 87/11/11 | مترمکعب | 87/07/24 | 87/07/25 |
| 713 | 2.8.3.6 | بتن ريزي ستونها و ديوارهاي طبقه سوم | 2d | 2009-03-03 | 2009-03-04 | 699 | 75d | 0d | 87/12/13 | 87/12/14 | مترمکعب | 87/08/27 | 87/08/28 |
| 714 | 2.8.3.7 | بتن ريزي ستونها و ديوارهاي طبقه چهارم | 2d | 2009-04-14 | 2009-04-15 | 700 | 82d | 0d | 88/1/25 | 88/1/26 | مترمکعب | 87/09/30 | 87/10/01 |
| 715 | 2.8.3.8 | بتن ريزي ستونها و ديوارهاي طبقه پنجم | 2d | 2009-05-17 | 2009-05-18 | 701 | 88d | 0d | 88/2/27 | 88/2/28 | مترمکعب | 87/11/03 | 87/11/04 |
| 716 | 2.8.3.9 | بتن ريزي ستونها و ديوارهاي طبقه ششم | 2d | 2009-06-19 | 2009-06-20 | 702 | 88d | 0d | 88/3/29 | 88/3/30 | مترمکعب | 87/12/06 | 87/12/07 |
| 717 | 2.8.3.10 | بتن ريزي ستونها و ديوارهاي طبقه هفتم | 2d | 2009-07-22 | 2009-07-23 | 703 | 93d | 0d | 88/4/31 | 88/5/1 | مترمکعب | 88/01/09 | 88/01/10 |
| 718 | 2.8.3.11 | بتن ريزي ستونها و ديوارهاي طبقه هشتم | 2d | 2009-08-24 | 2009-08-25 | 704 | 100d | 0d | 88/6/2 | 88/6/3 | مترمکعب | 88/02/11 | 88/02/12 |
| 719 | 2.8.3.12 | بتن ريزي ستونها و ديوارهاي طبقه نهم | 2d | 2009-09-26 | 2009-09-27 | 705 | 107d | 0d | 88/7/4 | 88/7/5 | مترمکعب | 88/03/09 | 88/03/10 |
| 720 | 2.8.3.13 | بتن ريزي ستونها و ديوارهاي طبقه دهم | 2d | 2009-10-29 | 2009-10-30 | 706 | 114d | 0d | 88/8/7 | 88/8/8 | مترمکعب | 88/04/11 | 88/04/12 |

| ID | WBS | Task | Duration | Start | Finish | Predecessors | Total slack | Free slack | Plan Start | Plan Finish | واحد | Text1 | Text2 |
| --- | --- | --- | --- | --- | --- | --- | --- | --- | --- | --- | --- | --- | --- |
| 721 | 2.8.4 | **آرماتوربندي تيرها** | 401d | 2008-09-21 | 2009-11-04 |  | 0d |  | 87/6/31 | 88/8/13 |  |  |  |
| 722 | 2.8.4.1 | آرماتوربندي تيرهاي زيرزمين دوم | 5d | 2008-09-21 | 2008-09-25 | 708 | 0d |  | 87/6/31 | 87/7/4 | تن |  |  |
| 723 | 2.8.4.2 | آرماتوربندي تيرهاي زيرزمين اول | 5d | 2008-10-24 | 2008-10-28 | 709 | 54d | 0d | 87/8/3 | 87/8/7 | تن |  |  |
| 724 | 2.8.4.3 | آرماتوربندي تيرهاي همكف | 5d | 2008-11-26 | 2008-11-30 | 710 | 54d | 0d | 87/9/6 | 87/9/10 | تن |  |  |
| 725 | 2.8.4.4 | آرماتوربندي تيرهاي طبقه اول | 5d | 2008-12-29 | 2009-01-02 | 711 | 61d | 0d | 87/10/9 | 87/10/13 | تن |  |  |
| 726 | 2.8.4.5 | آرماتوربندي تيرهاي طبقه دوم | 5d | 2009-01-31 | 2009-02-04 | 712 | 68d | 0d | 87/11/12 | 87/11/16 | تن | 87/07/25 | 87/08/04 |
| 727 | 2.8.4.6 | آرماتوربندي تيرها ي طبقه سوم | 5d | 2009-03-05 | 2009-03-09 | 713 | 75d | 0d | 87/12/15 | 87/12/19 | تن | 87/08/28 | 87/09/07 |
| 728 | 2.8.4.7 | آرماتوربندي تيرهاي طبقه چهارم | 5d | 2009-04-16 | 2009-04-20 | 714 | 82d | 0d | 88/1/27 | 88/1/31 | تن | 87/10/01 | 87/10/10 |
| 729 | 2.8.4.8 | آرماتوربندي تيرهاي طبقه پنجم | 5d | 2009-05-19 | 2009-05-23 | 715 | 88d | 0d | 88/2/29 | 88/3/2 | تن | 87/11/04 | 87/11/13 |
| 730 | 2.8.4.9 | آرماتوربندي تيرهاي طبقه ششم | 5d | 2009-06-21 | 2009-06-25 | 716 | 88d | 0d | 88/3/31 | 88/4/4 | تن | 87/12/07 | 87/12/16 |
| 731 | 2.8.4.10 | آرماتوربندي تيرهاي طبقه هفتم | 5d | 2009-07-24 | 2009-07-28 | 717 | 93d | 0d | 88/5/2 | 88/5/6 | تن | 88/01/10 | 88/01/19 |
| 732 | 2.8.4.11 | آرماتوربندي تيرهاي طبقه هشتم | 5d | 2009-08-26 | 2009-08-30 | 718 | 100d | 0d | 88/6/4 | 88/6/8 | تن | 88/02/12 | 88/02/21 |
| 733 | 2.8.4.12 | آرماتوربندي تيرهاي طبقه نهم | 5d | 2009-09-28 | 2009-10-02 | 719 | 107d | 0d | 88/7/6 | 88/7/10 | تن | 88/03/10 | 88/03/19 |
| 734 | 2.8.4.13 | آرماتوربندي تيرهاي طبقه دهم و خرپشته | 5d | 2009-10-31 | 2009-11-04 | 720 | 114d | 0d | 88/8/9 | 88/8/13 | تن | 88/04/12 | 88/04/21 |
| 735 | 2.8.5 | **قالب بندي تيرها** | 401d | 2008-09-22 | 2009-11-05 |  | 0d |  | 87/7/1 | 88/8/14 |  |  |  |
| 736 | 2.8.5.1 | قالب بندي تيرها زيرزمين دوم | 5d | 2008-09-22 | 2008-09-26 | 722SS+1d | 0d |  | 87/7/1 | 87/7/5 | مترمربع |  |  |
| 737 | 2.8.5.2 | قالب بندي تيرهاي زيرزمين اول | 5d | 2008-10-25 | 2008-10-29 | 723SS+1d | 54d | 0d | 87/8/4 | 87/8/8 | مترمربع |  |  |
| 738 | 2.8.5.3 | قالب بندي تيرهاي همكف | 5d | 2008-11-27 | 2008-12-01 | 724SS+1d | 54d | 0d | 87/9/7 | 87/9/11 | مترمربع |  |  |
| 739 | 2.8.5.4 | قالب بندي تيرهاي طبقه اول | 5d | 2008-12-30 | 2009-01-03 | 725SS+1d | 61d | 0d | 87/10/10 | 87/10/14 | مترمربع |  |  |
| 740 | 2.8.5.5 | قالب بندي تيرهاي طبقه دوم | 5d | 2009-02-01 | 2009-02-05 | 726SS+1d | 68d | 0d | 87/11/13 | 87/11/17 | مترمربع | 87/07/26 | 87/07/30 |
| 741 | 2.8.5.6 | قالب بندي تيرهاي طبقه سوم | 5d | 2009-03-06 | 2009-03-10 | 727SS+1d | 75d | 0d | 87/12/16 | 87/12/20 | مترمربع |  |  |
| 742 | 2.8.5.7 | قالب بندي تيرهاي طبقه چهارم | 5d | 2009-04-17 | 2009-04-21 | 728SS+1d | 82d | 0d | 88/1/28 | 88/2/1 | مترمربع | 87/10/02 | 87/10/06 |
| 743 | 2.8.5.8 | قالب بندي تيرهاي طبقه پنجم | 5d | 2009-05-20 | 2009-05-24 | 729SS+1d | 88d | 0d | 88/2/30 | 88/3/3 | مترمربع | 87/11/05 | 87/11/09 |
| 744 | 2.8.5.9 | قالب بندي تيرهاي طبقه ششم | 5d | 2009-06-22 | 2009-06-26 | 730SS+1d | 88d | 0d | 88/4/1 | 88/4/5 | مترمربع | 87/12/08 | 87/12/12 |
| 745 | 2.8.5.10 | قالب بندي تيرهاي طبقه هفتم | 5d | 2009-07-25 | 2009-07-29 | 731SS+1d | 93d | 0d | 88/5/3 | 88/5/7 | مترمربع | 88/01/11 | 88/01/15 |
| 746 | 2.8.5.11 | قالب بندي تيرهاي طبقه هشتم | 5d | 2009-08-27 | 2009-08-31 | 732SS+1d | 100d | 0d | 88/6/5 | 88/6/9 | مترمربع | 88/02/13 | 88/02/17 |
| 747 | 2.8.5.12 | قالب بندي تيرهاي طبقه نهم | 5d | 2009-09-29 | 2009-10-03 | 733SS+1d | 107d | 0d | 88/7/7 | 88/7/11 | مترمربع | 88/03/11 | 88/03/15 |
| 748 | 2.8.5.13 | قالب بندي تيرهاي طبقه دهم و خرپشته | 5d | 2009-11-01 | 2009-11-05 | 734SS+1d | 114d | 0d | 88/8/10 | 88/8/14 | مترمربع | 88/04/13 | 88/04/17 |

| ID | WBS | Task | Duration | Start | Finish | Predecessors | Total slack | Free slack | Plan Start | Plan Finish | واحد | Text1 | Text2 |
| --- | --- | --- | --- | --- | --- | --- | --- | --- | --- | --- | --- | --- | --- |
| 749 | 2.8.6 | **بتن ريزي تيرها** | 398d | 2008-09-27 | 2009-11-07 |  | 0d |  | 87/7/6 | 88/8/16 |  |  |  |
| 750 | 2.8.6.1 | بتن ريزي تيرهاي زيرزمين دوم | 2d | 2008-09-27 | 2008-09-28 | 736 | 0d |  | 87/7/6 | 87/7/7 | مترمکعب |  |  |
| 751 | 2.8.6.2 | بتن ريزي تيرهاي زيرزمين اول | 2d | 2008-10-30 | 2008-10-31 | 737 | 54d | 0d | 87/8/9 | 87/8/10 | مترمکعب |  |  |
| 752 | 2.8.6.3 | بتن ريزي تيرهاي همكف | 2d | 2008-12-02 | 2008-12-03 | 738 | 54d | 0d | 87/9/12 | 87/9/13 | مترمکعب |  |  |
| 753 | 2.8.6.4 | بتن ريزي تيرها طبقه اول | 2d | 2009-01-04 | 2009-01-05 | 739 | 61d | 0d | 87/10/15 | 87/10/16 | مترمکعب |  |  |
| 754 | 2.8.6.5 | بتن ريزي تيرهاي طبقه دوم | 2d | 2009-02-06 | 2009-02-07 | 740 | 68d | 0d | 87/11/18 | 87/11/19 | مترمکعب |  |  |
| 755 | 2.8.6.6 | بتن ريزي تيرهاي طبقه سوم | 2d | 2009-03-11 | 2009-03-12 | 741 | 75d | 0d | 87/12/21 | 87/12/22 | مترمکعب |  |  |
| 756 | 2.8.6.7 | بتن ريزي تيرهاي طبقه چهارم | 2d | 2009-04-22 | 2009-04-23 | 742 | 82d | 0d | 88/2/2 | 88/2/3 | مترمکعب |  |  |
| 757 | 2.8.6.8 | بتن ريزي تيرهاي طبقه پنجم | 2d | 2009-05-25 | 2009-05-26 | 743 | 88d | 0d | 88/3/4 | 88/3/5 | مترمکعب |  |  |
| 758 | 2.8.6.9 | بتن ريزي تيرهاي طبقه ششم | 2d | 2009-06-27 | 2009-06-28 | 744 | 88d | 0d | 88/4/6 | 88/4/7 | مترمکعب |  |  |
| 759 | 2.8.6.10 | بتن ريزي تيرهاي طبقه هفتم | 2d | 2009-07-30 | 2009-07-31 | 745 | 93d | 0d | 88/5/8 | 88/5/9 | مترمکعب |  |  |
| 760 | 2.8.6.11 | بتن ريزي تيرهاي طبقه هشتم | 2d | 2009-09-01 | 2009-09-02 | 746 | 100d | 0d | 88/6/10 | 88/6/11 | مترمکعب |  |  |
| 761 | 2.8.6.12 | بتن ريزي تيرهاي طبقه نهم | 2d | 2009-10-04 | 2009-10-05 | 747 | 107d | 0d | 88/7/12 | 88/7/13 | مترمکعب |  |  |
| 762 | 2.8.6.13 | بتن ريزي تيرهاي طبقه دهم و خرپشته | 2d | 2009-11-06 | 2009-11-07 | 748 | 114d | 0d | 88/8/15 | 88/8/16 | مترمکعب |  |  |
| 763 | 2.9 | **اجراي سقف سازه** | 406d | 2008-10-06 | 2009-11-24 |  | 0d |  | 87/7/15 | 88/9/3 | درصد |  |  |
| 764 | 2.9.1 | **ساخت تيرچه و تيرچه گذاري** | 399d | 2008-10-06 | 2009-11-17 |  | 0d |  | 87/7/15 | 88/8/26 |  |  |  |
| 765 | 2.9.1.1 | ساخت تيرچه و تيرچه گذاري زيرزمين دوم | 3d | 2008-10-06 | 2008-10-08 | 750FS+7d | 0d |  | 87/7/15 | 87/7/17 |  |  |  |
| 766 | 2.9.1.2 | ساخت تيرچه و تيرچه گذاري زيرزمين اول | 3d | 2008-11-08 | 2008-11-10 | 751FS+7d | 54d | 0d | 87/8/18 | 87/8/20 |  | 87/04/25 | 87/05/03 |
| 767 | 2.9.1.3 | ساخت تيرچه و تيرچه گذاري همكف | 3d | 2008-12-11 | 2008-12-13 | 752FS+7d | 54d | 0d | 87/9/21 | 87/9/23 |  | 87/05/27 | 87/06/05 |
| 768 | 2.9.1.4 | ساخت تيرچه و تيرچه گذاري طبقه اول | 3d | 2009-01-13 | 2009-01-15 | 753FS+7d | 61d | 0d | 87/10/24 | 87/10/26 |  | 87/06/29 | 87/07/07 |
| 769 | 2.9.1.5 | ساخت تيرچه و تيرچه گذاري طبقه دوم | 3d | 2009-02-15 | 2009-02-17 | 754FS+7d | 68d | 0d | 87/11/27 | 87/11/29 |  | 87/08/01 | 87/08/10 |
| 770 | 2.9.1.6 | ساخت تيرچه و تيرچه گذاري طبقه سوم | 3d | 2009-03-29 | 2009-03-31 | 755FS+7d | 75d | 0d | 88/1/9 | 88/1/11 |  | 87/09/04 | 87/09/13 |
| 771 | 2.9.1.7 | ساخت تيرچه و تيرچه گذاري طبقه چهارم | 3d | 2009-05-01 | 2009-05-03 | 756FS+7d | 82d | 0d | 88/2/11 | 88/2/13 |  | 87/10/07 | 87/10/16 |
| 772 | 2.9.1.8 | ساخت تيرچه و تيرچه گذاري طبقه پنجم | 3d | 2009-06-03 | 2009-06-05 | 757FS+7d | 88d | 0d | 88/3/13 | 88/3/15 |  | 87/11/10 | 87/11/19 |
| 773 | 2.9.1.9 | ساخت تيرچه و تيرچه گذاري طبقه ششم | 3d | 2009-07-06 | 2009-07-08 | 758FS+7d | 88d | 0d | 88/4/15 | 88/4/17 |  | 87/12/13 | 87/12/22 |
| 774 | 2.9.1.10 | ساخت تيرچه و تيرچه گذاري طبقه هفتم | 3d | 2009-08-08 | 2009-08-10 | 759FS+7d | 93d | 0d | 88/5/17 | 88/5/19 |  | 88/01/16 | 88/01/25 |
| 775 | 2.9.1.11 | ساخت تيرچه و تيرچه گذاري طبقه هشتم | 3d | 2009-09-10 | 2009-09-12 | 760FS+7d | 100d | 0d | 88/6/19 | 88/6/21 |  | 88/02/18 | 88/02/27 |
| 776 | 2.9.1.12 | ساخت تيرچه و تيرچه گذاري طبقه نهم | 3d | 2009-10-13 | 2009-10-15 | 761FS+7d | 107d | 0d | 88/7/21 | 88/7/23 |  | 88/03/16 | 88/03/25 |
| 777 | 2.9.1.13 | ساخت تيرچه و تيرچه گذاري طبقه دهم و خرپشته | 3d | 2009-11-15 | 2009-11-17 | 762FS+7d | 114d | 0d | 88/8/24 | 88/8/26 |  | 88/04/18 | 88/04/27 |

| ID | WBS | Task | Duration | Start | Finish | Predecessors | Total slack | Free slack | Plan Start | Plan Finish | واحد | Text1 | Text2 |
| --- | --- | --- | --- | --- | --- | --- | --- | --- | --- | --- | --- | --- | --- |
| 778 | 2.9.2 | **آرماتور بندي سقف و راه پله** | 402d | 2008-10-07 | 2009-11-21 |  | 0d |  | 87/7/16 | 88/8/30 |  |  |  |
| 779 | 2.9.2.1 | آرماتور بندي سقف و راه پله زيرزمين دوم | 6d | 2008-10-07 | 2008-10-12 | 765SS+1d | 0d |  | 87/7/16 | 87/7/21 | تن |  |  |
| 780 | 2.9.2.2 | آرماتور بندي سقف و راه پله زيرزمين اول | 6d | 2008-11-09 | 2008-11-14 | 766SS+1d | 54d | 0d | 87/8/19 | 87/8/24 | تن | 87/04/27 | 87/05/05 |
| 781 | 2.9.2.3 | آرماتور بندي سقف و راه پله همكف | 6d | 2008-12-12 | 2008-12-17 | 767SS+1d | 54d | 0d | 87/9/22 | 87/9/27 | تن | 87/05/29 | 87/06/07 |
| 782 | 2.9.2.4 | آرماتور بندي سقف و راه پله طبقه اول | 6d | 2009-01-14 | 2009-01-19 | 768SS+1d | 61d | 0d | 87/10/25 | 87/10/30 | تن | 87/06/31 | 87/07/09 |
| 783 | 2.9.2.5 | آرماتور بندي سقف و راه پله طبقه دوم | 6d | 2009-02-16 | 2009-02-21 | 769SS+1d | 68d | 0d | 87/11/28 | 87/12/3 | تن | 87/08/03 | 87/08/12 |
| 784 | 2.9.2.6 | آرماتور بندي سقف و راه پله طبقه سوم | 6d | 2009-03-30 | 2009-04-04 | 770SS+1d | 75d | 0d | 88/1/10 | 88/1/15 | تن | 87/09/06 | 87/09/15 |
| 785 | 2.9.2.7 | آرماتور بندي سقف و راه پله طبقه چهارم | 6d | 2009-05-02 | 2009-05-07 | 771SS+1d | 82d | 0d | 88/2/12 | 88/2/17 | تن | 87/10/09 | 87/10/18 |
| 786 | 2.9.2.8 | آرماتور بندي سقف و راه پله طبقه پنجم | 6d | 2009-06-04 | 2009-06-09 | 772SS+1d | 88d | 0d | 88/3/14 | 88/3/19 | تن | 87/11/12 | 87/11/21 |
| 787 | 2.9.2.9 | آرماتور بندي سقف و راه پله طبقه ششم | 6d | 2009-07-07 | 2009-07-12 | 773SS+1d | 88d | 0d | 88/4/16 | 88/4/21 | تن | 87/12/15 | 87/12/24 |
| 788 | 2.9.2.10 | آرماتور بندي سقف و راه پله طبقه هفتم | 6d | 2009-08-09 | 2009-08-14 | 774SS+1d | 93d | 0d | 88/5/18 | 88/5/23 | تن | 88/01/18 | 88/01/27 |
| 789 | 2.9.2.11 | آرماتور بندي سقف و راه پله طبقه هشتم | 6d | 2009-09-11 | 2009-09-16 | 775SS+1d | 100d | 0d | 88/6/20 | 88/6/25 | تن | 88/02/20 | 88/02/29 |
| 790 | 2.9.2.12 | آرماتور بندي سقف و راه پله طبقه نهم | 6d | 2009-10-14 | 2009-10-19 | 776SS+1d | 107d | 0d | 88/7/22 | 88/7/27 | تن | 88/03/18 | 88/03/27 |
| 791 | 2.9.2.13 | آرماتور بندي سقف و راه پله طبقه دهم | 6d | 2009-11-16 | 2009-11-21 | 777SS+1d | 114d | 0d | 88/8/25 | 88/8/30 | تن | 88/04/20 | 88/04/29 |
| 792 | 2.9.3 | **قالب بندي سقف و راه پله** | 401d | 2008-10-08 | 2009-11-21 |  | 0d |  | 87/7/17 | 88/8/30 |  |  |  |
| 793 | 2.9.3.1 | قالب بندي سقف و راه پله زيرزمين دوم | 5d | 2008-10-08 | 2008-10-12 | 779SS+1d | 0d |  | 87/7/17 | 87/7/21 | مترمربع |  |  |
| 794 | 2.9.3.2 | قالب بندي سقف و راه پله زيرزمين اول | 5d | 2008-11-10 | 2008-11-14 | 780SS+1d | 54d | 0d | 87/8/20 | 87/8/24 | مترمربع | 87/05/06 | 87/05/10 |
| 795 | 2.9.3.3 | قالب بندي سقف و راه پله همكف | 5d | 2008-12-13 | 2008-12-17 | 781SS+1d | 54d | 0d | 87/9/23 | 87/9/27 | مترمربع | 87/06/07 | 87/06/07 |
| 796 | 2.9.3.4 | قالب بندي سقف و راه پله طبقه اول | 5d | 2009-01-15 | 2009-01-19 | 782SS+1d | 61d | 0d | 87/10/26 | 87/10/30 | مترمربع | 87/07/09 | 87/07/09 |
| 797 | 2.9.3.5 | قالب بندي سقف و راه پله طبقه دوم | 5d | 2009-02-17 | 2009-02-21 | 783SS+1d | 68d | 0d | 87/11/29 | 87/12/3 | مترمربع | 87/08/12 | 87/08/12 |
| 798 | 2.9.3.6 | قالب بندي سقف و راه پله طبقه سوم | 5d | 2009-03-31 | 2009-04-04 | 784SS+1d | 75d | 0d | 88/1/11 | 88/1/15 | مترمربع | 87/09/15 | 87/09/15 |
| 799 | 2.9.3.7 | قالب بندي سقف و راه پله طبقه چهارم | 5d | 2009-05-03 | 2009-05-07 | 785SS+1d | 82d | 0d | 88/2/13 | 88/2/17 | مترمربع | 87/10/18 | 87/10/18 |
| 800 | 2.9.3.8 | قالب بندي سقف و راه پله طبقه پنجم | 5d | 2009-06-05 | 2009-06-09 | 786SS+1d | 88d | 0d | 88/3/15 | 88/3/19 | مترمربع | 87/11/21 | 87/11/21 |
| 801 | 2.9.3.9 | قالب بندي سقف و راه پله طبقه ششم | 5d | 2009-07-08 | 2009-07-12 | 787SS+1d | 88d | 0d | 88/4/17 | 88/4/21 | مترمربع | 87/12/24 | 87/12/24 |
| 802 | 2.9.3.10 | قالب بندي سقف و راه پله طبقه هفتم | 5d | 2009-08-10 | 2009-08-14 | 788SS+1d | 93d | 0d | 88/5/19 | 88/5/23 | مترمربع | 88/01/27 | 88/01/27 |
| 803 | 2.9.3.11 | قالب بندي سقف و راه پله طبقه هشتم | 5d | 2009-09-12 | 2009-09-16 | 789SS+1d | 100d | 0d | 88/6/21 | 88/6/25 | مترمربع | 88/02/30 | 88/02/30 |
| 804 | 2.9.3.12 | قالب بندي سقف و راه پله طبقه نهم | 5d | 2009-10-15 | 2009-10-19 | 790SS+1d | 107d | 0d | 88/7/23 | 88/7/27 | مترمربع | 88/03/27 | 88/03/27 |
| 805 | 2.9.3.13 | قالب بندي سقف و راه پله طبقه دهم | 5d | 2009-11-17 | 2009-11-21 | 791SS+1d | 114d | 0d | 88/8/26 | 88/8/30 | مترمربع | 88/04/29 | 88/04/29 |

| ID | WBS | Task | Duration | Start | Finish | Predecessors | Total slack | Free slack | Plan Start | Plan Finish | واحد | Text1 | Text2 |
| --- | --- | --- | --- | --- | --- | --- | --- | --- | --- | --- | --- | --- | --- |
| 806 | 2.9.4 | **بتن ريزي سقف و راه پله** | 399d | 2008-10-13 | 2009-11-24 |  | 0d |  | 87/7/22 | 88/9/3 |  |  |  |
| 807 | 2.9.4.1 | بتن ريزي سقف و راه پله زيرزمين دوم | 3d | 2008-10-13 | 2008-10-15 | 793 | 0d |  | 87/7/22 | 87/7/24 | مترمکعب |  |  |
| 808 | 2.9.4.2 | بتن ريزي سقف و راه پله زيرزمين اول | 3d | 2008-11-15 | 2008-11-17 | 794 | 54d | 0d | 87/8/25 | 87/8/27 | مترمکعب |  |  |
| 809 | 2.9.4.3 | بتن ريزي سقف و راه پله همكف | 3d | 2008-12-18 | 2008-12-20 | 795 | 54d | 0d | 87/9/28 | 87/9/30 | مترمکعب | 87/06/08 | 87/06/12 |
| 810 | 2.9.4.4 | بتن ريزي سقف و راه پله طبقه اول | 3d | 2009-01-20 | 2009-01-22 | 796 | 61d | 0d | 87/11/1 | 87/11/3 | مترمکعب | 87/07/10 | 87/07/14 |
| 811 | 2.9.4.5 | بتن ريزي سقف و راه پله طبقه دوم | 3d | 2009-02-22 | 2009-02-24 | 797 | 68d | 0d | 87/12/4 | 87/12/6 | مترمکعب | 87/08/13 | 87/08/17 |
| 812 | 2.9.4.6 | بتن ريزي سقف و راه پله طبقه سوم | 3d | 2009-04-05 | 2009-04-07 | 798 | 75d | 0d | 88/1/16 | 88/1/18 | مترمکعب | 87/09/16 | 87/09/20 |
| 813 | 2.9.4.7 | بتن ريزي سقف و راه پله طبقه چهارم | 3d | 2009-05-08 | 2009-05-10 | 799 | 82d | 0d | 88/2/18 | 88/2/20 | مترمکعب | 87/10/19 | 87/10/23 |
| 814 | 2.9.4.8 | بتن ريزي سقف و راه پله طبقه پنجم | 3d | 2009-06-10 | 2009-06-12 | 800 | 88d | 0d | 88/3/20 | 88/3/22 | مترمکعب | 87/11/22 | 87/11/26 |
| 815 | 2.9.4.9 | بتن ريزي سقف و راه پله طبقه ششم | 3d | 2009-07-13 | 2009-07-15 | 801 | 88d | 0d | 88/4/22 | 88/4/24 | مترمکعب | 87/12/25 | 87/12/29 |
| 816 | 2.9.4.10 | بتن ريزي سقف و راه پله طبقه هفتم | 3d | 2009-08-15 | 2009-08-17 | 802 | 93d | 0d | 88/5/24 | 88/5/26 | مترمکعب | 88/01/28 | 88/02/01 |
| 817 | 2.9.4.11 | بتن ريزي سقف و راه پله طبقه هشتم | 3d | 2009-09-17 | 2009-09-19 | 803 | 100d | 0d | 88/6/26 | 88/6/28 | مترمکعب | 88/02/26 | 88/02/30 |
| 818 | 2.9.4.12 | بتن ريزي سقف و راه پله طبقه نهم | 3d | 2009-10-20 | 2009-10-22 | 804 | 107d | 0d | 88/7/28 | 88/7/30 | مترمکعب | 88/03/28 | 88/04/01 |
| 819 | 2.9.4.13 | بتن ريزي سقف و راه پله طبقه دهم | 3d | 2009-11-22 | 2009-11-24 | 805 | 114d | 0d | 88/9/1 | 88/9/3 | مترمکعب |  |  |
| 820 | 2.10 | **سفت كاري** | 729d | 2008-10-23 | 2010-11-07 |  | 0d |  | 87/8/2 | 89/8/16 | درصد | 87/07/30 | 88/07/04 |
| 821 | 2.10.1 | **نبشي كشي نما** | 333d | 2008-12-28 | 2009-12-04 |  | 240d | 18d | 87/10/8 | 88/9/13 |  |  |  |
| 822 | 2.10.1.1 | نبشي كشي نماي همكف | 3d | 2008-12-28 | 2008-12-30 | 809FS+7d | 570d |  | 87/10/8 | 87/10/10 |  |  |  |
| 823 | 2.10.1.2 | نبشي كشي نماي طبقه اول | 3d | 2009-01-30 | 2009-02-01 | 810FS+7d | 537d |  | 87/11/11 | 87/11/13 |  |  |  |
| 824 | 2.10.1.3 | نبشي كشي نماي طبقه دوم | 3d | 2009-03-04 | 2009-03-06 | 811FS+7d | 504d |  | 87/12/14 | 87/12/16 |  |  |  |
| 825 | 2.10.1.4 | نبشي كشي نماي طبقه سوم | 3d | 2009-04-15 | 2009-04-17 | 812FS+7d | 471d |  | 88/1/26 | 88/1/28 |  |  |  |
| 826 | 2.10.1.5 | نبشي كشي نماي طبقه چهارم | 3d | 2009-05-18 | 2009-05-20 | 813FS+7d | 438d |  | 88/2/28 | 88/2/30 |  |  |  |
| 827 | 2.10.1.6 | نبشي كشي نماي طبقه پنجم | 3d | 2009-06-20 | 2009-06-22 | 814FS+7d | 405d |  | 88/3/30 | 88/4/1 |  |  |  |
| 828 | 2.10.1.7 | نبشي كشي نماي طبقه ششم | 3d | 2009-07-23 | 2009-07-25 | 815FS+7d | 372d |  | 88/5/1 | 88/5/3 |  |  |  |
| 829 | 2.10.1.8 | نبشي كشي نماي طبقه هفتم | 3d | 2009-08-25 | 2009-08-27 | 816FS+7d | 339d |  | 88/6/3 | 88/6/5 |  |  |  |
| 830 | 2.10.1.9 | نبشي كشي نماي طبقه هشتم | 3d | 2009-09-27 | 2009-09-29 | 817FS+7d | 306d |  | 88/7/5 | 88/7/7 |  |  |  |
| 831 | 2.10.1.10 | نبشي كشي نماي طبقه نهم | 3d | 2009-10-30 | 2009-11-01 | 818FS+7d | 273d |  | 88/8/8 | 88/8/10 |  |  |  |
| 832 | 2.10.1.11 | نبشي كشي نماي طبقه دهم و خرپشته | 3d | 2009-12-02 | 2009-12-04 | 819FS+7d | 240d |  | 88/9/11 | 88/9/13 |  |  |  |

| ID | WBS | Task | Duration | Start | Finish | Predecessors | Total slack | Free slack | Text1 | Text2 | واحد | Plan Start | Plan Finish |
| --- | --- | --- | --- | --- | --- | --- | --- | --- | --- | --- | --- | --- | --- |
| 833 | 2.10.2 | **اجراي ديوارهاي طبقات** | 410d | 2008-10-23 | 2009-12-15 |  | 0d |  | 87/11/16 | 88/07/04 | درصد | 87/8/2 | 88/9/24 |
| 834 | 2.10.2.1 | اجراي ديوارهاي طبقه زيرزمين دوم | 14d | 2008-10-23 | 2008-11-05 | 807FS+7d | 0d |  |  |  | مترمربع | 87/8/2 | 87/8/15 |
| 835 | 2.10.2.2 | اجراي ديوارهاي طبقه زيرزمين اول | 14d | 2008-11-25 | 2008-12-08 | 808FS+7d, 834 | 57d | 0d | 87/11/16 | 87/12/05 | مترمربع | 87/9/5 | 87/9/18 |
| 836 | 2.10.2.3 | اجراي ديوارهاي طبقه همكف | 14d | 2008-12-28 | 2009-01-10 | 809FS+7d, 835 | 54d | 0d | 87/12/06 | 87/12/25 | مترمربع | 87/10/8 | 87/10/21 |
| 837 | 2.10.2.4 | اجراي ديوارهاي طبقه اول | 14d | 2009-01-30 | 2009-02-12 | 810FS+7d, 836 | 61d | 0d | 87/12/26 | 88/01/15 | مترمربع | 87/11/11 | 87/11/24 |
| 838 | 2.10.2.5 | اجراي ديوارهاي طبقه دوم | 14d | 2009-03-04 | 2009-03-17 | 811FS+7d, 837 | 68d | 0d | 88/01/16 | 88/02/04 | مترمربع | 87/12/14 | 87/12/27 |
| 839 | 2.10.2.6 | اجراي ديوارهاي طبقه سوم | 14d | 2009-04-15 | 2009-04-28 | 812FS+7d, 838 | 75d | 0d | 88/02/05 | 88/02/24 | مترمربع | 88/1/26 | 88/2/8 |
| 840 | 2.10.2.7 | اجراي ديوارهاي طبقه چهارم | 14d | 2009-05-18 | 2009-05-31 | 813FS+7d, 839 | 82d | 0d | 88/02/25 | 88/03/13 | مترمربع | 88/2/28 | 88/3/10 |
| 841 | 2.10.2.8 | اجراي ديوارهاي طبقه پنجم | 14d | 2009-06-20 | 2009-07-03 | 814FS+7d, 840 | 89d | 0d | 88/03/14 | 88/04/02 | مترمربع | 88/3/30 | 88/4/12 |
| 842 | 2.10.2.9 | اجراي ديوارهاي طبقه ششم | 14d | 2009-07-23 | 2009-08-05 | 815FS+7d, 841 | 88d | 0d | 88/04/03 | 88/04/22 | مترمربع | 88/5/1 | 88/5/14 |
| 843 | 2.10.2.10 | اجراي ديوارهاي طبقه هفتم | 14d | 2009-08-25 | 2009-09-07 | 816FS+7d, 842 | 93d | 0d | 88/04/23 | 88/05/11 | مترمربع | 88/6/3 | 88/6/16 |
| 844 | 2.10.2.11 | اجراي ديوارهاي طبقه هشتم | 14d | 2009-09-27 | 2009-10-10 | 817FS+7d, 843 | 100d | 0d | 88/05/12 | 88/05/31 | مترمربع | 88/7/5 | 88/7/18 |
| 845 | 2.10.2.12 | اجراي ديوارهاي طبقه نهم | 14d | 2009-10-30 | 2009-11-12 | 818FS+7d, 844 | 107d | 0d | 88/06/01 | 88/06/20 | مترمربع | 88/8/8 | 88/8/21 |
| 846 | 2.10.2.13 | اجراي ديوارهاي طبقه دهم | 14d | 2009-12-02 | 2009-12-15 | 819FS+7d, 845 | 114d | 0d | 88/06/21 | 88/07/04 | مترمربع | 88/9/11 | 88/9/24 |
| 847 | 2.10.3 | **ساخت و نصب چهارجوب درب ها و نعل درگاهها** | 400d | 2008-11-03 | 2009-12-16 |  | 322d |  |  |  |  | 87/8/13 | 88/9/25 |
| 848 | 2.10.3.1 | ساخت و نصب چهارجوب درب ها و نعل درگاههاي طبقه زير زمين دوم | 4d | 2008-11-03 | 2008-11-06 | 834FF+1d | 718d |  |  |  |  | 87/8/13 | 87/8/16 |
| 849 | 2.10.3.2 | ساخت و نصب چهارجوب درب ها و نعل درگاههاي طبقه زيرزمين اول | 4d | 2008-12-06 | 2008-12-09 | 835FF+1d | 685d |  |  |  |  | 87/9/16 | 87/9/19 |
| 850 | 2.10.3.3 | ساخت و نصب چهارجوب درب ها و نعل درگاههاي طبقه همكف | 4d | 2009-01-08 | 2009-01-11 | 836FF+1d | 652d |  |  |  |  | 87/10/19 | 87/10/22 |
| 851 | 2.10.3.4 | ساخت و نصب چهارجوب درب ها و نعل درگاههاي طبقه اول | 4d | 2009-02-10 | 2009-02-13 | 837FF+1d | 619d |  |  |  |  | 87/11/22 | 87/11/25 |
| 852 | 2.10.3.5 | ساخت و نصب چهارجوب درب ها و نعل درگاههاي طبقه دوم | 4d | 2009-03-15 | 2009-03-18 | 838FF+1d | 586d |  |  |  |  | 87/12/25 | 87/12/28 |
| 853 | 2.10.3.6 | ساخت و نصب چهارجوب درب ها و نعل درگاههاي طبقه سوم | 4d | 2009-04-26 | 2009-04-29 | 839FF+1d | 553d |  |  |  |  | 88/2/6 | 88/2/9 |
| 854 | 2.10.3.7 | ساخت و نصب چهارجوب درب ها و نعل درگاههاي طبقه چهارم | 4d | 2009-05-29 | 2009-06-01 | 840FF+1d | 520d |  |  |  |  | 88/3/8 | 88/3/11 |
| 855 | 2.10.3.8 | ساخت و نصب چهارجوب درب ها و نعل درگاههاي طبقه پنجم | 4d | 2009-07-01 | 2009-07-04 | 841FF+1d | 487d |  |  |  |  | 88/4/10 | 88/4/13 |
| 856 | 2.10.3.9 | ساخت و نصب چهارجوب درب ها و نعل درگاههاي طبقه ششم | 4d | 2009-08-03 | 2009-08-06 | 842FF+1d | 454d |  |  |  |  | 88/5/12 | 88/5/15 |
| 857 | 2.10.3.10 | ساخت و نصب چهارجوب درب ها و نعل درگاههاي طبقه هفتم | 4d | 2009-09-05 | 2009-09-08 | 843FF+1d | 421d |  |  |  |  | 88/6/14 | 88/6/17 |
| 858 | 2.10.3.11 | ساخت و نصب چهارجوب درب ها و نعل درگاههاي طبقه هشتم | 4d | 2009-10-08 | 2009-10-11 | 844FF+1d | 388d |  |  |  |  | 88/7/16 | 88/7/19 |
| 859 | 2.10.3.12 | ساخت و نصب چهارجوب درب ها و نعل درگاههاي طبقه نهم | 4d | 2009-11-10 | 2009-11-13 | 845FF+1d | 355d |  |  |  |  | 88/8/19 | 88/8/22 |
| 860 | 2.10.3.13 | ساخت و نصب چهارجوب درب ها و نعل درگاههاي طبقه دهم و خرپشته | 4d | 2009-12-13 | 2009-12-16 | 846FF+1d | 322d |  |  |  |  | 88/9/22 | 88/9/25 |

| ID | WBS | Task | Duration | Start | Finish | Predecessors | Total slack | Free slack | Text1 | Text2 | واحد | Plan Start | Plan Finish |
| --- | --- | --- | --- | --- | --- | --- | --- | --- | --- | --- | --- | --- | --- |
| 861 | 2.10.4 | **اجراي گچ و خاك طبقات** | 396d | 2009-01-11 | 2010-02-19 |  | 54d |  | 87/12/06 | 88/08/09 | درصد | 87/10/22 | 88/11/30 |
| 862 | 2.10.4.1 | اجراي گچ و خاك طبقه همكف | 30d | 2009-01-11 | 2009-02-09 | 836, 1018 | 54d | 0d | 88/01/06 | 88/01/25 | مترمربع | 87/10/22 | 87/11/21 |
| 863 | 2.10.4.2 | اجراي گچ و خاك طبقه اول | 30d | 2009-02-13 | 2009-03-14 | 837, 862 | 61d | 0d | 88/01/26 | 88/02/14 | مترمربع | 87/11/25 | 87/12/24 |
| 864 | 2.10.4.3 | اجراي گچ و خاك طبقه دوم | 30d | 2009-03-18 | 2009-04-25 | 838, 863 | 68d | 0d | 88/02/15 | 88/03/03 | مترمربع | 87/12/28 | 88/2/5 |
| 865 | 2.10.4.4 | اجراي گچ و خاك طبقه سوم | 30d | 2009-04-29 | 2009-05-28 | 839, 864 | 75d | 0d | 88/03/04 | 88/03/23 | مترمربع | 88/2/9 | 88/3/7 |
| 866 | 2.10.4.5 | اجراي گچ و خاك طبقه چهارم | 30d | 2009-06-01 | 2009-06-30 | 840, 865 | 82d | 0d | 88/03/24 | 88/04/12 | مترمربع | 88/3/11 | 88/4/9 |
| 867 | 2.10.4.6 | اجراي گچ و خاك طبقه پنجم | 30d | 2009-07-04 | 2009-08-02 | 841, 866 | 89d | 0d | 88/04/13 | 88/05/01 | مترمربع | 88/4/13 | 88/5/11 |
| 868 | 2.10.4.7 | اجراي گچ و خاك طبقه ششم | 38d | 2009-08-06 | 2009-09-12 | 842, 867 | 88d | 0d | 88/05/02 | 88/05/21 | مترمربع | 88/5/15 | 88/6/21 |
| 869 | 2.10.4.8 | اجراي گچ و خاك طبقه هفتم | 40d | 2009-09-13 | 2009-10-22 | 843, 868 | 88d | 0d | 88/05/22 | 88/06/10 | مترمربع | 88/6/22 | 88/7/30 |
| 870 | 2.10.4.9 | اجراي گچ و خاك طبقه هشتم | 40d | 2009-10-23 | 2009-12-01 | 844, 869 | 88d | 0d | 88/06/11 | 88/06/30 | مترمربع | 88/8/1 | 88/9/10 |
| 871 | 2.10.4.10 | اجراي گچ و خاك طبقه نهم | 40d | 2009-12-02 | 2010-01-10 | 845, 870 | 88d | 0d | 88/06/31 | 88/07/19 | مترمربع | 88/9/11 | 88/10/20 |
| 872 | 2.10.4.11 | اجراي گچ و خاك طبقه دهم و خرپشته | 40d | 2010-01-11 | 2010-02-19 | 846, 871 | 88d | 0d | 88/07/20 | 88/08/09 | مترمربع | 88/10/21 | 88/11/30 |
| 873 | 2.10.5 | **اجراي سقف كاذب طبقات** | 163d | 2010-05-29 | 2010-11-07 |  | 0d |  | 88/02/15 | 88/09/19 | درصد | 89/3/8 | 89/8/16 |
| 874 | 2.10.5.1 | اجراي سقف كاذب همکف | 20d | 2010-05-29 | 2010-06-17 | 1069, 1097, 1109 | 0d |  | 88/02/15 | 88/03/03 | مترمربع | 89/3/8 | 89/3/27 |
| 875 | 2.10.5.2 | اجراي سقف كاذب طبقه 1 | 20d | 2010-06-05 | 2010-06-24 | 1070, 1098, 1110 | 140d |  | 88/03/04 | 88/03/23 | مترمربع | 89/3/15 | 89/4/3 |
| 876 | 2.10.5.3 | اجراي سقف كاذب طبقه 2 | 20d | 2010-06-17 | 2010-07-06 | 1071, 1099, 1111 | 128d |  | 88/03/24 | 88/04/12 | مترمربع | 89/3/27 | 89/4/15 |
| 877 | 2.10.5.4 | اجراي سقف كاذب طبقه 3 | 20d | 2010-07-02 | 2010-07-21 | 1072, 1100, 1112 | 113d |  | 88/04/13 | 88/05/01 | مترمربع | 89/4/11 | 89/4/30 |
| 878 | 2.10.5.5 | اجراي سقف كاذب طبقه 4 | 20d | 2010-07-17 | 2010-08-05 | 1073, 1101, 1113 | 98d |  | 88/05/02 | 88/05/21 | مترمربع | 89/4/26 | 89/5/14 |
| 879 | 2.10.5.6 | اجراي سقف كاذب طبقه 5 | 20d | 2010-08-01 | 2010-08-20 | 1074, 1102, 1114 | 83d |  | 88/05/22 | 88/06/10 | مترمربع | 89/5/10 | 89/5/29 |
| 880 | 2.10.5.7 | اجراي سقف كاذب طبقه 6 | 20d | 2010-08-16 | 2010-09-04 | 1075, 1103, 1115 | 68d |  | 88/06/11 | 88/06/30 | مترمربع | 89/5/25 | 89/6/13 |
| 881 | 2.10.5.8 | اجراي سقف كاذب طبقه 7 | 20d | 2010-08-31 | 2010-09-19 | 1076, 1104, 1116 | 53d |  | 88/06/31 | 88/07/19 | مترمربع | 89/6/9 | 89/6/28 |
| 882 | 2.10.5.9 | اجراي سقف كاذب طبقه 8 | 20d | 2010-09-15 | 2010-10-04 | 1077, 1105, 1117 | 38d |  | 88/07/20 | 88/08/09 | مترمربع | 89/6/24 | 89/7/12 |
| 883 | 2.10.5.10 | اجراي سقف كاذب طبقه 9 | 20d | 2010-09-30 | 2010-10-19 | 1078, 1106, 1118 | 23d |  | 88/08/10 | 88/08/29 | مترمربع | 89/7/8 | 89/7/27 |
| 884 | 2.10.5.11 | اجراي سقف كاذب طبقه10 | 22d | 2010-10-17 | 2010-11-07 | 1079, 1107, 1119 | 4d |  | 88/08/30 | 88/09/19 | مترمربع | 89/7/25 | 89/8/16 |

| ID | WBS | Task | Duration | Start | Finish | Predecessors | Total slack | Free slack | Text1 | Text2 | واحد | Plan Start | Plan Finish |
| --- | --- | --- | --- | --- | --- | --- | --- | --- | --- | --- | --- | --- | --- |
| 885 | 2.10.6 | **اجراي كف سازي نهائی طبقات** | 222d | 2010-02-14 | 2010-10-01 |  | 0d |  | 87/10/06 | 88/10/24 | درصد | 88/11/25 | 89/7/9 |
| 886 | 2.10.6.1 | اجراي كف سازي طبقه زيرزمين دوم | 20d | 2010-02-14 | 2010-03-05 | 944 | 0d |  | 88/01/16 | 88/02/04 | مترمربع | 88/11/25 | 88/12/14 |
| 887 | 2.10.6.2 | اجراي كف سازي طبقه زيرزمين اول | 20d | 2010-03-01 | 2010-03-28 | 945, 988 | 218d | 0d | 88/01/16 | 88/02/04 | مترمربع | 88/12/10 | 89/1/8 |
| 888 | 2.10.6.3 | اجراي كف سازي طبقه همكف | 20d | 2010-04-04 | 2010-04-23 | 1020SS, 946 | 0d |  | 88/03/24 | 88/04/02 | مترمربع | 89/1/15 | 89/2/3 |
| 889 | 2.10.6.4 | اجراي كف سازي طبقه اول | 20d | 2010-04-11 | 2010-04-30 | 1021SS, 946 | 44d | 0d | 88/04/13 | 88/04/22 | مترمربع | 89/1/22 | 89/2/10 |
| 890 | 2.10.6.5 | اجراي كف سازي طبقه 2 | 20d | 2010-04-23 | 2010-05-12 | 1022SS, 947 | 42d | 0d | 88/05/02 | 88/05/11 | مترمربع | 89/2/3 | 89/2/22 |
| 891 | 2.10.6.6 | اجراي كف سازي طبقه 3 | 20d | 2010-05-08 | 2010-05-27 | 1023SS, 948 | 37d | 0d | 88/05/22 | 88/05/31 | مترمربع | 89/2/18 | 89/3/6 |
| 892 | 2.10.6.7 | اجراي كف سازي طبقه 4 | 20d | 2010-05-23 | 2010-06-11 | 1024SS, 949 | 32d | 0d | 88/06/11 | 88/06/20 | مترمربع | 89/3/2 | 89/3/21 |
| 893 | 2.10.6.8 | اجراي كف سازي طبقه 5 | 20d | 2010-06-07 | 2010-06-26 | 1025SS, 950 | 27d | 0d | 88/06/31 | 88/07/09 | مترمربع | 89/3/17 | 89/4/5 |
| 894 | 2.10.6.9 | اجراي كف سازي طبقه 6 | 20d | 2010-06-22 | 2010-07-11 | 1026SS, 951 | 22d | 0d | 88/07/20 | 88/07/29 | مترمربع | 89/4/1 | 89/4/20 |
| 895 | 2.10.6.10 | اجراي كف سازي طبقه 7 | 20d | 2010-07-07 | 2010-07-26 | 1027SS, 952 | 17d | 0d | 88/08/10 | 88/08/19 | مترمربع | 89/4/16 | 89/5/4 |
| 896 | 2.10.6.11 | اجراي كف سازي طبقه 8 | 20d | 2010-07-22 | 2010-08-10 | 1028SS, 953 | 12d | 0d | 88/08/30 | 88/09/09 | مترمربع | 89/4/31 | 89/5/19 |
| 897 | 2.10.6.12 | اجراي كف سازي طبقه 9 | 20d | 2010-08-06 | 2010-08-25 | 1029SS, 954 | 7d | 0d | 88/09/20 | 88/09/29 | مترمربع | 89/5/15 | 89/6/3 |
| 898 | 2.10.6.13 | اجراي كف سازي طبقه 10 و خرپشته | 20d | 2010-08-23 | 2010-09-11 | 1030SS, 955 | 0d |  |  |  | مترمربع | 89/6/1 | 89/6/20 |
| 899 | 2.10.6.14 | اجراي كف سازي بام | 20d | 2010-09-12 | 2010-10-01 | 898 | 41d |  | 88/10/10 | 88/10/24 | درصد | 89/6/21 | 89/7/9 |
| 900 | 2.11 | **فاز اول تاسيسات مكانيكي طبقات** | 558d | 2009-01-25 | 2010-08-22 |  | 0d |  | 87/12/06 | 88/08/19 | درصد | 87/11/6 | 89/5/31 |
| 901 | 2.11.1 | **لوله كشي فاضلاب ، آب باران ، ونت** | 511d | 2009-01-25 | 2010-07-06 |  | 0d |  | 87/12/06 | 88/07/29 | درصد | 87/11/6 | 89/4/15 |
| 902 | 2.11.1.1 | لوله كشي زيرزمين دوم | 30d | 2009-01-25 | 2009-02-23 | 1017FS+60d | 0d |  |  |  | مترطول | 87/11/6 | 87/12/5 |
| 903 | 2.11.1.2 | لوله كشي زيرزمين اول | 30d | 2009-03-06 | 2009-04-13 | 902FS+10d, 1018FS+10d | 0d |  | 87/12/06 | 87/12/25 | مترطول | 87/12/16 | 88/1/24 |
| 904 | 2.11.1.3 | لوله كشي طبقه همكف | 30d | 2009-04-24 | 2009-05-23 | 862FS+10d, 903FS+10d | 0d |  | 87/12/26 | 88/01/15 | مترطول | 88/2/4 | 88/3/2 |
| 905 | 2.11.1.4 | لوله كشي طبقه اول | 30d | 2009-06-03 | 2009-07-02 | 863FS+10d, 904FS+10d | 0d |  | 88/01/16 | 88/02/04 | مترطول | 88/3/13 | 88/4/11 |
| 906 | 2.11.1.5 | لوله كشي طبقه دوم | 30d | 2009-07-13 | 2009-08-11 | 864FS+10d, 905FS+10d | 0d |  | 88/02/05 | 88/02/24 | مترطول | 88/4/22 | 88/5/20 |
| 907 | 2.11.1.6 | لوله كشي طبقه سوم | 30d | 2009-08-22 | 2009-09-20 | 865FS+10d, 906FS+10d | 0d |  | 88/02/25 | 88/03/13 | مترطول | 88/5/31 | 88/6/29 |
| 908 | 2.11.1.7 | لوله كشي طبقه چهارم | 30d | 2009-10-01 | 2009-10-30 | 866FS+10d, 907FS+10d | 0d |  | 88/03/14 | 88/04/02 | مترطول | 88/7/9 | 88/8/8 |
| 909 | 2.11.1.8 | لوله كشي طبقه پنجم | 30d | 2009-11-10 | 2009-12-09 | 867FS+10d, 908FS+10d | 0d |  | 88/04/03 | 88/04/22 | مترطول | 88/8/19 | 88/9/18 |
| 910 | 2.11.1.9 | لوله كشي طبقه ششم | 30d | 2009-12-20 | 2010-01-18 | 868FS+10d, 909FS+10d | 0d |  | 88/04/23 | 88/05/11 | مترطول | 88/9/29 | 88/10/28 |
| 911 | 2.11.1.10 | لوله كشي طبقه هفتم | 30d | 2010-01-29 | 2010-02-27 | 869FS+10d, 910FS+10d | 0d |  | 88/05/12 | 88/05/31 | مترطول | 88/11/9 | 88/12/8 |
| 912 | 2.11.1.11 | لوله كشي طبقه هشتم | 30d | 2010-03-10 | 2010-04-16 | 870FS+10d, 911FS+10d | 0d |  | 88/06/01 | 88/06/20 | مترطول | 88/12/19 | 89/1/27 |
| 913 | 2.11.1.12 | لوله كشي طبقه نهم | 30d | 2010-04-27 | 2010-05-26 | 871FS+10d, 912FS+10d | 0d |  | 88/06/21 | 88/07/09 | مترطول | 89/2/7 | 89/3/5 |
| 914 | 2.11.1.13 | لوله كشي طبقه دهم | 31d | 2010-06-06 | 2010-07-06 | 872FS+10d, 913FS+10d | 0d |  | 88/07/10 | 88/07/29 | درصد | 89/3/16 | 89/4/15 |

| ID | WBS | Task | Duration | Start | Finish | Predecessors | Total slack | Free slack | Text1 | Text2 | واحد | Plan Start | Plan Finish |
| --- | --- | --- | --- | --- | --- | --- | --- | --- | --- | --- | --- | --- | --- |
| 915 | 2.11.2 | **لوله كشي تهويه طبقات** | 516d | 2009-01-30 | 2010-07-16 |  | 118d |  | 87/12/06 | 88/07/29 | درصد | 87/11/11 | 89/4/25 |
| 916 | 2.11.2.1 | لوله كشي تهويه طبقه زيرزمين دوم | 30d | 2009-01-30 | 2009-02-28 | 902SS+5d | 604d |  |  |  | مترطول | 87/11/11 | 87/12/10 |
| 917 | 2.11.2.2 | لوله كشي تهويه طبقه زيرزمين اول | 30d | 2009-03-16 | 2009-04-23 | 903SS+10d | 559d |  | 87/12/06 | 87/12/25 | مترطول | 87/12/26 | 88/2/3 |
| 918 | 2.11.2.3 | لوله كشي تهويه طبقه همكف | 30d | 2009-05-04 | 2009-06-02 | 904SS+10d | 297d |  | 87/12/26 | 88/01/15 | مترطول | 88/2/14 | 88/3/12 |
| 919 | 2.11.2.4 | لوله كشي تهويه طبقه اول | 30d | 2009-06-13 | 2009-07-12 | 905SS+10d | 308d | 264d | 88/01/16 | 88/02/04 | مترطول | 88/3/23 | 88/4/21 |
| 920 | 2.11.2.5 | لوله كشي تهويه طبقه دوم | 30d | 2009-07-23 | 2009-08-21 | 906SS+10d | 278d | 236d | 88/02/05 | 88/02/24 | مترطول | 88/5/1 | 88/5/30 |
| 921 | 2.11.2.6 | لوله كشي تهويه طبقه سوم | 30d | 2009-09-01 | 2009-09-30 | 907SS+10d | 248d | 211d | 88/02/25 | 88/03/13 | مترطول | 88/6/10 | 88/7/8 |
| 922 | 2.11.2.7 | لوله كشي تهويه طبقه چهارم | 30d | 2009-10-11 | 2009-11-09 | 908SS+10d | 218d | 186d | 88/03/14 | 88/04/02 | مترطول | 88/7/19 | 88/8/18 |
| 923 | 2.11.2.8 | لوله كشي تهويه طبقه پنجم | 30d | 2009-11-20 | 2009-12-19 | 909SS+10d | 188d | 161d | 88/04/03 | 88/04/22 | مترطول | 88/8/29 | 88/9/28 |
| 924 | 2.11.2.9 | لوله كشي تهويه طبقه ششم | 30d | 2009-12-30 | 2010-01-28 | 910SS+10d | 158d | 136d | 88/04/23 | 88/05/11 | مترطول | 88/10/9 | 88/11/8 |
| 925 | 2.11.2.10 | لوله كشي تهويه طبقه هفتم | 30d | 2010-02-08 | 2010-03-09 | 911SS+10d | 128d | 111d | 88/05/12 | 88/05/31 | مترطول | 88/11/19 | 88/12/18 |
| 926 | 2.11.2.11 | لوله كشي تهويه طبقه هشتم | 30d | 2010-03-28 | 2010-04-26 | 912SS+10d | 98d | 86d | 88/06/01 | 88/06/20 | مترطول | 89/1/8 | 89/2/6 |
| 927 | 2.11.2.12 | لوله كشي تهويه طبقه نهم | 30d | 2010-05-07 | 2010-06-05 | 913SS+10d | 68d | 61d | 88/06/21 | 88/07/09 | مترطول | 89/2/17 | 89/3/15 |
| 928 | 2.11.2.13 | لوله كشي تهويه طبقه دهم | 31d | 2010-06-16 | 2010-07-16 | 914SS+10d | 37d |  | 88/07/10 | 88/07/29 | درصد | 89/3/26 | 89/4/25 |
| 929 | 2.11.3 | **اجراي لوله كشي آتش نشاني و نصب جعبه ها** | 91d | 2010-03-06 | 2010-06-12 |  | 0d |  | 87/12/06 | 88/07/29 | درصد | 88/12/15 | 89/3/22 |
| 930 | 2.11.3.1 | اجراي لوله آتش نشاني و نصب جعبه هاي زيرزمين دوم | 7d | 2010-03-06 | 2010-03-12 | 886 | 0d |  |  |  | درصد | 88/12/15 | 88/12/21 |
| 931 | 2.11.3.2 | اجراي لوله آتش نشاني و نصب جعبه هاي زيرزمين اول | 7d | 2010-03-13 | 2010-03-27 | 930, 1018 | 0d |  | 87/12/06 | 87/12/25 | درصد | 88/12/22 | 89/1/7 |
| 932 | 2.11.3.3 | اجراي لوله آتش نشاني و نصب جعبه هاي طبقه همكف | 7d | 2010-03-28 | 2010-04-03 | 862, 931 | 0d |  | 87/12/26 | 88/01/15 | درصد | 89/1/8 | 89/1/14 |
| 933 | 2.11.3.4 | اجراي لوله آتش نشاني و نصب جعبه هاي طبقه اول | 7d | 2010-04-04 | 2010-04-10 | 863, 932 | 44d | 0d | 88/01/16 | 88/02/04 | درصد | 89/1/15 | 89/1/21 |
| 934 | 2.11.3.5 | اجراي لوله آتش نشاني و نصب جعبه هاي طبقه دوم | 7d | 2010-04-11 | 2010-04-17 | 864, 933 | 47d | 0d | 88/02/05 | 88/02/24 | درصد | 89/1/22 | 89/1/28 |
| 935 | 2.11.3.6 | اجراي لوله آتش نشاني و نصب جعبه هاي طبقه سوم | 7d | 2010-04-18 | 2010-04-24 | 865, 934 | 50d | 0d | 88/02/25 | 88/03/13 | درصد | 89/1/29 | 89/2/4 |
| 936 | 2.11.3.7 | اجراي لوله آتش نشاني و نصب جعبه هاي طبقه جهارم | 7d | 2010-04-25 | 2010-05-01 | 866, 935 | 53d | 0d | 88/03/14 | 88/04/02 | درصد | 89/2/5 | 89/2/11 |
| 937 | 2.11.3.8 | اجراي لوله آتش نشاني و نصب جعبه هاي طبقه پنجم | 7d | 2010-05-02 | 2010-05-08 | 867, 936 | 56d | 0d | 88/04/03 | 88/04/22 | درصد | 89/2/12 | 89/2/18 |
| 938 | 2.11.3.9 | اجراي لوله آتش نشاني و نصب جعبه هاي طبقه ششم | 7d | 2010-05-09 | 2010-05-15 | 868, 937 | 59d | 0d | 88/04/23 | 88/05/11 | درصد | 89/2/19 | 89/2/25 |
| 939 | 2.11.3.10 | اجراي لوله آتش نشاني و نصب جعبه هاي طبقه هفتم | 7d | 2010-05-16 | 2010-05-22 | 869, 938 | 62d | 0d | 88/05/12 | 88/05/31 | درصد | 89/2/26 | 89/3/1 |
| 940 | 2.11.3.11 | اجراي لوله آتش نشاني و نصب جعبه هاي طبقه هشتم | 7d | 2010-05-23 | 2010-05-29 | 870, 939 | 65d | 0d | 88/06/01 | 88/06/20 | درصد | 89/3/2 | 89/3/8 |
| 941 | 2.11.3.12 | اجراي لوله آتش نشاني و نصب جعبه هاي طبقه نهم | 7d | 2010-05-30 | 2010-06-05 | 871, 940 | 68d | 0d | 88/06/21 | 88/07/09 | درصد | 89/3/9 | 89/3/15 |
| 942 | 2.11.3.13 | اجراي لوله آتش نشاني و نصب جعبه هاي طبقه دهم | 7d | 2010-06-06 | 2010-06-12 | 872, 941 | 71d |  | 88/07/10 | 88/07/29 | درصد | 89/3/16 | 89/3/22 |

| ID | WBS | Task | Duration | Start | Finish | Predecessors | Total slack | Text1 | Text2 | واحد | Plan Start | Plan Finish |
| --- | --- | --- | --- | --- | --- | --- | --- | --- | --- | --- | --- | --- |
| 943 | 2.11.4 | **لوله كشي سرد و گرم طبقات** | 197d | 2010-01-30 | 2010-08-22 |  | 0d | 87/12/06 | 88/07/29 | درصد | 88/11/10 | 89/5/31 |
| 944 | 2.11.4.1 | لوله كشي سرد و گرم زيرزمين دوم | 15d | 2010-01-30 | 2010-02-14 | 1017, 1001, 945SF | 0d |  |  | مترطول | 88/11/10 | 88/11/25 |
| 945 | 2.11.4.2 | لوله كشي سرد و گرم زيرزمين اول | 15d | 2010-02-14 | 2010-03-01 | 1018, 1002, 946SF | 0d | 87/12/06 | 87/12/25 | مترطول | 88/11/25 | 88/12/10 |
| 946 | 2.11.4.3 | لوله كشي سرد و گرم طبقه همكف | 15d | 2010-03-01 | 2010-03-16 | 862, 1003, 947SF | 0d | 87/12/26 | 88/01/15 | مترطول | 88/12/10 | 88/12/25 |
| 947 | 2.11.4.4 | لوله كشي سرد و گرم طبقه اول | 15d | 2010-03-16 | 2010-04-08 | 863, 1004, 948SF | 0d | 88/01/16 | 88/02/04 | مترطول | 88/12/25 | 89/1/19 |
| 948 | 2.11.4.5 | لوله كشي سرد و گرم طبقه دوم | 15d | 2010-04-08 | 2010-04-23 | 864, 1005, 949SF | 0d | 88/02/05 | 88/02/24 | مترطول | 89/1/19 | 89/2/3 |
| 949 | 2.11.4.6 | لوله كشي سرد و گرم طبقه سوم | 15d | 2010-04-23 | 2010-05-08 | 865, 1006, 950SF | 0d | 88/02/25 | 88/03/13 | مترطول | 89/2/3 | 89/2/18 |
| 950 | 2.11.4.7 | لوله كشي سرد و گرم طبقه چهارم | 15d | 2010-05-08 | 2010-05-23 | 866, 1007, 951SF | 0d | 88/03/14 | 88/04/02 | مترطول | 89/2/18 | 89/3/2 |
| 951 | 2.11.4.8 | لوله كشي سرد و گرم طبقه پنجم | 15d | 2010-05-23 | 2010-06-07 | 867, 1008, 952SF | 0d | 88/04/03 | 88/04/22 | مترطول | 89/3/2 | 89/3/17 |
| 952 | 2.11.4.9 | لوله كشي سرد و گرم طبقه ششم | 15d | 2010-06-07 | 2010-06-22 | 868, 1009, 953SF | 0d | 88/04/23 | 88/05/11 | مترطول | 89/3/17 | 89/4/1 |
| 953 | 2.11.4.10 | لوله كشي سرد و گرم طبقه هفتم | 15d | 2010-06-22 | 2010-07-07 | 869, 1010, 954SF | 0d | 88/05/12 | 88/05/31 | مترطول | 89/4/1 | 89/4/16 |
| 954 | 2.11.4.11 | لوله كشي سرد و گرم طبقه هشتم | 15d | 2010-07-07 | 2010-07-22 | 870, 1011, 955SF | 0d | 88/06/01 | 88/06/20 | مترطول | 89/4/16 | 89/4/31 |
| 955 | 2.11.4.12 | لوله كشي سرد و گرم طبقه نهم | 15d | 2010-07-22 | 2010-08-06 | 871, 1012, 956SF | 0d | 88/06/21 | 88/07/09 | مترطول | 89/4/31 | 89/5/15 |
| 956 | 2.11.4.13 | لوله كشي سرد و گرم طبقه دهم | 17d | 2010-08-06 | 2010-08-22 | 872, 1013 | 0d | 88/07/10 | 88/07/29 | مترطول | 89/5/15 | 89/5/31 |
| 957 | 2.11.5 | **لوله كشي گرمايش طبقات** | 197d | 2010-01-30 | 2010-08-22 |  | 0d | 87/12/06 | 88/07/29 | درصد | 88/11/10 | 89/5/31 |
| 958 | 2.11.5.1 | لوله كشي گرمايش زيرزمين دوم | 15d | 2010-01-30 | 2010-02-13 | 944SS | 0d |  |  | مترطول | 88/11/10 | 88/11/24 |
| 959 | 2.11.5.2 | لوله كشي گرمايش زيرزمين اول | 15d | 2010-02-14 | 2010-02-28 | 945SS, 958, 1018 | 0d | 87/12/06 | 87/12/25 | مترطول | 88/11/25 | 88/12/9 |
| 960 | 2.11.5.3 | لوله كشي گرمايش طبقه همكف | 15d | 2010-03-01 | 2010-03-15 | 862, 946SS, 959 | 0d | 87/12/26 | 88/01/15 | مترطول | 88/12/10 | 88/12/24 |
| 961 | 2.11.5.4 | لوله كشي گرمايش طبقه اول | 15d | 2010-03-16 | 2010-04-07 | 863, 947SS, 960 | 0d | 88/01/16 | 88/02/04 | مترطول | 88/12/25 | 89/1/18 |
| 962 | 2.11.5.5 | لوله كشي گرمايش طبقه دوم | 15d | 2010-04-08 | 2010-04-22 | 864, 948SS, 961 | 0d | 88/02/05 | 88/02/24 | مترطول | 89/1/19 | 89/2/2 |
| 963 | 2.11.5.6 | لوله كشي گرمايش طبقه سوم | 15d | 2010-04-23 | 2010-05-07 | 865, 949SS, 962 | 0d | 88/02/25 | 88/03/13 | مترطول | 89/2/3 | 89/2/17 |
| 964 | 2.11.5.7 | لوله كشي گرمايش طبقه چهارم | 15d | 2010-05-08 | 2010-05-22 | 866, 950SS, 963 | 0d | 88/03/14 | 88/04/02 | مترطول | 89/2/18 | 89/3/1 |
| 965 | 2.11.5.8 | لوله كشي گرمايش طبقه پنجم | 15d | 2010-05-23 | 2010-06-06 | 867, 951SS, 964 | 0d | 88/04/03 | 88/04/22 | مترطول | 89/3/2 | 89/3/16 |
| 966 | 2.11.5.9 | لوله كشي گرمايش طبقه ششم | 15d | 2010-06-07 | 2010-06-21 | 868, 952SS, 965 | 0d | 88/04/23 | 88/05/11 | مترطول | 89/3/17 | 89/3/31 |
| 967 | 2.11.5.10 | لوله كشي گرمايش طبقه هفتم | 15d | 2010-06-22 | 2010-07-06 | 869, 953SS, 966 | 0d | 88/05/12 | 88/05/31 | مترطول | 89/4/1 | 89/4/15 |
| 968 | 2.11.5.11 | لوله كشي گرمايش طبقه هشتم | 15d | 2010-07-07 | 2010-07-21 | 870, 954SS, 967 | 0d | 88/06/01 | 88/06/20 | مترطول | 89/4/16 | 89/4/30 |
| 969 | 2.11.5.12 | لوله كشي گرمايش طبقه نهم | 15d | 2010-07-22 | 2010-08-05 | 871, 955SS, 968 | 0d | 88/06/21 | 88/07/09 | مترطول | 89/4/31 | 89/5/14 |
| 970 | 2.11.5.13 | لوله كشي گرمايش طبقه دهم | 17d | 2010-08-06 | 2010-08-22 | 872, 956SS, 969 | 0d | 88/07/10 | 88/07/29 | مترطول | 89/5/15 | 89/5/31 |

| ID | WBS | Task | Duration | Start | Finish | Predecessors | Total slack | Free slack | Text1 | Text2 | واحد | Plan Start | Plan Finish |
| --- | --- | --- | --- | --- | --- | --- | --- | --- | --- | --- | --- | --- | --- |
| 971 | 2.11.6 | **لوله كشي سرمايش(سيستم اسپليت) طبقات** | 197d | 2010-01-30 | 2010-08-22 |  | 0d |  | 87/12/06 | 88/07/29 | درصد | 88/11/10 | 89/5/31 |
| 972 | 2.11.6.1 | لوله كشي سرمايش(سيستم اسپليت) زيرزمين دوم | 15d | 2010-01-30 | 2010-02-13 | 958SS, 1017 | 0d |  |  |  | مترطول | 88/11/10 | 88/11/24 |
| 973 | 2.11.6.2 | لوله كشي سرمايش(سيستم اسپليت )زيرزمين اول | 15d | 2010-02-14 | 2010-02-28 | 972, 1018 | 0d |  | 87/12/06 | 87/12/25 | مترطول | 88/11/25 | 88/12/9 |
| 974 | 2.11.6.3 | لوله كشي سرمايش(سيستم اسپليت ) طبقه همكف | 15d | 2010-03-01 | 2010-03-15 | 862, 973 | 0d |  | 87/12/26 | 88/01/15 | مترطول | 88/12/10 | 88/12/24 |
| 975 | 2.11.6.4 | لوله كشي سرمايش(سيستم اسپليت )طبقه اول | 15d | 2010-03-16 | 2010-04-07 | 863, 974 | 0d |  | 88/01/16 | 88/02/04 | مترطول | 88/12/25 | 89/1/18 |
| 976 | 2.11.6.5 | لوله كشي سرمايش(سيستم اسپليت ) طبقه دوم | 15d | 2010-04-08 | 2010-04-22 | 864, 975 | 0d |  | 88/02/05 | 88/02/24 | مترطول | 89/1/19 | 89/2/2 |
| 977 | 2.11.6.6 | لوله كشي سرمايش(سيستم اسپليت ) طبقه سوم | 15d | 2010-04-23 | 2010-05-07 | 865, 976 | 0d |  | 88/02/25 | 88/03/13 | مترطول | 89/2/3 | 89/2/17 |
| 978 | 2.11.6.7 | لوله كشي سرمايش(سيستم اسپليت ) طبقه چهارم | 15d | 2010-05-08 | 2010-05-22 | 866, 977 | 0d |  | 88/03/14 | 88/04/02 | مترطول | 89/2/18 | 89/3/1 |
| 979 | 2.11.6.8 | لوله كشي سرمايش(سيستم اسپليت )طبقه پنجم | 15d | 2010-05-23 | 2010-06-06 | 867, 978 | 0d |  | 88/04/03 | 88/04/22 | مترطول | 89/3/2 | 89/3/16 |
| 980 | 2.11.6.9 | لوله كشي سرمايش(سيستم اسپليت ) طبقه ششم | 15d | 2010-06-07 | 2010-06-21 | 868, 979 | 0d |  | 88/04/23 | 88/05/11 | مترطول | 89/3/17 | 89/3/31 |
| 981 | 2.11.6.10 | لوله كشي سرمايش(سيستم اسپليت ) طبقه هفتم | 15d | 2010-06-22 | 2010-07-06 | 869, 980 | 0d |  | 88/05/12 | 88/05/31 | مترطول | 89/4/1 | 89/4/15 |
| 982 | 2.11.6.11 | لوله كشي سرمايش(سيستم اسپليت )طبقه هشتم | 15d | 2010-07-07 | 2010-07-21 | 870, 981 | 0d |  | 88/06/01 | 88/06/20 | مترطول | 89/4/16 | 89/4/30 |
| 983 | 2.11.6.12 | لوله كشي سرمايش(سيستم اسپليت )طبقه نهم | 15d | 2010-07-22 | 2010-08-05 | 871, 982 | 0d |  | 88/06/21 | 88/07/09 | مترطول | 89/4/31 | 89/5/14 |
| 984 | 2.11.6.13 | لوله كشي سرمايش(سيستم اسپليت )طبقه دهم | 17d | 2010-08-06 | 2010-08-22 | 872, 983 | 0d |  | 88/07/10 | 88/07/29 | مترطول | 89/5/15 | 89/5/31 |
| 985 | 2.12 | **فاز اول تاسيسات برقي طبقات** | 601d | 2008-11-26 | 2010-08-05 |  | 17d |  | 87/12/06 | 88/07/29 | درصد | 87/9/6 | 89/5/14 |
| 986 | 2.12.1 | **اجراي سيستم ارت بندي طبقات** | 457d | 2008-11-26 | 2010-03-06 |  | 161d |  |  |  |  | 87/9/6 | 88/12/15 |
| 987 | 2.12.1.1 | اجراي سيستم ارت بندي( زيرزمين دوم ) | 15d | 2008-11-26 | 2008-12-10 | 1017 | 423d | 18d |  |  | درصد | 87/9/6 | 87/9/20 |
| 988 | 2.12.1.2 | اجراي سيستم ارت بندي( زيرزمين اول ) | 15d | 2008-12-29 | 2009-01-12 | 987, 1018 | 405d | 28d | 87/12/06 | 87/12/25 | درصد | 87/10/9 | 87/10/23 |
| 989 | 2.12.1.3 | اجراي سيستم ارت بندي( همكف ) | 15d | 2009-02-10 | 2009-02-24 | 862, 988 | 377d | 18d | 87/12/26 | 88/01/15 | درصد | 87/11/22 | 87/12/6 |
| 990 | 2.12.1.4 | اجراي سيستم ارت بندي طبقه اول | 15d | 2009-03-15 | 2009-04-07 | 863, 989 | 359d | 18d | 88/01/16 | 88/02/04 | درصد | 87/12/25 | 88/1/18 |
| 991 | 2.12.1.5 | اجراي سيستم ارت بندي طبقه دوم | 15d | 2009-04-26 | 2009-05-10 | 864, 990 | 341d | 18d | 88/02/05 | 88/02/24 | درصد | 88/2/6 | 88/2/20 |
| 992 | 2.12.1.6 | اجراي سيستم ارت بندي طبقه سوم | 15d | 2009-05-29 | 2009-06-12 | 865, 991 | 323d | 18d | 88/02/25 | 88/03/13 | درصد | 88/3/8 | 88/3/22 |
| 993 | 2.12.1.7 | اجراي سيستم ارت بندي طبقه چهارم | 15d | 2009-07-01 | 2009-07-15 | 866, 992 | 305d | 18d | 88/03/14 | 88/04/02 | درصد | 88/4/10 | 88/4/24 |
| 994 | 2.12.1.8 | اجراي سيستم ارت بندي طبقه پنجم | 15d | 2009-08-03 | 2009-08-17 | 867, 993 | 287d | 26d | 88/04/03 | 88/04/22 | درصد | 88/5/12 | 88/5/26 |
| 995 | 2.12.1.9 | اجراي سيستم ارت بندي طبقه ششم | 15d | 2009-09-13 | 2009-09-27 | 868, 994 | 261d | 25d | 88/04/23 | 88/05/11 | درصد | 88/6/22 | 88/7/5 |
| 996 | 2.12.1.10 | اجراي سيستم ارت بندي طبقه هفتم | 15d | 2009-10-23 | 2009-11-06 | 869, 995 | 236d | 25d | 88/05/12 | 88/05/31 | درصد | 88/8/1 | 88/8/15 |
| 997 | 2.12.1.11 | اجراي سيستم ارت بندي طبقه هشتم | 15d | 2009-12-02 | 2009-12-16 | 870, 996 | 211d | 25d | 88/06/01 | 88/06/20 | درصد | 88/9/11 | 88/9/25 |
| 998 | 2.12.1.12 | اجراي سيستم ارت بندي طبقه نهم | 15d | 2010-01-11 | 2010-01-25 | 871, 997 | 186d | 25d | 88/06/21 | 88/07/09 | درصد | 88/10/21 | 88/11/5 |
| 999 | 2.12.1.13 | اجراي سيستم ارت بندي طبقه دهم | 15d | 2010-02-20 | 2010-03-06 | 872, 998 | 161d |  | 88/07/10 | 88/07/29 | درصد | 88/12/1 | 88/12/15 |

| ID | WBS | Task | Duration | Start | Finish | Predecessors | Total slack | Free slack | Plan Start | Plan Finish | واحد | Text1 | Text2 |
| --- | --- | --- | --- | --- | --- | --- | --- | --- | --- | --- | --- | --- | --- |
| 1000 | 2.12.2 | **لوله گذاري و نصب قوطي كليد و پريز طبقات** | 481d | 2009-04-04 | 2010-08-05 |  | 0d |  | 88/1/15 | 89/5/14 |  |  |  |
| 1001 | 2.12.2.1 | لوله گذاري و نصب قوطي كليد و پريز( زيرزمين دوم ) | 30d | 2009-04-04 | 2009-05-03 | 902, 1017FS+120d | 91d | 0d | 88/1/15 | 88/2/13 | درصد |  |  |
| 1002 | 2.12.2.2 | لوله گذاري و نصب قوطي كليد و پريز( زيرزمين اول ) | 30d | 2009-05-04 | 2009-06-02 | 903, 1001, 1018FS+10d | 91d | 0d | 88/2/14 | 88/3/12 | درصد | 87/12/06 | 87/12/25 |
| 1003 | 2.12.2.3 | لوله گذاري و نصب قوطي كليد و پريز( همكف ) | 30d | 2009-06-03 | 2009-07-02 | 862FS+10d, 904, 1002 | 91d | 0d | 88/3/13 | 88/4/11 | درصد | 87/12/26 | 88/01/15 |
| 1004 | 2.12.2.4 | لوله گذاري و نصب قوطي كليد و پريز 1 | 30d | 2009-07-03 | 2009-08-01 | 863FS+10d, 905, 1003 | 91d | 10d | 88/4/12 | 88/5/10 | درصد | 88/01/16 | 88/02/04 |
| 1005 | 2.12.2.5 | لوله گذاري و نصب قوطي كليد و پريز 2 | 30d | 2009-08-12 | 2009-09-10 | 864FS+10d, 906, 1004 | 81d | 10d | 88/5/21 | 88/6/19 | درصد | 88/02/05 | 88/02/24 |
| 1006 | 2.12.2.6 | لوله گذاري و نصب قوطي كليد و پريز 3 | 30d | 2009-09-21 | 2009-10-20 | 865FS+10d, 907, 1005 | 71d | 10d | 88/6/30 | 88/7/28 | درصد | 88/02/25 | 88/03/13 |
| 1007 | 2.12.2.7 | لوله گذاري و نصب قوطي كليد و پريز 4 | 30d | 2009-10-31 | 2009-11-29 | 866FS+10d, 908, 1006 | 61d | 10d | 88/8/9 | 88/9/8 | درصد | 88/03/14 | 88/04/02 |
| 1008 | 2.12.2.8 | لوله گذاري و نصب قوطي كليد و پريز 5 | 30d | 2009-12-10 | 2010-01-08 | 867FS+10d, 909, 1007 | 51d | 10d | 88/9/19 | 88/10/18 | درصد | 88/04/03 | 88/04/22 |
| 1009 | 2.12.2.9 | لوله گذاري و نصب قوطي كليد و پريز 6 | 30d | 2010-01-19 | 2010-02-17 | 868FS+10d, 910, 1008 | 41d | 10d | 88/10/29 | 88/11/28 | درصد | 88/04/23 | 88/05/11 |
| 1010 | 2.12.2.10 | لوله گذاري و نصب قوطي كليد و پريز 7 | 30d | 2010-02-28 | 2010-04-06 | 869FS+10d, 911, 1009 | 31d | 10d | 88/12/9 | 89/1/17 | درصد | 88/05/12 | 88/05/31 |
| 1011 | 2.12.2.11 | لوله گذاري و نصب قوطي كليد و پريز 8 | 30d | 2010-04-17 | 2010-05-16 | 870FS+10d, 912, 1010 | 21d | 10d | 89/1/28 | 89/2/26 | درصد | 88/06/01 | 88/06/20 |
| 1012 | 2.12.2.12 | لوله گذاري و نصب قوطي كليد و پريز 9 | 30d | 2010-05-27 | 2010-06-25 | 871FS+10d, 913, 1011 | 11d |  | 89/3/6 | 89/4/4 | درصد | 88/06/21 | 88/07/09 |
| 1013 | 2.12.2.13 | لوله گذاري و نصب قوطي كليد و پريز 10 | 30d | 2010-07-07 | 2010-08-05 | 872FS+10d, 914, 1012 | 0d |  | 89/4/16 | 89/5/14 | درصد | 88/07/10 | 88/07/29 |
| 1014 | 2.13 | **نازك كاري** | 711d | 2008-11-06 | 2010-11-03 |  | 0d |  | 87/8/16 | 89/8/12 | درصد | 87/10/06 | 88/12/04 |
| 1015 | 2.13.1 | اجراي بتن كف پاركينگ و كفسازي | 10d | 2010-02-14 | 2010-02-23 | 944, 987 | 233d | 0d | 88/11/25 | 88/12/4 | درصد | 87/10/06 | 88/02/04 |
| 1016 | 2.13.2 | **سيمانكاري آستر و رويه زيرزمين پاركينگ** | 53d | 2008-11-06 | 2008-12-28 |  | 0d |  | 87/8/16 | 87/10/8 |  |  |  |
| 1017 | 2.13.2.1 | سيمانكاري آستر و رويه زيرزمين دوم | 20d | 2008-11-06 | 2008-11-25 | 834 | 0d |  | 87/8/16 | 87/9/5 | مترمربع |  |  |
| 1018 | 2.13.2.2 | سيمانكاري آستر و رويه زيرزمين اول | 20d | 2008-12-09 | 2008-12-28 | 835, 1017 | 57d | 0d | 87/9/19 | 87/10/8 | مترمربع | 87/12/06 | 87/12/25 |
| 1019 | 2.13.3 | **پلاستر سيمان سرويسها،آشپزخانه ها،،بالكن هاو…** | 151d | 2010-04-04 | 2010-09-01 |  | 0d |  | 89/1/15 | 89/6/10 |  |  |  |
| 1020 | 2.13.3.1 | پلاستر سيمان سرويسها،آشپزخانه هاو،بالكن هاي طبقه همكف | 10d | 2010-04-04 | 2010-04-13 | 904, 918, 932, 946, 960, 974, 989, 1003 | 0d |  | 89/1/15 | 89/1/24 | متر مربع |  |  |
| 1021 | 2.13.3.2 | پلاستر سيمان سرويسها،آشپزخانه هاو،بالكن هاي طبقه اول | 10d | 2010-04-11 | 2010-04-20 | 905, 919, 933, 947, 961, 975, 990, 1004 | 44d | 0d | 89/1/22 | 89/1/31 | متر مربع |  |  |
| 1022 | 2.13.3.3 | پلاستر سيمان سرويسها،آشپزخانه هاو،بالكن هاي طبقه دوم | 10d | 2010-04-23 | 2010-05-02 | 906, 920, 934, 948, 962, 976, 991, 1005 | 42d | 0d | 89/2/3 | 89/2/12 | متر مربع |  |  |
| 1023 | 2.13.3.4 | پلاستر سيمان سرويسها،آشپزخانه هاو،بالكن هاي طبقه سوم | 10d | 2010-05-08 | 2010-05-17 | 907, 921, 935, 949, 963, 977, 992, 1006 | 37d | 0d | 89/2/18 | 89/2/27 | متر مربع |  |  |
| 1024 | 2.13.3.5 | پلاستر سيمان سرويسها،آشپزخانه هاو،بالكن هاي طبقه چهارم | 10d | 2010-05-23 | 2010-06-01 | 908, 922, 936, 950, 964, 978, 993, 1007 | 32d | 0d | 89/3/2 | 89/3/11 | متر مربع |  |  |
| 1025 | 2.13.3.6 | پلاستر سيمان سرويسها،آشپزخانه هاو،بالكن هاي طبقه پنجم | 10d | 2010-06-07 | 2010-06-16 | 909, 923, 937, 951, 965, 979, 994, 1008 | 27d | 0d | 89/3/17 | 89/3/26 | متر مربع |  |  |
| 1026 | 2.13.3.7 | پلاستر سيمان سرويسها،آشپزخانه هاو،بالكن هاي طبقه ششم | 10d | 2010-06-22 | 2010-07-01 | 910, 924, 938, 952, 966, 980, 995, 1009 | 22d | 0d | 89/4/1 | 89/4/10 | متر مربع |  |  |
| 1027 | 2.13.3.8 | پلاستر سيمان سرويسها،آشپزخانه هاو،بالكن هاي طبقه هفتم | 10d | 2010-07-07 | 2010-07-16 | 911, 925, 939, 953, 967, 981, 996, 1010 | 17d | 0d | 89/4/16 | 89/4/25 | متر مربع |  |  |
| 1028 | 2.13.3.9 | پلاستر سيمان سرويسها،آشپزخانه هاو،بالكن هاي طبقه هشتم | 10d | 2010-07-22 | 2010-07-31 | 912, 926, 940, 954, 968, 982, 997, 1011 | 12d | 0d | 89/4/31 | 89/5/9 | متر مربع |  |  |
| 1029 | 2.13.3.10 | پلاستر سيمان سرويسها،آشپزخانه هاو،بالكن هاي طبقه نهم | 10d | 2010-08-06 | 2010-08-15 | 913, 927, 941, 955, 969, 983, 998, 1012 | 7d | 0d | 89/5/15 | 89/5/24 | متر مربع |  |  |
| 1030 | 2.13.3.11 | پلاستر سيمان سرويسها،آشپزخانه هاو،بالكن هاي طبقه دهم | 10d | 2010-08-23 | 2010-09-01 | 914, 928, 942, 956, 970, 984, 999, 1013 | 0d |  | 89/6/1 | 89/6/10 | متر مربع |  |  |

| ID | WBS | Task | Duration | Start | Finish | Predecessors | Total slack | Free slack | Plan Start | Plan Finish | Text1 | Text2 | واحد |
| --- | --- | --- | --- | --- | --- | --- | --- | --- | --- | --- | --- | --- | --- |
| 1031 | 2.13.4 | **نصب پنجره ها و شيشه هاي طبقات** | 146d | 2010-04-04 | 2010-08-27 |  | 76d | 0d | 89/1/15 | 89/6/5 |  |  |  |
| 1032 | 2.13.4.1 | نصب پنجره ها و شيشه هاي طبقه همكف | 5d | 2010-04-04 | 2010-04-08 | 1020SS | 217d |  | 89/1/15 | 89/1/19 |  |  |  |
| 1033 | 2.13.4.2 | نصب پنجره ها و شيشه هاي طبقه اول | 5d | 2010-04-11 | 2010-04-15 | 1021SS | 210d |  | 89/1/22 | 89/1/26 |  |  |  |
| 1034 | 2.13.4.3 | نصب پنجره ها و شيشه هاي طبقه دوم | 5d | 2010-04-23 | 2010-04-27 | 1022SS | 198d |  | 89/2/3 | 89/2/7 |  |  |  |
| 1035 | 2.13.4.4 | نصب پنجره ها و شيشه هاي طبقه سوم | 5d | 2010-05-08 | 2010-05-12 | 1023SS | 183d |  | 89/2/18 | 89/2/22 |  |  |  |
| 1036 | 2.13.4.5 | نصب پنجره ها و شيشه هاي طبقه چهارم | 5d | 2010-05-23 | 2010-05-27 | 1024SS | 168d |  | 89/3/2 | 89/3/6 |  |  |  |
| 1037 | 2.13.4.6 | نصب پنجره ها و شيشه هاي طبقه پنجم | 5d | 2010-06-07 | 2010-06-11 | 1025SS | 153d |  | 89/3/17 | 89/3/21 |  |  |  |
| 1038 | 2.13.4.7 | نصب پنجره ها و شيشه هاي طبقه ششم | 5d | 2010-06-22 | 2010-06-26 | 1026SS | 138d |  | 89/4/1 | 89/4/5 |  |  |  |
| 1039 | 2.13.4.8 | نصب پنجره ها و شيشه هاي طبقه هفتم | 5d | 2010-07-07 | 2010-07-11 | 1027SS | 123d |  | 89/4/16 | 89/4/20 |  |  |  |
| 1040 | 2.13.4.9 | نصب پنجره ها و شيشه هاي طبقه هشتم | 5d | 2010-07-22 | 2010-07-26 | 1028SS | 108d |  | 89/4/31 | 89/5/4 |  |  |  |
| 1041 | 2.13.4.10 | نصب پنجره ها و شيشه هاي طبقه نهم | 5d | 2010-08-06 | 2010-08-10 | 1029SS | 93d |  | 89/5/15 | 89/5/19 |  |  |  |
| 1042 | 2.13.4.11 | نصب پنجره ها و شيشه هاي طبقه دهم | 5d | 2010-08-23 | 2010-08-27 | 1030SS | 76d |  | 89/6/1 | 89/6/5 |  |  |  |
| 1043 | 2.13.5 | نماسازي | 94d | 2009-12-23 | 2010-04-04 | 821, 1031SF | 222d |  | 88/10/2 | 89/1/15 | 88/05/14 | 88/12/01 | مترمربع |
| 1044 | 2.13.6 | **عايق كاري سرويسها،آشپزخانه ها،بالكن ها و پشت بام** | 146d | 2010-04-24 | 2010-09-16 |  | 0d |  | 89/2/4 | 89/6/25 |  |  |  |
| 1045 | 2.13.6.1 | عايق كاري سرويسها،آشپزخانه هاو،بالكن هاي طبقه همكف | 5d | 2010-04-24 | 2010-04-28 | 888, 1020 | 0d |  | 89/2/4 | 89/2/8 |  |  | مترمربع |
| 1046 | 2.13.6.2 | عايق كاري سرويسها،آشپزخانه هاو،بالكن هاي طبقه اول | 5d | 2010-05-01 | 2010-05-05 | 889, 1021 | 44d | 0d | 89/2/11 | 89/2/15 |  |  | مترمربع |
| 1047 | 2.13.6.3 | عايق كاري سرويسها،آشپزخانه هاو،بالكن هاي طبقه دوم | 5d | 2010-05-13 | 2010-05-17 | 890, 1022 | 42d | 0d | 89/2/23 | 89/2/27 |  |  | مترمربع |
| 1048 | 2.13.6.4 | عايق كاري سرويسها،آشپزخانه هاو،بالكن هاي طبقه سوم | 5d | 2010-05-28 | 2010-06-01 | 891, 1023 | 37d | 0d | 89/3/7 | 89/3/11 |  |  | مترمربع |
| 1049 | 2.13.6.5 | عايق كاري سرويسها،آشپزخانه هاو،بالكن هاي طبقه چهارم | 5d | 2010-06-12 | 2010-06-16 | 892, 1024 | 32d | 0d | 89/3/22 | 89/3/26 |  |  | مترمربع |
| 1050 | 2.13.6.6 | عايق كاري سرويسها،آشپزخانه هاو،بالكن هاي طبقه پنجم | 5d | 2010-06-27 | 2010-07-01 | 893, 1025 | 27d | 0d | 89/4/6 | 89/4/10 |  |  | مترمربع |
| 1051 | 2.13.6.7 | عايق كاري سرويسها،آشپزخانه هاو،بالكن هاي طبقه ششم | 5d | 2010-07-12 | 2010-07-16 | 894, 1026 | 22d | 0d | 89/4/21 | 89/4/25 |  |  | مترمربع |
| 1052 | 2.13.6.8 | عايق كاري سرويسها،آشپزخانه هاو،بالكن هاي طبقه هفتم | 5d | 2010-07-27 | 2010-07-31 | 895, 1027 | 17d | 0d | 89/5/5 | 89/5/9 |  |  | مترمربع |
| 1053 | 2.13.6.9 | عايق كاري سرويسها،آشپزخانه هاو،بالكن هاي طبقه هشتم | 5d | 2010-08-11 | 2010-08-15 | 896, 1028 | 12d | 0d | 89/5/20 | 89/5/24 |  |  | مترمربع |
| 1054 | 2.13.6.10 | عايق كاري سرويسها،آشپزخانه هاو،بالكن هاي طبقه نهم | 5d | 2010-08-26 | 2010-08-30 | 897, 1029 | 7d | 0d | 89/6/4 | 89/6/8 |  |  | مترمربع |
| 1055 | 2.13.6.11 | عايق كاري سرويسها،آشپزخانه هاو،بالكن هاي طبقه دهم | 5d | 2010-09-12 | 2010-09-16 | 898, 1030 | 0d |  | 89/6/21 | 89/6/25 |  |  | مترمربع |

| ID | WBS | Task | Duration | Start | Finish | Predecessors | Total slack | Free slack | Plan Start | Plan Finish | واحد | Text1 | Text2 |
| --- | --- | --- | --- | --- | --- | --- | --- | --- | --- | --- | --- | --- | --- |
| 1056 | 2.13.7 | **سراميك كاري سرويسها و آشپزخانه هاوپذيرايي و اتاق خوابها** | 161d | 2010-04-29 | 2010-10-06 |  | 0d |  | 89/2/9 | 89/7/14 |  |  |  |
| 1057 | 2.13.7.1 | سراميك كاري سرويسها و آشپزخانه هاوپذيرايي و اتاق خوابهاي همكف | 20d | 2010-04-29 | 2010-05-18 | 1045 | 0d |  | 89/2/9 | 89/2/28 | مترمربع |  |  |
| 1058 | 2.13.7.2 | سراميك كاري سرويسها و آشپزخانه هاوپذيرايي و اتاق خوابهاي طبقه اول | 20d | 2010-05-06 | 2010-05-25 | 1046 | 44d | 0d | 89/2/16 | 89/3/4 | مترمربع |  |  |
| 1059 | 2.13.7.3 | سراميك كاري سرويسها و آشپزخانه هاوپذيرايي و اتاق خوابهاي طبقه دوم | 20d | 2010-05-18 | 2010-06-06 | 1047 | 42d | 0d | 89/2/28 | 89/3/16 | مترمربع |  |  |
| 1060 | 2.13.7.4 | سراميك كاري سرويسها و آشپزخانه هاوپذيرايي و اتاق خوابهاي طبقه سوم | 20d | 2010-06-02 | 2010-06-21 | 1048 | 37d | 0d | 89/3/12 | 89/3/31 | مترمربع |  |  |
| 1061 | 2.13.7.5 | سراميك كاري سرويسها و آشپزخانه هاوپذيرايي و اتاق خوابهاي طبقه چهارم | 20d | 2010-06-17 | 2010-07-06 | 1049 | 32d | 0d | 89/3/27 | 89/4/15 | مترمربع |  |  |
| 1062 | 2.13.7.6 | سراميك كاري سرويسها و آشپزخانه هاوپذيرايي و اتاق خوابهاي طبقه پنجم | 20d | 2010-07-02 | 2010-07-21 | 1050 | 27d | 0d | 89/4/11 | 89/4/30 | مترمربع |  |  |
| 1063 | 2.13.7.7 | سراميك كاري سرويسها و آشپزخانه هاوپذيرايي و اتاق خوابهاي طبقه ششم | 20d | 2010-07-17 | 2010-08-05 | 1051 | 22d | 0d | 89/4/26 | 89/5/14 | مترمربع |  |  |
| 1064 | 2.13.7.8 | سراميك كاري سرويسها و آشپزخانه هاوپذيرايي و اتاق خوابهاي طبقه هفتم | 20d | 2010-08-01 | 2010-08-20 | 1052 | 17d | 0d | 89/5/10 | 89/5/29 | مترمربع |  |  |
| 1065 | 2.13.7.9 | سراميك كاري سرويسها و آشپزخانه هاوپذيرايي و اتاق خوابهاي طبقه هشتم | 20d | 2010-08-16 | 2010-09-04 | 1053 | 12d | 0d | 89/5/25 | 89/6/13 | مترمربع |  |  |
| 1066 | 2.13.7.10 | سراميك كاري سرويسها و آشپزخانه هاوپذيرايي و اتاق خوابهاي طبقه نهم | 20d | 2010-08-31 | 2010-09-19 | 1054 | 7d | 0d | 89/6/9 | 89/6/28 | مترمربع |  |  |
| 1067 | 2.13.7.11 | سراميك كاري سرويسها و آشپزخانه هاوپذيرايي و اتاق خوابهاي طبقه دهم | 20d | 2010-09-17 | 2010-10-06 | 1055 | 0d |  | 89/6/26 | 89/7/14 | مترمربع |  |  |
| 1068 | 2.13.8 | **كاشيكاري سرويسها و آشپزخانه ها** | 161d | 2010-05-09 | 2010-10-16 |  | 0d |  | 89/2/19 | 89/7/24 |  | 87/12/06 | 88/08/10 |
| 1069 | 2.13.8.1 | كاشيكاري سرويسها و آشپزخانه هاي طبقه همكف | 20d | 2010-05-09 | 2010-05-28 | 1057SS+10d | 0d |  | 89/2/19 | 89/3/7 | مترمربع |  |  |
| 1070 | 2.13.8.2 | كاشيكاري سرويسها و آشپزخانه هاي طبقه اول | 20d | 2010-05-16 | 2010-06-04 | 1058SS+10d | 140d | 0d | 89/2/26 | 89/3/14 | مترمربع | 87/12/06 | 87/12/25 |
| 1071 | 2.13.8.3 | كاشيكاري سرويسها و آشپزخانه هاي طبقه دوم | 20d | 2010-05-28 | 2010-06-16 | 1059SS+10d | 128d | 0d | 89/3/7 | 89/3/26 | مترمربع | 88/01/26 | 88/02/14 |
| 1072 | 2.13.8.4 | كاشيكاري سرويسها و آشپزخانه هاي طبقه سوم | 20d | 2010-06-12 | 2010-07-01 | 1060SS+10d | 113d | 0d | 89/3/22 | 89/4/10 | مترمربع | 88/02/15 | 88/03/03 |
| 1073 | 2.13.8.5 | كاشيكاري سرويسها و آشپزخانه هاي طبقه چهارم | 20d | 2010-06-27 | 2010-07-16 | 1061SS+10d | 98d | 0d | 89/4/6 | 89/4/25 | مترمربع | 88/03/04 | 88/03/23 |
| 1074 | 2.13.8.6 | كاشيكاري سرويسها و آشپزخانه هاي طبقه پنجم | 20d | 2010-07-12 | 2010-07-31 | 1062SS+10d | 83d | 0d | 89/4/21 | 89/5/9 | مترمربع | 88/03/24 | 88/04/12 |
| 1075 | 2.13.8.7 | كاشيكاري سرويسها و آشپزخانه هاي طبقه ششم | 20d | 2010-07-27 | 2010-08-15 | 1063SS+10d | 68d | 0d | 89/5/5 | 89/5/24 | مترمربع | 88/04/13 | 88/05/01 |
| 1076 | 2.13.8.8 | كاشيكاري سرويسها و آشپزخانه هاي طبقه هفتم | 20d | 2010-08-11 | 2010-08-30 | 1064SS+10d | 53d | 0d | 89/5/20 | 89/6/8 | مترمربع | 88/05/02 | 88/05/21 |
| 1077 | 2.13.8.9 | كاشيكاري سرويسها و آشپزخانه هاي طبقه هشتم | 20d | 2010-08-26 | 2010-09-14 | 1065SS+10d | 38d | 0d | 89/6/4 | 89/6/23 | مترمربع | 88/05/22 | 88/06/10 |
| 1078 | 2.13.8.10 | كاشيكاري سرويسها و آشپزخانه هاي طبقه نهم | 20d | 2010-09-10 | 2010-09-29 | 1066SS+10d | 23d | 0d | 89/6/19 | 89/7/7 | مترمربع | 88/06/11 | 88/06/30 |
| 1079 | 2.13.8.11 | كاشيكاري سرويسها و آشپزخانه هاي طبقه دهم | 20d | 2010-09-27 | 2010-10-16 | 1067SS+10d | 4d | 0d | 89/7/5 | 89/7/24 | مترمربع | 88/06/31 | 88/07/19 |

| ID | WBS | Task | Duration | Start | Finish | Predecessors | Total slack | Free slack | Plan Start | Plan Finish | واحد |
| --- | --- | --- | --- | --- | --- | --- | --- | --- | --- | --- | --- |
| 1080 | 2.13.9 | **اجراي سنگ كف و اجراي پله ها** | 187d | 2010-02-14 | 2010-08-27 |  | 66d |  | 88/11/25 | 89/6/5 |  |
| 1081 | 2.13.9.1 | اجراي سنگ كف و اجراي پله هاي طبقه زيرزمين دوم | 5d | 2010-02-14 | 2010-02-18 | 944, 987 | 238d | 5d | 88/11/25 | 88/11/29 | مترمربع |
| 1082 | 2.13.9.2 | اجراي سنگ كف و اجراي پله هاي طبقه زيرزمين اول | 5d | 2010-03-01 | 2010-03-05 | 945, 988 | 233d | 15d | 88/12/10 | 88/12/14 | مترمربع |
| 1083 | 2.13.9.3 | اجراي سنگ كف و اجراي پله هاي طبقه همكف | 5d | 2010-04-04 | 2010-04-08 | 1020SS | 40d | 15d | 89/1/15 | 89/1/19 | مترمربع |
| 1084 | 2.13.9.4 | اجراي سنگ كف و اجراي پله هاي طبقه اول | 5d | 2010-04-11 | 2010-04-15 | 1021SS | 180d | 15d | 89/1/22 | 89/1/26 | مترمربع |
| 1085 | 2.13.9.5 | اجراي سنگ كف و اجراي پله هاي طبقه دوم | 5d | 2010-04-23 | 2010-04-27 | 1022SS | 168d | 15d | 89/2/3 | 89/2/7 | مترمربع |
| 1086 | 2.13.9.6 | اجراي سنگ كف و اجراي پله هاي طبقه سوم | 5d | 2010-05-08 | 2010-05-12 | 1023SS | 153d | 15d | 89/2/18 | 89/2/22 | مترمربع |
| 1087 | 2.13.9.7 | اجراي سنگ كف و اجراي پله هاي طبقه چهارم | 5d | 2010-05-23 | 2010-05-27 | 1024SS | 138d | 15d | 89/3/2 | 89/3/6 | مترمربع |
| 1088 | 2.13.9.8 | اجراي سنگ كف و اجراي پله هاي طبقه پنجم | 5d | 2010-06-07 | 2010-06-11 | 1025SS | 123d | 15d | 89/3/17 | 89/3/21 | مترمربع |
| 1089 | 2.13.9.9 | اجراي سنگ كف و اجراي پله هاي طبقه ششم | 5d | 2010-06-22 | 2010-06-26 | 1026SS | 108d | 15d | 89/4/1 | 89/4/5 | مترمربع |
| 1090 | 2.13.9.10 | اجراي سنگ كف و اجراي پله هاي طبقه هفتم | 5d | 2010-07-07 | 2010-07-11 | 1027SS | 93d | 15d | 89/4/16 | 89/4/20 | مترمربع |
| 1091 | 2.13.9.11 | اجراي سنگ كف و اجراي پله هاي طبقه هشتم | 5d | 2010-07-22 | 2010-07-26 | 1028SS | 78d | 15d | 89/4/31 | 89/5/4 | مترمربع |
| 1092 | 2.13.9.12 | اجراي سنگ كف و اجراي پله هاي طبقه نهم | 5d | 2010-08-06 | 2010-08-10 | 1029SS | 63d | 15d | 89/5/15 | 89/5/19 | مترمربع |
| 1093 | 2.13.9.13 | اجراي سنگ كف و اجراي پله هاي طبقه دهم | 5d | 2010-08-23 | 2010-08-27 | 1030SS | 44d | 15d | 89/6/1 | 89/6/5 | مترمربع |
| 1094 | 2.13.10 | **اجراي سنگ بدنه در راهروها و راه پله ها** | 202d | 2010-02-24 | 2010-09-21 |  | 51d |  | 88/12/5 | 89/6/30 |  |
| 1095 | 2.13.10.1 | اجراي سنگ بدنه در راهروها و راه پله هاي طبقه زيرزمين دوم | 10d | 2010-02-24 | 2010-03-05 | 1015, 1081 | 233d | 0d | 88/12/5 | 88/12/14 | مترمربع |
| 1096 | 2.13.10.2 | اجراي سنگ بدنه در راهروها و راه پله هاي طبقه زيرزمين اول | 10d | 2010-03-29 | 2010-04-07 | 887, 1082 | 218d |  | 89/1/9 | 89/1/18 | مترمربع |
| 1097 | 2.13.10.3 | اجراي سنگ بدنه در راهروها و راه پله هاي طبقه همكف | 10d | 2010-04-24 | 2010-05-03 | 888, 1083 | 25d |  | 89/2/4 | 89/2/13 | مترمربع |
| 1098 | 2.13.10.4 | اجراي سنگ بدنه در راهروها و راه پله هاي طبقه اول | 10d | 2010-05-01 | 2010-05-10 | 889, 1084 | 165d | 25d | 89/2/11 | 89/2/20 | مترمربع |
| 1099 | 2.13.10.5 | اجراي سنگ بدنه در راهروها و راه پله هاي طبقه دوم | 10d | 2010-05-13 | 2010-05-22 | 890, 1085 | 153d | 25d | 89/2/23 | 89/3/1 | مترمربع |
| 1100 | 2.13.10.6 | اجراي سنگ بدنه در راهروها و راه پله هاي طبقه سوم | 10d | 2010-05-28 | 2010-06-06 | 891, 1086 | 138d | 25d | 89/3/7 | 89/3/16 | مترمربع |
| 1101 | 2.13.10.7 | اجراي سنگ بدنه در راهروها و راه پله هاي طبقه چهارم | 10d | 2010-06-12 | 2010-06-21 | 892, 1087 | 123d | 25d | 89/3/22 | 89/3/31 | مترمربع |
| 1102 | 2.13.10.8 | اجراي سنگ بدنه در راهروها و راه پله هاي طبقه پنجم | 10d | 2010-06-27 | 2010-07-06 | 893, 1088 | 108d | 25d | 89/4/6 | 89/4/15 | مترمربع |
| 1103 | 2.13.10.9 | اجراي سنگ بدنه در راهروها و راه پله هاي طبقه ششم | 10d | 2010-07-12 | 2010-07-21 | 894, 1089 | 93d | 25d | 89/4/21 | 89/4/30 | مترمربع |
| 1104 | 2.13.10.10 | اجراي سنگ بدنه در راهروها و راه پله هاي طبقه هفتم | 10d | 2010-07-27 | 2010-08-05 | 895, 1090 | 78d | 25d | 89/5/5 | 89/5/14 | مترمربع |
| 1105 | 2.13.10.11 | اجراي سنگ بدنه در راهروها و راه پله هاي طبقه هشتم | 10d | 2010-08-11 | 2010-08-20 | 896, 1091 | 63d | 25d | 89/5/20 | 89/5/29 | مترمربع |
| 1106 | 2.13.10.12 | اجراي سنگ بدنه در راهروها و راه پله هاي طبقه نهم | 10d | 2010-08-26 | 2010-09-04 | 897, 1092 | 48d | 25d | 89/6/4 | 89/6/13 | مترمربع |
| 1107 | 2.13.10.13 | اجراي سنگ بدنه در راهروها و راه پله هاي طبقه دهم | 10d | 2010-09-12 | 2010-09-21 | 898, 1093 | 29d | 25d | 89/6/21 | 89/6/30 | مترمربع |

| ID | WBS | Task | Duration | Start | Finish | Predecessors | Total slack | Free slack | Plan Start | Plan Finish | واحد |
| --- | --- | --- | --- | --- | --- | --- | --- | --- | --- | --- | --- |
| 1108 | 2.13.11 | **اجراي موزاييك و قرنيز ديوارها** | 151d | 2010-04-24 | 2010-09-21 |  | 25d |  | 89/2/4 | 89/6/30 |  |
| 1109 | 2.13.11.1 | اجراي موزاييك و قرنيز ديوارها طبقه همكف | 10d | 2010-04-24 | 2010-05-03 | 888, 1083 | 25d |  | 89/2/4 | 89/2/13 | مترمربع |
| 1110 | 2.13.11.2 | اجراي موزاييك و قرنيز ديوارهاي طبقه اول | 10d | 2010-05-01 | 2010-05-10 | 889, 1084 | 165d | 25d | 89/2/11 | 89/2/20 | مترمربع |
| 1111 | 2.13.11.3 | اجراي موزاييك و قرنيز ديوارهاي طبقه دوم | 10d | 2010-05-13 | 2010-05-22 | 890, 1085 | 153d | 25d | 89/2/23 | 89/3/1 | مترمربع |
| 1112 | 2.13.11.4 | اجراي موزاييك و قرنيز ديوارهاي طبقه سوم | 10d | 2010-05-28 | 2010-06-06 | 891, 1086 | 138d | 25d | 89/3/7 | 89/3/16 | مترمربع |
| 1113 | 2.13.11.5 | اجراي موزاييك و قرنيز ديوارهاي طبقه چهارم | 10d | 2010-06-12 | 2010-06-21 | 892, 1087 | 123d | 25d | 89/3/22 | 89/3/31 | مترمربع |
| 1114 | 2.13.11.6 | اجراي موزاييك و قرنيز ديوارهاي طبقه پنجم | 10d | 2010-06-27 | 2010-07-06 | 893, 1088 | 108d | 25d | 89/4/6 | 89/4/15 | مترمربع |
| 1115 | 2.13.11.7 | اجراي موزاييك و قرنيز ديوارهاي طبقه ششم | 10d | 2010-07-12 | 2010-07-21 | 894, 1089 | 93d | 25d | 89/4/21 | 89/4/30 | مترمربع |
| 1116 | 2.13.11.8 | اجراي موزاييك و قرنيز ديوارهاي طبقه هفتم | 10d | 2010-07-27 | 2010-08-05 | 895, 1090 | 78d | 25d | 89/5/5 | 89/5/14 | مترمربع |
| 1117 | 2.13.11.9 | اجراي موزاييك و قرنيز ديوارهاي طبقه هشتم | 10d | 2010-08-11 | 2010-08-20 | 896, 1091 | 63d | 25d | 89/5/20 | 89/5/29 | مترمربع |
| 1118 | 2.13.11.10 | اجراي موزاييك و قرنيز ديوارهاي طبقه نهم | 10d | 2010-08-26 | 2010-09-04 | 897, 1092 | 48d | 25d | 89/6/4 | 89/6/13 | مترمربع |
| 1119 | 2.13.11.11 | اجراي موزاييك و قرنيز ديوارهاي طبقه دهم | 10d | 2010-09-12 | 2010-09-21 | 898, 1093 | 29d | 25d | 89/6/21 | 89/6/30 | مترمربع |
| 1120 | 2.13.12 | **اجراي كارهاي چوبي درهاي ورودي وادها،اتاق خوابها و …** | 110d | 2010-06-28 | 2010-10-15 |  | 1d |  | 89/4/7 | 89/7/23 |  |
| 1121 | 2.13.12.1 | اجراي كارهاي چوبي درهاي ورودي وادها،اتاق خوابهاي طبقه همكف | 10d | 2010-06-28 | 2010-07-07 | 1145 | 99d | 0d | 89/4/7 | 89/4/16 |  |
| 1122 | 2.13.12.2 | اجراي كارهاي چوبي درهاي ورودي وادها،اتاق خوابهاي طبقه اول | 10d | 2010-07-08 | 2010-07-17 | 1146 | 89d | 0d | 89/4/17 | 89/4/26 |  |
| 1123 | 2.13.12.3 | اجراي كارهاي چوبي درهاي ورودي وادها،اتاق خوابهاي طبقه دوم | 10d | 2010-07-18 | 2010-07-27 | 1147 | 79d | 0d | 89/4/27 | 89/5/5 |  |
| 1124 | 2.13.12.4 | اجراي كارهاي چوبي درهاي ورودي وادها،اتاق خوابهاي طبقه سوم | 10d | 2010-07-28 | 2010-08-06 | 1148 | 69d | 0d | 89/5/6 | 89/5/15 |  |
| 1125 | 2.13.12.5 | اجراي كارهاي چوبي درهاي ورودي وادها،اتاق خوابهاي طبقه چهارم | 10d | 2010-08-07 | 2010-08-16 | 1149 | 59d | 0d | 89/5/16 | 89/5/25 |  |
| 1126 | 2.13.12.6 | اجراي كارهاي چوبي درهاي ورودي وادها،اتاق خوابهاي طبقه پنجم | 10d | 2010-08-17 | 2010-08-26 | 1150 | 49d | 0d | 89/5/26 | 89/6/4 |  |
| 1127 | 2.13.12.7 | اجراي كارهاي چوبي درهاي ورودي وادها،اتاق خوابهاي طبقه ششم | 10d | 2010-08-27 | 2010-09-05 | 1151 | 39d | 0d | 89/6/5 | 89/6/14 |  |
| 1128 | 2.13.12.8 | اجراي كارهاي چوبي درهاي ورودي وادها،اتاق خوابهاي طبقه هفتم | 10d | 2010-09-06 | 2010-09-15 | 1152 | 29d | 0d | 89/6/15 | 89/6/24 |  |
| 1129 | 2.13.12.9 | اجراي كارهاي چوبي درهاي ورودي وادها،اتاق خوابهاي طبقه هشتم | 10d | 2010-09-16 | 2010-09-25 | 1153 | 19d | 0d | 89/6/25 | 89/7/3 |  |
| 1130 | 2.13.12.10 | اجراي كارهاي چوبي درهاي ورودي وادها،اتاق خوابهاي طبقه نهم | 10d | 2010-09-26 | 2010-10-05 | 1154 | 9d | 0d | 89/7/4 | 89/7/13 |  |
| 1131 | 2.13.12.11 | اجراي كارهاي چوبي درهاي ورودي وادها،اتاق خوابهاي طبقه دهم | 10d | 2010-10-06 | 2010-10-15 | 1155 | 1d |  | 89/7/14 | 89/7/23 |  |

| ID | WBS | Task | Duration | Start | Finish | Predecessors | Total slack | Text1 | Text2 | واحد | Plan Start | Plan Finish |
| --- | --- | --- | --- | --- | --- | --- | --- | --- | --- | --- | --- | --- |
| 1132 | 2.13.13 | **اجراي سقف كاذب سرويسهاي طبقات** | 156d | 2010-05-29 | 2010-10-31 |  | 11d | 88/02/15 | 88/09/19 | درصد | 89/3/8 | 89/8/9 |
| 1133 | 2.13.13.1 | اجراي سقف كاذب سرويسهاي طبقه همكف | 15d | 2010-05-29 | 2010-06-12 | 1069 | 152d | 88/02/15 | 88/03/03 | مترمربع | 89/3/8 | 89/3/22 |
| 1134 | 2.13.13.2 | اجراي سقف كاذب سرويسهاي طبقه اول | 15d | 2010-06-05 | 2010-06-19 | 1070 | 145d | 88/03/04 | 88/03/23 | مترمربع | 89/3/15 | 89/3/29 |
| 1135 | 2.13.13.3 | اجراي سقف كاذب سرويسهاي طبقه دوم | 15d | 2010-06-17 | 2010-07-01 | 1071 | 133d | 88/03/24 | 88/04/12 | مترمربع | 89/3/27 | 89/4/10 |
| 1136 | 2.13.13.4 | اجراي سقف كاذب سرويسهاي طبقه سوم | 15d | 2010-07-02 | 2010-07-16 | 1072 | 118d | 88/04/13 | 88/05/01 | مترمربع | 89/4/11 | 89/4/25 |
| 1137 | 2.13.13.5 | اجراي سقف كاذب سرويسهاي طبقه چهارم | 15d | 2010-07-17 | 2010-07-31 | 1073 | 103d | 88/05/02 | 88/05/21 | مترمربع | 89/4/26 | 89/5/9 |
| 1138 | 2.13.13.6 | اجراي سقف كاذب سرويسهاي طبقه پنجم | 15d | 2010-08-01 | 2010-08-15 | 1074 | 88d | 88/05/22 | 88/06/10 | مترمربع | 89/5/10 | 89/5/24 |
| 1139 | 2.13.13.7 | اجراي سقف كاذب سرويسهاي طبقه ششم | 15d | 2010-08-16 | 2010-08-30 | 1075 | 73d | 88/06/11 | 88/06/30 | مترمربع | 89/5/25 | 89/6/8 |
| 1140 | 2.13.13.8 | اجراي سقف كاذب سرويسهاي طبقه هفتم | 15d | 2010-08-31 | 2010-09-14 | 1076 | 58d | 88/06/31 | 88/07/19 | مترمربع | 89/6/9 | 89/6/23 |
| 1141 | 2.13.13.9 | اجراي سقف كاذب سرويسهاي طبقه هشتم | 15d | 2010-09-15 | 2010-09-29 | 1077 | 43d | 88/07/20 | 88/08/09 | مترمربع | 89/6/24 | 89/7/7 |
| 1142 | 2.13.13.10 | اجراي سقف كاذب سرويسهاي طبقه نهم | 15d | 2010-09-30 | 2010-10-14 | 1078 | 28d | 88/08/10 | 88/08/29 | مترمربع | 89/7/8 | 89/7/22 |
| 1143 | 2.13.13.11 | اجراي سقف كاذب سرويسهاي طبقه دهم | 15d | 2010-10-17 | 2010-10-31 | 1079 | 11d | 88/08/30 | 88/09/19 | مترمربع | 89/7/25 | 89/8/9 |
| 1144 | 2.13.14 | **اجراي سفيدكاري** | 110d | 2010-06-18 | 2010-10-05 |  | 0d | 87/12/26 | 88/10/09 | درصد | 89/3/28 | 89/7/13 |
| 1145 | 2.13.14.1 | اجراي سفيدکاري همکف | 10d | 2010-06-18 | 2010-06-27 | 862, 874 | 0d | 88/03/04 | 88/03/23 | مترمربع | 89/3/28 | 89/4/6 |
| 1146 | 2.13.14.2 | اجراي سفيدكاري طبقه 1 | 10d | 2010-06-28 | 2010-07-07 | 1145 | 0d | 88/03/24 | 88/04/12 | مترمربع | 89/4/7 | 89/4/16 |
| 1147 | 2.13.14.3 | اجراي سفيدكاري طبقه 2 | 10d | 2010-07-08 | 2010-07-17 | 1146 | 0d | 88/04/13 | 88/05/01 | مترمربع | 89/4/17 | 89/4/26 |
| 1148 | 2.13.14.4 | اجراي سفيدكاري طبقه 3 | 10d | 2010-07-18 | 2010-07-27 | 1147 | 0d | 88/05/02 | 88/05/21 | مترمربع | 89/4/27 | 89/5/5 |
| 1149 | 2.13.14.5 | اجراي سفيدكاري طبقه 4 | 10d | 2010-07-28 | 2010-08-06 | 1148 | 0d | 88/05/22 | 88/06/10 | مترمربع | 89/5/6 | 89/5/15 |
| 1150 | 2.13.14.6 | اجراي سفيدكاري طبقه 5 | 10d | 2010-08-07 | 2010-08-16 | 1149 | 0d | 88/06/11 | 88/06/30 | مترمربع | 89/5/16 | 89/5/25 |
| 1151 | 2.13.14.7 | اجراي سفيدكاري طبقه 6 | 10d | 2010-08-17 | 2010-08-26 | 1150 | 0d | 88/06/31 | 88/07/19 | مترمربع | 89/5/26 | 89/6/4 |
| 1152 | 2.13.14.8 | اجراي سفيدكاري طبقه 7 | 10d | 2010-08-27 | 2010-09-05 | 1151 | 0d | 88/07/20 | 88/08/09 | مترمربع | 89/6/5 | 89/6/14 |
| 1153 | 2.13.14.9 | اجراي سفيدكاري طبقه 8 | 10d | 2010-09-06 | 2010-09-15 | 1152 | 0d | 88/08/10 | 88/08/29 | مترمربع | 89/6/15 | 89/6/24 |
| 1154 | 2.13.14.10 | اجراي سفيدكاري طبقه 9 | 10d | 2010-09-16 | 2010-09-25 | 1153 | 0d | 88/08/30 | 88/09/19 | مترمربع | 89/6/25 | 89/7/3 |
| 1155 | 2.13.14.11 | اجراي سفيدكاري طبقه 10 وخرپشته | 10d | 2010-09-26 | 2010-10-05 | 1154 | 0d | 88/09/20 | 88/10/09 | مترمربع | 89/7/4 | 89/7/13 |

| ID | WBS | Task | Duration | Start | Finish | Predecessors | Total slack | Free slack | Plan Start | Plan Finish |
| --- | --- | --- | --- | --- | --- | --- | --- | --- | --- | --- |
| 1156 | 2.13.15 | **نصب دربهاي اصلي ساختمان** | 105d | 2010-06-28 | 2010-10-10 |  | 4d |  | 89/4/7 | 89/7/18 |
| 1157 | 2.13.15.1 | نصب دربهاي اصلي ساختمان طبقه همكف | 5d | 2010-06-28 | 2010-07-02 | 1145 | 104d | 5d | 89/4/7 | 89/4/11 |
| 1158 | 2.13.15.2 | نصب دربهاي اصلي طبقه اول | 5d | 2010-07-08 | 2010-07-12 | 1146 | 94d | 5d | 89/4/17 | 89/4/21 |
| 1159 | 2.13.15.3 | نصب دربهاي اصلي طبقه دوم | 5d | 2010-07-18 | 2010-07-22 | 1147 | 84d | 5d | 89/4/27 | 89/4/31 |
| 1160 | 2.13.15.4 | نصب دربهاي اصلي طبقه سوم | 5d | 2010-07-28 | 2010-08-01 | 1148 | 74d | 5d | 89/5/6 | 89/5/10 |
| 1161 | 2.13.15.5 | نصب دربهاي اصلي طبقه چهارم | 5d | 2010-08-07 | 2010-08-11 | 1149 | 64d | 5d | 89/5/16 | 89/5/20 |
| 1162 | 2.13.15.6 | نصب دربهاي اصلي طبقه پنجم | 5d | 2010-08-17 | 2010-08-21 | 1150 | 54d | 5d | 89/5/26 | 89/5/30 |
| 1163 | 2.13.15.7 | نصب دربهاي اصلي طبقه ششم | 5d | 2010-08-27 | 2010-08-31 | 1151 | 44d | 5d | 89/6/5 | 89/6/9 |
| 1164 | 2.13.15.8 | نصب دربهاي اصلي طبقه هفتم | 5d | 2010-09-06 | 2010-09-10 | 1152 | 34d | 5d | 89/6/15 | 89/6/19 |
| 1165 | 2.13.15.9 | نصب دربهاي اصلي طبقه هشتم | 5d | 2010-09-16 | 2010-09-20 | 1153 | 24d | 5d | 89/6/25 | 89/6/29 |
| 1166 | 2.13.15.10 | نصب دربهاي اصلي طبقه نهم | 5d | 2010-09-26 | 2010-09-30 | 1154 | 14d | 5d | 89/7/4 | 89/7/8 |
| 1167 | 2.13.15.11 | نصب دربهاي اصلي طبقه دهم | 5d | 2010-10-06 | 2010-10-10 | 1155 | 0d |  | 89/7/14 | 89/7/18 |
| 1168 | 2.13.16 | **نصب كابينت طبقات** | 110d | 2010-06-28 | 2010-10-15 |  | 1d |  | 89/4/7 | 89/7/23 |
| 1169 | 2.13.16.1 | نصب كابينت طبقه همكف | 10d | 2010-06-28 | 2010-07-07 | 1145 | 99d | 0d | 89/4/7 | 89/4/16 |
| 1170 | 2.13.16.2 | نصب كابينت طبقه اول | 10d | 2010-07-08 | 2010-07-17 | 1146 | 89d | 0d | 89/4/17 | 89/4/26 |
| 1171 | 2.13.16.3 | نصب كابينت طبقه دوم | 10d | 2010-07-18 | 2010-07-27 | 1147 | 79d | 0d | 89/4/27 | 89/5/5 |
| 1172 | 2.13.16.4 | نصب كابينت طبقه سوم | 10d | 2010-07-28 | 2010-08-06 | 1148 | 69d | 0d | 89/5/6 | 89/5/15 |
| 1173 | 2.13.16.5 | نصب كابينت طبقه چهارم | 10d | 2010-08-07 | 2010-08-16 | 1149 | 59d | 0d | 89/5/16 | 89/5/25 |
| 1174 | 2.13.16.6 | نصب كابينت طبقه پنجم | 10d | 2010-08-17 | 2010-08-26 | 1150 | 49d | 0d | 89/5/26 | 89/6/4 |
| 1175 | 2.13.16.7 | نصب كابينت طبقه ششم | 10d | 2010-08-27 | 2010-09-05 | 1151 | 39d | 0d | 89/6/5 | 89/6/14 |
| 1176 | 2.13.16.8 | نصب كابينت طبقه هفتم | 10d | 2010-09-06 | 2010-09-15 | 1152 | 29d | 0d | 89/6/15 | 89/6/24 |
| 1177 | 2.13.16.9 | نصب كابينت طبقه هشتم | 10d | 2010-09-16 | 2010-09-25 | 1153 | 19d | 0d | 89/6/25 | 89/7/3 |
| 1178 | 2.13.16.10 | نصب كابينت طبقه نهم | 10d | 2010-09-26 | 2010-10-05 | 1154 | 9d | 0d | 89/7/4 | 89/7/13 |
| 1179 | 2.13.16.11 | نصب كابينت طبقه دهم | 10d | 2010-10-06 | 2010-10-15 | 1155 | 1d |  | 89/7/14 | 89/7/23 |

| ID | WBS | Task | Duration | Start | Finish | Predecessors | Total slack | Free slack | Plan Start | Plan Finish | Text1 | Text2 | واحد |
| --- | --- | --- | --- | --- | --- | --- | --- | --- | --- | --- | --- | --- | --- |
| 1180 | 2.13.17 | **نصب نرده طبقات** | 105d | 2010-06-28 | 2010-10-10 |  | 6d |  | 89/4/7 | 89/7/18 |  |  |  |
| 1181 | 2.13.17.1 | نصب نرده طبقه همكف | 5d | 2010-06-28 | 2010-07-02 | 1145 | 104d | 5d | 89/4/7 | 89/4/11 |  |  |  |
| 1182 | 2.13.17.2 | نصب نرده طبقه اول | 5d | 2010-07-08 | 2010-07-12 | 1146 | 94d | 5d | 89/4/17 | 89/4/21 |  |  |  |
| 1183 | 2.13.17.3 | نصب نرده طبقه دوم | 5d | 2010-07-18 | 2010-07-22 | 1147 | 84d | 5d | 89/4/27 | 89/4/31 |  |  |  |
| 1184 | 2.13.17.4 | نصب نرده طبقه سوم | 5d | 2010-07-28 | 2010-08-01 | 1148 | 74d | 5d | 89/5/6 | 89/5/10 |  |  |  |
| 1185 | 2.13.17.5 | نصب نرده طبقه چهارم | 5d | 2010-08-07 | 2010-08-11 | 1149 | 64d | 5d | 89/5/16 | 89/5/20 |  |  |  |
| 1186 | 2.13.17.6 | نصب نرده طبقه پنجم | 5d | 2010-08-17 | 2010-08-21 | 1150 | 54d | 5d | 89/5/26 | 89/5/30 |  |  |  |
| 1187 | 2.13.17.7 | نصب نرده طبقه ششم | 5d | 2010-08-27 | 2010-08-31 | 1151 | 44d | 5d | 89/6/5 | 89/6/9 |  |  |  |
| 1188 | 2.13.17.8 | نصب نرده طبقه هفتم | 5d | 2010-09-06 | 2010-09-10 | 1152 | 34d | 5d | 89/6/15 | 89/6/19 |  |  |  |
| 1189 | 2.13.17.9 | نصب نرده طبقه هشتم | 5d | 2010-09-16 | 2010-09-20 | 1153 | 24d | 5d | 89/6/25 | 89/6/29 |  |  |  |
| 1190 | 2.13.17.10 | نصب نرده طبقه نهم | 5d | 2010-09-26 | 2010-09-30 | 1154 | 14d | 5d | 89/7/4 | 89/7/8 |  |  |  |
| 1191 | 2.13.17.11 | نصب نرده طبقه دهم | 5d | 2010-10-06 | 2010-10-10 | 1155 | 6d |  | 89/7/14 | 89/7/18 |  |  |  |
| 1192 | 2.13.18 | **نقاشي** | 119d | 2010-07-08 | 2010-11-03 |  | 0d |  | 89/4/17 | 89/8/12 | 88/02/05 | 88/11/14 | درصد |
| 1193 | 2.13.18.1 | نقاشي طبفه همكف | 18d | 2010-07-08 | 2010-07-25 | 1121, 1157, 1169, 1181, 1207, 1246 | 99d | 0d | 89/4/17 | 89/5/3 | 88/04/03 | 88/04/22 | مترمربع |
| 1194 | 2.13.18.2 | نقاشي طبقه 1 | 18d | 2010-07-18 | 2010-08-04 | 1122, 1158, 1170, 1182, 1208, 1247 | 89d | 0d | 89/4/27 | 89/5/13 | 88/04/23 | 88/05/11 | مترمربع |
| 1195 | 2.13.18.3 | نقاشي طبقه 2 | 18d | 2010-07-28 | 2010-08-14 | 1123, 1159, 1171, 1183, 1248, 1208 | 79d | 0d | 89/5/6 | 89/5/23 | 88/05/12 | 88/05/31 | مترمربع |
| 1196 | 2.13.18.4 | نقاشي طبقه 3 | 18d | 2010-08-07 | 2010-08-24 | 1124, 1160, 1172, 1184, 1249, 1209 | 69d | 0d | 89/5/16 | 89/6/2 | 88/06/01 | 88/06/20 | مترمربع |
| 1197 | 2.13.18.5 | نقاشي طبقه 4 | 18d | 2010-08-17 | 2010-09-03 | 1125, 1161, 1173, 1185, 1250, 1210 | 59d | 0d | 89/5/26 | 89/6/12 | 88/06/21 | 88/07/09 | مترمربع |
| 1198 | 2.13.18.6 | نقاشي طبقه 5 | 18d | 2010-08-27 | 2010-09-13 | 1126, 1162, 1174, 1186, 1251, 1211 | 49d | 0d | 89/6/5 | 89/6/22 | 88/07/10 | 88/07/29 | مترمربع |
| 1199 | 2.13.18.7 | نقاشي طبقه 6 | 18d | 2010-09-06 | 2010-09-23 | 1127, 1163, 1175, 1187, 1212, 1252 | 39d | 0d | 89/6/15 | 89/7/1 | 88/07/30 | 88/08/19 | مترمربع |
| 1200 | 2.13.18.8 | نقاشي طبقه 7 | 18d | 2010-09-16 | 2010-10-03 | 1128, 1164, 1176, 1188, 1213, 1253 | 29d | 0d | 89/6/25 | 89/7/11 | 88/08/20 | 88/09/09 | مترمربع |
| 1201 | 2.13.18.9 | نقاشي طبقه 8 | 18d | 2010-09-26 | 2010-10-13 | 1129, 1165, 1177, 1189, 1214, 1254 | 19d | 0d | 89/7/4 | 89/7/21 | 88/09/10 | 88/09/29 | مترمربع |
| 1202 | 2.13.18.10 | نقاشي طبقه 9 | 18d | 2010-10-06 | 2010-10-23 | 1130, 1166, 1178, 1190, 1215, 1255 | 9d | 0d | 89/7/14 | 89/8/1 | 88/09/30 | 88/10/19 | مترمربع |
| 1203 | 2.13.18.11 | نقاشي طبقه 10 | 18d | 2010-10-17 | 2010-11-03 | 1131, 1167, 1179, 1191, 1216, 1256 | 0d |  | 89/7/25 | 89/8/12 | 88/10/25 | 88/11/14 | مترمربع |

| ID | WBS | Task | Duration | Start | Finish | Predecessors | Total slack | Free slack | Plan Start | Plan Finish | Text1 | Text2 | واحد |
| --- | --- | --- | --- | --- | --- | --- | --- | --- | --- | --- | --- | --- | --- |
| 1204 | 2.14 | **فاز دوم تاسيسات مكانيكي** | 243d | 2010-03-06 | 2010-11-11 |  | 0d |  | 88/12/15 | 89/8/20 |  |  |  |
| 1205 | 2.14.1 | نصب سيستم آتشنشاني در موتورخانه | 10d | 2010-03-06 | 2010-03-15 | 1095 | 233d |  | 88/12/15 | 88/12/24 |  |  |  |
| 1206 | 2.14.2 | **اجراي لوله گاز** | 110d | 2010-06-20 | 2010-10-07 |  | 19d |  | 89/3/30 | 89/7/15 | 87/12/26 | 88/08/19 | درصد |
| 1207 | 2.14.2.1 | لوله كشي گاز طبقه همکف | 10d | 2010-06-20 | 2010-06-29 | 1145SS+2d | 19d | 0d | 89/3/30 | 89/4/8 | 88/01/16 | 88/02/04 | درصد |
| 1208 | 2.14.2.2 | لوله كشي گاز طبقه اول | 10d | 2010-06-30 | 2010-07-09 | 1146SS+2d, 1207 | 19d | 0d | 89/4/9 | 89/4/18 | 88/02/05 | 88/02/24 | درصد |
| 1209 | 2.14.2.3 | لوله كشي گاز طبقه دوم | 10d | 2010-07-10 | 2010-07-19 | 1147SS+2d, 1208 | 19d | 0d | 89/4/19 | 89/4/28 | 88/02/25 | 88/03/13 | درصد |
| 1210 | 2.14.2.4 | لوله كشي گاز طبقه سوم | 10d | 2010-07-20 | 2010-07-29 | 1148SS+2d, 1209 | 19d | 0d | 89/4/29 | 89/5/7 | 88/03/14 | 88/04/02 | درصد |
| 1211 | 2.14.2.5 | لوله كشي گاز طبقه چهارم | 10d | 2010-07-30 | 2010-08-08 | 1149SS+2d, 1210 | 19d | 0d | 89/5/8 | 89/5/17 | 88/04/03 | 88/04/22 | درصد |
| 1212 | 2.14.2.6 | لوله كشي گاز طبقه پنجم | 10d | 2010-08-09 | 2010-08-18 | 1150SS+2d, 1211 | 19d | 0d | 89/5/18 | 89/5/27 | 88/04/23 | 88/05/11 | درصد |
| 1213 | 2.14.2.7 | لوله كشي گاز طبقه ششم | 10d | 2010-08-19 | 2010-08-28 | 1151SS+2d, 1212 | 19d | 0d | 89/5/28 | 89/6/6 | 88/05/12 | 88/05/31 | درصد |
| 1214 | 2.14.2.8 | لوله كشي گاز طبقه هفتم | 10d | 2010-08-29 | 2010-09-07 | 1152SS+2d, 1213 | 19d | 0d | 89/6/7 | 89/6/16 | 88/06/01 | 88/06/20 | درصد |
| 1215 | 2.14.2.9 | لوله كشي گاز طبقه هشتم | 10d | 2010-09-08 | 2010-09-17 | 1153SS+2d, 1214 | 19d | 0d | 89/6/17 | 89/6/26 | 88/06/21 | 88/07/09 | درصد |
| 1216 | 2.14.2.10 | لوله كشي گاز طبقه نهم | 10d | 2010-09-18 | 2010-09-27 | 1154SS+2d, 1215 | 19d | 0d | 89/6/27 | 89/7/5 | 88/07/10 | 88/07/29 | درصد |
| 1217 | 2.14.2.11 | لوله كشي گاز طبقه 10 و بام | 10d | 2010-09-28 | 2010-10-07 | 1155SS+2d, 1216 | 35d |  | 89/7/6 | 89/7/15 | 88/07/30 | 88/08/19 | درصد |
| 1218 | 2.14.3 | **نصب شيرآلات و رادياتورهاي طبقات** | 109d | 2010-07-26 | 2010-11-11 |  | 0d |  | 89/5/4 | 89/8/20 |  |  |  |
| 1219 | 2.14.3.1 | نصب شيرآلات و رادياتورهاي طبقه همكف | 8d | 2010-07-26 | 2010-08-02 | 1193 | 101d |  | 89/5/4 | 89/5/11 |  |  |  |
| 1220 | 2.14.3.2 | نصب شيرآلات و رادياتورهاي طبقه اول | 8d | 2010-08-05 | 2010-08-12 | 1194 | 91d |  | 89/5/14 | 89/5/21 |  |  |  |
| 1221 | 2.14.3.3 | نصب شيرآلات و رادياتورهاي طبقه دوم | 8d | 2010-08-15 | 2010-08-22 | 1195 | 81d |  | 89/5/24 | 89/5/31 |  |  |  |
| 1222 | 2.14.3.4 | نصب شيرآلات و رادياتورهاي طبقه سوم | 8d | 2010-08-25 | 2010-09-01 | 1196 | 71d |  | 89/6/3 | 89/6/10 |  |  |  |
| 1223 | 2.14.3.5 | نصب شيرآلات و رادياتورهاي طبقه چهارم | 8d | 2010-09-04 | 2010-09-11 | 1197 | 61d |  | 89/6/13 | 89/6/20 |  |  |  |
| 1224 | 2.14.3.6 | نصب شيرآلات و رادياتورهاي طبقه پنجم | 8d | 2010-09-14 | 2010-09-21 | 1198 | 51d |  | 89/6/23 | 89/6/30 |  |  |  |
| 1225 | 2.14.3.7 | نصب شيرآلات و رادياتورهاي طبقه ششم | 8d | 2010-09-24 | 2010-10-01 | 1199 | 41d |  | 89/7/2 | 89/7/9 |  |  |  |
| 1226 | 2.14.3.8 | نصب شيرآلات و رادياتورهاي طبقه هفتم | 8d | 2010-10-04 | 2010-10-11 | 1200 | 31d |  | 89/7/12 | 89/7/19 |  |  |  |
| 1227 | 2.14.3.9 | نصب شيرآلات و رادياتورهاي طبقه هشتم | 8d | 2010-10-14 | 2010-10-21 | 1201 | 21d |  | 89/7/22 | 89/7/29 |  |  |  |
| 1228 | 2.14.3.10 | نصب شيرآلات و رادياتورهاي طبقه نهم | 8d | 2010-10-24 | 2010-10-31 | 1202 | 11d |  | 89/8/2 | 89/8/9 |  |  |  |
| 1229 | 2.14.3.11 | نصب شيرآلات و رادياتورهاي طبقه دهم | 8d | 2010-11-04 | 2010-11-11 | 1203 | 0d |  | 89/8/13 | 89/8/20 |  |  |  |

| ID | WBS | Task | Duration | Start | Finish | Predecessors | Total slack | Free slack | Plan Start | Plan Finish |
| --- | --- | --- | --- | --- | --- | --- | --- | --- | --- | --- |
| 1230 | 2.14.4 | **نصب پكيج هاي طبقات** | 109d | 2010-07-26 | 2010-11-11 |  | 0d |  | 89/5/4 | 89/8/20 |
| 1231 | 2.14.4.1 | نصب پكيج هاي طبقه همكف | 10d | 2010-07-26 | 2010-08-04 | 1193 | 99d |  | 89/5/4 | 89/5/13 |
| 1232 | 2.14.4.2 | نصب پكيج هاي طبقه اول | 10d | 2010-08-05 | 2010-08-14 | 1194 | 89d |  | 89/5/14 | 89/5/23 |
| 1233 | 2.14.4.3 | نصب پكيج هاي طبقه دوم | 10d | 2010-08-15 | 2010-08-24 | 1195 | 79d |  | 89/5/24 | 89/6/2 |
| 1234 | 2.14.4.4 | نصب پكيج هاي طبقه سوم | 10d | 2010-08-25 | 2010-09-03 | 1196 | 69d |  | 89/6/3 | 89/6/12 |
| 1235 | 2.14.4.5 | نصب پكيج هاي طبقه چهارم | 10d | 2010-09-04 | 2010-09-13 | 1197 | 59d |  | 89/6/13 | 89/6/22 |
| 1236 | 2.14.4.6 | نصب پكيج هاي طبقه پنجم | 10d | 2010-09-14 | 2010-09-23 | 1198 | 49d |  | 89/6/23 | 89/7/1 |
| 1237 | 2.14.4.7 | نصب پكيج هاي طبقه ششم | 10d | 2010-09-24 | 2010-10-03 | 1199 | 39d |  | 89/7/2 | 89/7/11 |
| 1238 | 2.14.4.8 | نصب پكيج هاي طبقه هفتم | 10d | 2010-10-04 | 2010-10-13 | 1200 | 29d |  | 89/7/12 | 89/7/21 |
| 1239 | 2.14.4.9 | نصب پكيج هاي طبقه هشتم | 10d | 2010-10-14 | 2010-10-23 | 1201 | 19d |  | 89/7/22 | 89/8/1 |
| 1240 | 2.14.4.10 | نصب پكيج هاي طبقه نهم | 10d | 2010-10-24 | 2010-11-02 | 1202 | 9d |  | 89/8/2 | 89/8/11 |
| 1241 | 2.14.4.11 | نصب پكيج هاي طبقه دهم | 8d | 2010-11-04 | 2010-11-11 | 1203 | 0d |  | 89/8/13 | 89/8/20 |
| 1242 | 2.15 | **فاز دوم تاسيسات برقي** | 177d | 2010-05-19 | 2010-11-11 |  | 0d |  | 89/2/29 | 89/8/20 |
| 1243 | 2.15.1 | **سيم كشي طبقات** | 171d | 2010-05-19 | 2010-11-05 |  | 0d |  | 89/2/29 | 89/8/14 |
| 1244 | 2.15.1.1 | سيم كشي زيرزمين دوم | 10d | 2010-10-27 | 2010-11-05 | 1245 | 0d |  | 89/8/5 | 89/8/14 |
| 1245 | 2.15.1.2 | سيم كشي زيرزمين اول | 10d | 2010-10-17 | 2010-10-26 | 1256 | 0d |  | 89/7/25 | 89/8/4 |
| 1246 | 2.15.1.3 | سيم كشي طبقه همكف | 10d | 2010-05-19 | 2010-05-28 | 1057 | 41d | 0d | 89/2/29 | 89/3/7 |
| 1247 | 2.15.1.4 | سيم كشي طبقه اول | 10d | 2010-05-29 | 2010-06-07 | 1058, 1246 | 41d | 0d | 89/3/8 | 89/3/17 |
| 1248 | 2.15.1.5 | سيم كشي طبقه دوم | 10d | 2010-06-08 | 2010-06-17 | 1059, 1247 | 41d | 4d | 89/3/18 | 89/3/27 |
| 1249 | 2.15.1.6 | سيم كشي طبقه سوم | 10d | 2010-06-22 | 2010-07-01 | 1060, 1248 | 37d | 5d | 89/4/1 | 89/4/10 |
| 1250 | 2.15.1.7 | سيم كشي طبقه چهارم | 10d | 2010-07-07 | 2010-07-16 | 1061, 1249 | 32d | 5d | 89/4/16 | 89/4/25 |
| 1251 | 2.15.1.8 | سيم كشي طبقه پنجم | 10d | 2010-07-22 | 2010-07-31 | 1062, 1250 | 27d | 5d | 89/4/31 | 89/5/9 |
| 1252 | 2.15.1.9 | سيم كشي طبقه ششم | 10d | 2010-08-06 | 2010-08-15 | 1063, 1251 | 22d | 5d | 89/5/15 | 89/5/24 |
| 1253 | 2.15.1.10 | سيم كشي طبقه هفتم | 10d | 2010-08-21 | 2010-08-30 | 1064, 1252 | 17d | 5d | 89/5/30 | 89/6/8 |
| 1254 | 2.15.1.11 | سيم كشي طبقه هشتم | 10d | 2010-09-05 | 2010-09-14 | 1065, 1253 | 12d | 5d | 89/6/14 | 89/6/23 |
| 1255 | 2.15.1.12 | سيم كشي طبقه نهم | 10d | 2010-09-20 | 2010-09-29 | 1066, 1254 | 7d | 6d | 89/6/29 | 89/7/7 |
| 1256 | 2.15.1.13 | سيم كشي طبقه دهم و خرپشته | 10d | 2010-10-07 | 2010-10-16 | 1067, 1255 | 0d |  | 89/7/15 | 89/7/24 |

| ID | WBS | Task | Duration | Start | Finish | Predecessors | Total slack | Plan Start | Plan Finish |
| --- | --- | --- | --- | --- | --- | --- | --- | --- | --- |
| 1257 | 2.15.2 | **نصب كليد و پريز لوازم برقي و هواكش** | 109d | 2010-07-26 | 2010-11-11 |  | 0d | 89/5/4 | 89/8/20 |
| 1258 | 2.15.2.1 | نصب كليد و پريز لوازم برقي و هواكش زيرزمين دوم | 6d | 2010-11-06 | 2010-11-11 | 1244 | 0d | 89/8/15 | 89/8/20 |
| 1259 | 2.15.2.2 | نصب كليد و پريز لوازم برقي و هواكش زيرزمين اول | 10d | 2010-10-27 | 2010-11-05 | 1245 | 6d | 89/8/5 | 89/8/14 |
| 1260 | 2.15.2.3 | نصب كليد و پريز لوازم برقي و هواكش طبقه همكف | 10d | 2010-07-26 | 2010-08-04 | 1193 | 99d | 89/5/4 | 89/5/13 |
| 1261 | 2.15.2.4 | نصب كليد و پريز لوازم برقي و هواكش طبقه اول | 10d | 2010-08-05 | 2010-08-14 | 1194 | 89d | 89/5/14 | 89/5/23 |
| 1262 | 2.15.2.5 | نصب كليد و پريز لوازم برقي و هواكش طبقه دوم | 10d | 2010-08-15 | 2010-08-24 | 1195 | 79d | 89/5/24 | 89/6/2 |
| 1263 | 2.15.2.6 | نصب كليد و پريز لوازم برقي و هواكش طبقه سوم | 10d | 2010-08-25 | 2010-09-03 | 1196 | 69d | 89/6/3 | 89/6/12 |
| 1264 | 2.15.2.7 | نصب كليد و پريز لوازم برقي و هواكش طبقه چهارم | 10d | 2010-09-04 | 2010-09-13 | 1197 | 59d | 89/6/13 | 89/6/22 |
| 1265 | 2.15.2.8 | نصب كليد و پريز لوازم برقي و هواكش طبقه پنجم | 10d | 2010-09-14 | 2010-09-23 | 1198 | 49d | 89/6/23 | 89/7/1 |
| 1266 | 2.15.2.9 | نصب كليد و پريز لوازم برقي و هواكش طبقه ششم | 10d | 2010-09-24 | 2010-10-03 | 1199 | 39d | 89/7/2 | 89/7/11 |
| 1267 | 2.15.2.10 | نصب كليد و پريز لوازم برقي و هواكش طبقه هفتم | 10d | 2010-10-04 | 2010-10-13 | 1200 | 29d | 89/7/12 | 89/7/21 |
| 1268 | 2.15.2.11 | نصب كليد و پريز لوازم برقي و هواكش طبقه هشتم | 10d | 2010-10-14 | 2010-10-23 | 1201 | 19d | 89/7/22 | 89/8/1 |
| 1269 | 2.15.2.12 | نصب كليد و پريز لوازم برقي و هواكش طبقه نهم | 10d | 2010-10-24 | 2010-11-02 | 1202 | 9d | 89/8/2 | 89/8/11 |
| 1270 | 2.15.2.13 | نصب كليد و پريز لوازم برقي و هواكش طبقه دهم | 6d | 2010-11-04 | 2010-11-09 | 1203 | 2d | 89/8/13 | 89/8/18 |
| 1271 | 2.15.3 | **ساخت و نصب تابلوهاي برقي** | 109d | 2010-07-26 | 2010-11-11 |  | 0d | 89/5/4 | 89/8/20 |
| 1272 | 2.15.3.1 | ساخت و نصب تابلوهاي برقي زيرزمين دوم | 6d | 2010-11-06 | 2010-11-11 | 1244 | 0d | 89/8/15 | 89/8/20 |
| 1273 | 2.15.3.2 | ساخت و نصب تابلوهاي برقي زيرزمين اول | 10d | 2010-10-27 | 2010-11-05 | 1245 | 6d | 89/8/5 | 89/8/14 |
| 1274 | 2.15.3.3 | ساخت و نصب تابلوهاي برقي طبقه همكف | 10d | 2010-07-26 | 2010-08-04 | 1193 | 99d | 89/5/4 | 89/5/13 |
| 1275 | 2.15.3.4 | ساخت و نصب تابلوهاي برقي طبقه اول | 10d | 2010-08-05 | 2010-08-14 | 1194 | 89d | 89/5/14 | 89/5/23 |
| 1276 | 2.15.3.5 | ساخت و نصب تابلوهاي برقي طبقه دوم | 10d | 2010-08-15 | 2010-08-24 | 1195 | 79d | 89/5/24 | 89/6/2 |
| 1277 | 2.15.3.6 | ساخت و نصب تابلوهاي برقي طبقه سوم | 10d | 2010-08-25 | 2010-09-03 | 1196 | 69d | 89/6/3 | 89/6/12 |
| 1278 | 2.15.3.7 | ساخت و نصب تابلوهاي برقي طبقه چهارم | 10d | 2010-09-04 | 2010-09-13 | 1197 | 59d | 89/6/13 | 89/6/22 |
| 1279 | 2.15.3.8 | ساخت و نصب تابلوهاي برقي طبقه پنجم | 10d | 2010-09-14 | 2010-09-23 | 1198 | 49d | 89/6/23 | 89/7/1 |
| 1280 | 2.15.3.9 | ساخت و نصب تابلوهاي برقي طبقه ششم | 10d | 2010-09-24 | 2010-10-03 | 1199 | 39d | 89/7/2 | 89/7/11 |
| 1281 | 2.15.3.10 | ساخت و نصب تابلوهاي برقي طبقه هفتم | 10d | 2010-10-04 | 2010-10-13 | 1200 | 29d | 89/7/12 | 89/7/21 |
| 1282 | 2.15.3.11 | ساخت و نصب تابلوهاي برقي طبقه هشتم | 10d | 2010-10-14 | 2010-10-23 | 1201 | 19d | 89/7/22 | 89/8/1 |
| 1283 | 2.15.3.12 | ساخت و نصب تابلوهاي برقي طبقه نهم | 10d | 2010-10-24 | 2010-11-02 | 1202 | 9d | 89/8/2 | 89/8/11 |
| 1284 | 2.15.3.13 | ساخت و نصب تابلوهاي برقي طبقه دهم | 8d | 2010-11-04 | 2010-11-11 | 1203 | 0d | 89/8/13 | 89/8/20 |

| ID | WBS | Task | Type | Duration | Start | Finish | Predecessors | Total slack | Free slack | Plan Start | Plan Finish |
| --- | --- | --- | --- | --- | --- | --- | --- | --- | --- | --- | --- |
| 1285 | 2.15.4 | **نصب و راه اندازي سيستم اعلام حريق و درب بازكن** |  | 109d | 2010-07-26 | 2010-11-11 |  | 0d |  | 89/5/4 | 89/8/20 |
| 1286 | 2.15.4.1 | نصب و راه اندازي سيستم اعلام حريق و درب بازكن زيرزمين دوم |  | 6d | 2010-11-06 | 2010-11-11 | 1244 | 0d |  | 89/8/15 | 89/8/20 |
| 1287 | 2.15.4.2 | نصب و راه اندازي سيستم اعلام حريق و درب بازكن زيرزمين اول |  | 10d | 2010-10-27 | 2010-11-05 | 1245 | 6d |  | 89/8/5 | 89/8/14 |
| 1288 | 2.15.4.3 | نصب و راه اندازي سيستم اعلام حريق و درب بازكن طبقه همكف |  | 10d | 2010-07-26 | 2010-08-04 | 1193 | 99d |  | 89/5/4 | 89/5/13 |
| 1289 | 2.15.4.4 | نصب و راه اندازي سيستم اعلام حريق و درب بازكن طبقه اول |  | 10d | 2010-08-05 | 2010-08-14 | 1194 | 89d |  | 89/5/14 | 89/5/23 |
| 1290 | 2.15.4.5 | نصب و راه اندازي سيستم اعلام حريق و درب بازكن طبقه دوم |  | 10d | 2010-08-15 | 2010-08-24 | 1195 | 79d |  | 89/5/24 | 89/6/2 |
| 1291 | 2.15.4.6 | نصب و راه اندازي سيستم اعلام حريق و درب بازكن طبقه سوم |  | 10d | 2010-08-25 | 2010-09-03 | 1196 | 69d |  | 89/6/3 | 89/6/12 |
| 1292 | 2.15.4.7 | نصب و راه اندازي سيستم اعلام حريق و درب بازكن طبقه چهارم |  | 10d | 2010-09-04 | 2010-09-13 | 1197 | 59d |  | 89/6/13 | 89/6/22 |
| 1293 | 2.15.4.8 | نصب و راه اندازي سيستم اعلام حريق و درب بازكن طبقه پنجم |  | 10d | 2010-09-14 | 2010-09-23 | 1198 | 49d |  | 89/6/23 | 89/7/1 |
| 1294 | 2.15.4.9 | نصب و راه اندازي سيستم اعلام حريق و درب بازكن طبقه ششم |  | 10d | 2010-09-24 | 2010-10-03 | 1199 | 39d |  | 89/7/2 | 89/7/11 |
| 1295 | 2.15.4.10 | نصب و راه اندازي سيستم اعلام حريق و درب بازكن طبقه هفتم |  | 10d | 2010-10-04 | 2010-10-13 | 1200 | 29d |  | 89/7/12 | 89/7/21 |
| 1296 | 2.15.4.11 | نصب و راه اندازي سيستم اعلام حريق و درب بازكن طبقه هشتم |  | 10d | 2010-10-14 | 2010-10-23 | 1201 | 19d |  | 89/7/22 | 89/8/1 |
| 1297 | 2.15.4.12 | نصب و راه اندازي سيستم اعلام حريق و درب بازكن طبقه نهم |  | 10d | 2010-10-24 | 2010-11-02 | 1202 | 9d |  | 89/8/2 | 89/8/11 |
| 1298 | 2.15.4.13 | نصب و راه اندازي سيستم اعلام حريق و درب بازكن طبقه دهم |  | 8d | 2010-11-04 | 2010-11-11 | 1203 | 0d |  | 89/8/13 | 89/8/20 |
| 1299 | 2.16 | **نصب و راه اندازي آسانسور و ژنراتور** |  | 70d | 2010-09-01 | 2010-11-09 |  | 0d |  | 89/6/10 | 89/8/18 |
| 1300 | 2.16.1 | آهن كشي آسانسور |  | 20d | 2010-09-01 | 2010-09-20 | 1301FF-20d | 50d |  | 89/6/10 | 89/6/29 |
| 1301 | 2.16.2 | نصب درب و ريل |  | 20d | 2010-09-21 | 2010-10-10 | 1167FF | 0d |  | 89/6/30 | 89/7/18 |
| 1302 | 2.16.3 | نصب و راه اندازي كامل آسانسور |  | 20d | 2010-10-11 | 2010-10-30 | 1301 | 0d |  | 89/7/19 | 89/8/8 |
| 1303 | 2.16.4 | نصب و راه اندازي ژنراتور |  | 10d | 2010-10-31 | 2010-11-09 | 1302 | 0d |  | 89/8/9 | 89/8/18 |
| 1304 | 2.17 | **محوطه سازي** |  | 215d | 2010-03-04 | 2010-10-12 |  | 30d |  | 88/12/13 | 89/7/20 |
| 1305 | 2.17.1 | ديواركشي پيرامون |  | 40d | 2010-05-11 | 2010-06-19 | 1306FF-70d | 145d | 0d | 89/2/21 | 89/3/29 |
| 1306 | 2.17.2 | محوطه سازي مجتمع |  | 60d | 2010-06-30 | 2010-08-28 | 1307FF-45d | 75d | 0d | 89/4/9 | 89/6/6 |
| 1307 | 2.17.3 | اجراي تاسيسات محوطه |  | 35d | 2010-09-08 | 2010-10-12 | 1309FF-30d | 30d | 0d | 89/6/17 | 89/7/20 |
| 1308 | 2.17.4 | اجرا ساختمان نگهباني و سردرب |  | 50d | 2010-03-04 | 2010-04-30 | 1305FF-50d | 195d |  | 88/12/13 | 89/2/10 |
| 1309 | 2.18 | برچيدن كارگاه بلوك 1 |  | 10d | 2010-11-02 | 2010-11-11 | 1299FS-8d | 0d |  | 89/8/11 | 89/8/20 |
| 1310 | 2.19 | اتمام بلوك 1 | milestone | 0d | 2010-11-11 | 2010-11-11 | 1309 | 0d |  | 89/8/20 | 89/8/20 |

| ID | WBS | Task | Duration | Start | Finish | Predecessors | Total slack | Free slack | Plan Start | Plan Finish | Text1 | Text2 | واحد |
| --- | --- | --- | --- | --- | --- | --- | --- | --- | --- | --- | --- | --- | --- |
| 1311 | 3 | **بلوك 3** | 900d | 2008-05-09 | 2010-11-11 |  | 0d |  | 87/2/20 | 89/8/20 |  |  |  |
| 1312 | 3.1 | **طراحي پروژه** | 70d | 2008-05-09 | 2008-07-17 |  | 0d |  | 87/2/20 | 87/4/27 |  |  |  |
| 1313 | 3.1.1 | طراحي فاز 1 و تاييد شهرداري | 35d | 2008-05-09 | 2008-06-12 |  | 0d |  | 87/2/20 | 87/3/23 |  |  |  |
| 1314 | 3.1.2 | طراحي كامل (فاز 2) و تاييد شهرداري | 35d | 2008-06-13 | 2008-07-17 | 1313 | 0d |  | 87/3/24 | 87/4/27 |  |  |  |
| 1315 | 3.2 | اخذ پروانه | 5d | 2008-07-18 | 2008-07-22 | 1314 | 0d |  | 87/4/28 | 87/5/1 |  |  |  |
| 1316 | 3.3 | **آزمايشگاه مكانيك خاك و نقشه برداري** | 10d | 2008-07-23 | 2008-08-01 |  | 4d |  | 87/5/2 | 87/5/11 |  |  |  |
| 1317 | 3.3.1 | آزمايشگاه مكانيك خاك | 5d | 2008-07-23 | 2008-07-27 | 1315 | 820d |  | 87/5/2 | 87/5/6 |  |  |  |
| 1318 | 3.3.2 | نقشه برداري | 10d | 2008-07-23 | 2008-08-01 | 1315 | 4d |  | 87/5/2 | 87/5/11 |  |  |  |
| 1319 | 3.4 | **انشعابات** | 14d | 2008-07-23 | 2008-08-05 |  | 0d |  | 87/5/2 | 87/5/15 |  |  |  |
| 1320 | 3.4.1 | انشعاب آب و فاضلاب | 14d | 2008-07-23 | 2008-08-05 | 1315 | 0d |  | 87/5/2 | 87/5/15 |  |  |  |
| 1321 | 3.4.2 | انشعاب برق | 14d | 2008-07-23 | 2008-08-05 | 1315 | 0d |  | 87/5/2 | 87/5/15 |  |  |  |
| 1322 | 3.4.3 | انشعاب گاز | 14d | 2008-07-23 | 2008-08-05 | 1315 | 0d |  | 87/5/2 | 87/5/15 |  |  |  |
| 1323 | 3.4.4 | انشعاب تلفن | 14d | 2008-07-23 | 2008-08-05 | 1315 | 0d |  | 87/5/2 | 87/5/15 |  |  |  |
| 1324 | 3.5 | تجهيز كارگاه | 14d | 2008-07-23 | 2008-08-05 | 1315 | 0d |  | 87/5/2 | 87/5/15 | 86/11/16 | 86/12/25 | درصد |
| 1325 | 3.6 | **خاكبرداري** | 15d | 2008-08-06 | 2008-08-20 |  | 0d |  | 87/5/16 | 87/5/30 | 86/12/26 | 87/02/05 | درصد |
| 1326 | 3.6.1 | خاکبرداري با ماشين | 15d | 2008-08-06 | 2008-08-20 | 1318, 1319, 1324 | 0d |  | 87/5/16 | 87/5/30 | 86/12/26 | 87/01/16 | مترمکعب |
| 1327 | 3.6.2 | خاكبرداري دستي و رگلاژ | 15d | 2008-08-06 | 2008-08-20 | 1326FF | 0d |  | 87/5/16 | 87/5/30 | 87/01/17 | 87/02/05 |  |
| 1328 | 3.7 | **اجراي فونداسيون** | 21d | 2008-08-21 | 2008-09-10 |  | 0d |  | 87/5/31 | 87/6/20 | 87/03/05 | 87/04/08 | درصد |
| 1329 | 3.7.1 | بتن مگر | 5d | 2008-08-21 | 2008-08-25 | 1325 | 0d |  | 87/5/31 | 87/6/4 | 87/03/06 | 87/03/10 | مترمکعب |
| 1330 | 3.7.2 | آرماتور بندي فونداسيون | 10d | 2008-08-26 | 2008-09-04 | 1329 | 0d |  | 87/6/5 | 87/6/14 | 87/03/11 | 87/03/20 | تن |
| 1331 | 3.7.3 | قالب بندي فونداسيون | 10d | 2008-08-27 | 2008-09-05 | 1330SS+1d | 0d |  | 87/6/6 | 87/6/15 | 87/03/07 | 87/03/21 | مترمربع |
| 1332 | 3.7.4 | بتن ريزي فونداسيون | 5d | 2008-09-06 | 2008-09-10 | 1331 | 0d |  | 87/6/16 | 87/6/20 | 87/03/22 | 87/04/08 | مترمکعب |
| 1333 | 3.8 | **اجراي اسكلت سازه** | 412d | 2008-09-13 | 2009-11-07 |  | 0d |  | 87/6/23 | 88/8/16 |  |  | درصد |
| 1334 | 3.8.1 | **آرماتوربندي ستونها و ديوارها** | 401d | 2008-09-13 | 2009-10-27 |  | 0d |  | 87/6/23 | 88/8/5 |  |  |  |
| 1335 | 3.8.1.1 | آرماتور بندي ستونها و ديوارهاي زيرزمين دوم | 5d | 2008-09-13 | 2008-09-17 | 1328FS+2d | 0d |  | 87/6/23 | 87/6/27 |  |  | تن |
| 1336 | 3.8.1.2 | آرماتور بندي ستونها و ديوارهاي زيرزمين اول | 5d | 2008-10-16 | 2008-10-20 | 1462 | 54d | 0d | 87/7/25 | 87/7/29 | 87/04/09 | 87/04/18 | تن |
| 1337 | 3.8.1.3 | آرماتور بندي ستونها و ديوارهاي همكف | 5d | 2008-11-18 | 2008-11-22 | 1463 | 54d | 0d | 87/8/28 | 87/9/2 | 87/05/11 | 87/05/20 | تن |
| 1338 | 3.8.1.4 | آرماتور بندي ستونها و ديوارهاي طبقه اول | 5d | 2008-12-21 | 2008-12-25 | 1464 | 61d | 0d | 87/10/1 | 87/10/5 | 87/06/13 | 87/06/22 | تن |
| 1339 | 3.8.1.5 | آرماتور بندي ستونها و ديوارهاي طبقه دوم | 5d | 2009-01-23 | 2009-01-27 | 1465 | 68d | 0d | 87/11/4 | 87/11/8 | 87/07/15 | 87/07/24 | تن |
| 1340 | 3.8.1.6 | آرماتور بندي ستونها و ديوارهاي طبقه سوم | 5d | 2009-02-25 | 2009-03-01 | 1466 | 75d | 0d | 87/12/7 | 87/12/11 | 87/08/18 | 87/08/27 | تن |
| 1341 | 3.8.1.7 | آرماتور بندي ستونها وديوارهاي طبقه چهارم | 5d | 2009-04-08 | 2009-04-12 | 1467 | 82d | 0d | 88/1/19 | 88/1/23 | 87/09/21 | 87/09/30 | تن |
| 1342 | 3.8.1.8 | آرماتور بندي ستونها و ديوارهاي طبقه پنجم | 5d | 2009-05-11 | 2009-05-15 | 1468 | 88d | 0d | 88/2/21 | 88/2/25 | 87/10/24 | 87/11/03 | تن |
| 1343 | 3.8.1.9 | آرماتور بندي ستونها و ديوارهاي طبقه ششم | 5d | 2009-06-13 | 2009-06-17 | 1469 | 88d | 0d | 88/3/23 | 88/3/27 | 87/11/27 | 87/12/06 | تن |
| 1344 | 3.8.1.10 | آرماتور بندي ستونها و ديوارهاي طبقه هفتم | 5d | 2009-07-16 | 2009-07-20 | 1470 | 93d | 0d | 88/4/25 | 88/4/29 | 87/12/30 | 88/01/09 | تن |
| 1345 | 3.8.1.11 | آرماتور بندي ستونها و ديوارهاي طبقه هشتم | 5d | 2009-08-18 | 2009-08-22 | 1471 | 100d | 0d | 88/5/27 | 88/5/31 | 88/02/02 | 88/02/11 | تن |
| 1346 | 3.8.1.12 | آرماتور بندي ستونها و ديوارهاي طبقه نهم | 5d | 2009-09-20 | 2009-09-24 | 1472 | 107d | 0d | 88/6/29 | 88/7/2 | 88/02/31 | 88/03/09 | تن |
| 1347 | 3.8.1.13 | آرماتور بندي ستونها و ديوارهاي طبقه دهم و خرپشته | 5d | 2009-10-23 | 2009-10-27 | 1473 | 114d | 0d | 88/8/1 | 88/8/5 | 88/04/02 | 88/04/11 | تن |

| ID | WBS | Task | Duration | Start | Finish | Predecessors | Total slack | Free slack | Plan Start | Plan Finish | واحد | Text1 | Text2 |
| --- | --- | --- | --- | --- | --- | --- | --- | --- | --- | --- | --- | --- | --- |
| 1348 | 3.8.2 | **قالب بندي ستونها و ديوارها** | 401d | 2008-09-14 | 2009-10-28 |  | 0d |  | 87/6/24 | 88/8/6 |  |  |  |
| 1349 | 3.8.2.1 | قالب بندي ستونها و ديوارهاي زيرزمين دوم | 5d | 2008-09-14 | 2008-09-18 | 1335SS+1d | 0d |  | 87/6/24 | 87/6/28 | مترمربع |  |  |
| 1350 | 3.8.2.2 | قالب بندي ستونها و ديوارها ي زيرزمين اول | 5d | 2008-10-17 | 2008-10-21 | 1336SS+1d | 54d | 0d | 87/7/26 | 87/7/30 | مترمربع | 87/04/10 | 87/04/19 |
| 1351 | 3.8.2.3 | قالب بندي ستونها و ديوارهاي همكف | 5d | 2008-11-19 | 2008-11-23 | 1337SS+1d | 54d | 0d | 87/8/29 | 87/9/3 | مترمربع | 87/05/12 | 87/05/21 |
| 1352 | 3.8.2.4 | قالب بندي ستونها و ديوارهاي طبقه اول | 5d | 2008-12-22 | 2008-12-26 | 1338SS+1d | 61d | 0d | 87/10/2 | 87/10/6 | مترمربع | 87/06/14 | 87/06/23 |
| 1353 | 3.8.2.5 | قالب بندي ستونها و ديوارهاي طبقه دوم | 5d | 2009-01-24 | 2009-01-28 | 1339SS+1d | 68d | 0d | 87/11/5 | 87/11/9 | مترمربع | 87/07/16 | 87/07/25 |
| 1354 | 3.8.2.6 | قالب بندي ستونها و ديوارهاي طبقه سوم | 5d | 2009-02-26 | 2009-03-02 | 1340SS+1d | 75d | 0d | 87/12/8 | 87/12/12 | مترمربع | 87/08/19 | 87/08/28 |
| 1355 | 3.8.2.7 | قالب بندي ستونها و ديوارهاي طبقه چهارم | 5d | 2009-04-09 | 2009-04-13 | 1341SS+1d | 82d | 0d | 88/1/20 | 88/1/24 | مترمربع | 87/09/22 | 87/10/01 |
| 1356 | 3.8.2.8 | قالب بندي ستونها و ديوارهاي طبقه پنجم | 5d | 2009-05-12 | 2009-05-16 | 1342SS+1d | 88d | 0d | 88/2/22 | 88/2/26 | مترمربع | 87/10/25 | 87/11/04 |
| 1357 | 3.8.2.9 | قالب بندي ستونها و ديوارهاي طبقه ششم | 5d | 2009-06-14 | 2009-06-18 | 1343SS+1d | 88d | 0d | 88/3/24 | 88/3/28 | مترمربع | 87/11/28 | 87/12/07 |
| 1358 | 3.8.2.10 | قالب بندي ستونها و ديوارهاي طبقه هفتم | 5d | 2009-07-17 | 2009-07-21 | 1344SS+1d | 93d | 0d | 88/4/26 | 88/4/30 | مترمربع | 88/01/01 | 88/01/10 |
| 1359 | 3.8.2.11 | قالب بندي ستونها و ديوارهاي طبقه هشتم | 5d | 2009-08-19 | 2009-08-23 | 1345SS+1d | 100d | 0d | 88/5/28 | 88/6/1 | مترمربع | 88/02/03 | 88/02/12 |
| 1360 | 3.8.2.12 | قالب بندي ستونها و ديوارهاي طبقه نهم | 5d | 2009-09-21 | 2009-09-25 | 1346SS+1d | 107d | 0d | 88/6/30 | 88/7/3 | مترمربع | 88/03/01 | 88/03/10 |
| 1361 | 3.8.2.13 | قالب بندي ستونها و ديوارهاي طبقه دهم و خرپشته | 5d | 2009-10-24 | 2009-10-28 | 1347SS+1d | 114d | 0d | 88/8/2 | 88/8/6 | مترمربع | 88/04/03 | 88/04/12 |
| 1362 | 3.8.3 | **بتن ريزي ستونها و ديوارها** | 398d | 2008-09-19 | 2009-10-30 |  | 0d |  | 87/6/29 | 88/8/8 |  |  |  |
| 1363 | 3.8.3.1 | بتن ريزي ستونها و ديوارهاي زيرزمين دوم | 2d | 2008-09-19 | 2008-09-20 | 1349 | 0d |  | 87/6/29 | 87/6/30 | مترمکعب |  |  |
| 1364 | 3.8.3.2 | بتن ريزي ستونها و ديوارهاي زيرزمين اول | 2d | 2008-10-22 | 2008-10-23 | 1350 | 54d | 0d | 87/8/1 | 87/8/2 | مترمکعب | 87/04/19 | 87/04/28 |
| 1365 | 3.8.3.3 | بتن ريزي ستونها و ديوارهاي همكف | 2d | 2008-11-24 | 2008-11-25 | 1351 | 54d | 0d | 87/9/4 | 87/9/5 | مترمکعب | 87/05/21 | 87/05/30 |
| 1366 | 3.8.3.4 | بتن ريزي ستونها و ديوارهاي طبقه اول | 2d | 2008-12-27 | 2008-12-28 | 1352 | 61d | 0d | 87/10/7 | 87/10/8 | مترمکعب | 87/06/23 | 87/07/01 |
| 1367 | 3.8.3.5 | بتن ريزي ستونها و ديوارهاي طبقه دوم | 2d | 2009-01-29 | 2009-01-30 | 1353 | 68d | 0d | 87/11/10 | 87/11/11 | مترمکعب | 87/07/24 | 87/07/25 |
| 1368 | 3.8.3.6 | بتن ريزي ستونها و ديوارهاي طبقه سوم | 2d | 2009-03-03 | 2009-03-04 | 1354 | 75d | 0d | 87/12/13 | 87/12/14 | مترمکعب | 87/08/27 | 87/08/28 |
| 1369 | 3.8.3.7 | بتن ريزي ستونها و ديوارهاي طبقه چهارم | 2d | 2009-04-14 | 2009-04-15 | 1355 | 82d | 0d | 88/1/25 | 88/1/26 | مترمکعب | 87/09/30 | 87/10/01 |
| 1370 | 3.8.3.8 | بتن ريزي ستونها و ديوارهاي طبقه پنجم | 2d | 2009-05-17 | 2009-05-18 | 1356 | 88d | 0d | 88/2/27 | 88/2/28 | مترمکعب | 87/11/03 | 87/11/04 |
| 1371 | 3.8.3.9 | بتن ريزي ستونها و ديوارهاي طبقه ششم | 2d | 2009-06-19 | 2009-06-20 | 1357 | 88d | 0d | 88/3/29 | 88/3/30 | مترمکعب | 87/12/06 | 87/12/07 |
| 1372 | 3.8.3.10 | بتن ريزي ستونها و ديوارهاي طبقه هفتم | 2d | 2009-07-22 | 2009-07-23 | 1358 | 93d | 0d | 88/4/31 | 88/5/1 | مترمکعب | 88/01/09 | 88/01/10 |
| 1373 | 3.8.3.11 | بتن ريزي ستونها و ديوارهاي طبقه هشتم | 2d | 2009-08-24 | 2009-08-25 | 1359 | 100d | 0d | 88/6/2 | 88/6/3 | مترمکعب | 88/02/11 | 88/02/12 |
| 1374 | 3.8.3.12 | بتن ريزي ستونها و ديوارهاي طبقه نهم | 2d | 2009-09-26 | 2009-09-27 | 1360 | 107d | 0d | 88/7/4 | 88/7/5 | مترمکعب | 88/03/09 | 88/03/10 |
| 1375 | 3.8.3.13 | بتن ريزي ستونها و ديوارهاي طبقه دهم | 2d | 2009-10-29 | 2009-10-30 | 1361 | 114d | 0d | 88/8/7 | 88/8/8 | مترمکعب | 88/04/11 | 88/04/12 |

| ID | WBS | Task | Duration | Start | Finish | Predecessors | Total slack | Free slack | Plan Start | Plan Finish | واحد | Text1 | Text2 |
| --- | --- | --- | --- | --- | --- | --- | --- | --- | --- | --- | --- | --- | --- |
| 1376 | 3.8.4 | **آرماتوربندي تيرها** | 401d | 2008-09-21 | 2009-11-04 |  | 0d |  | 87/6/31 | 88/8/13 |  |  |  |
| 1377 | 3.8.4.1 | آرماتوربندي تيرهاي زيرزمين دوم | 5d | 2008-09-21 | 2008-09-25 | 1363 | 0d |  | 87/6/31 | 87/7/4 | تن |  |  |
| 1378 | 3.8.4.2 | آرماتوربندي تيرهاي زيرزمين اول | 5d | 2008-10-24 | 2008-10-28 | 1364 | 54d | 0d | 87/8/3 | 87/8/7 | تن |  |  |
| 1379 | 3.8.4.3 | آرماتوربندي تيرهاي همكف | 5d | 2008-11-26 | 2008-11-30 | 1365 | 54d | 0d | 87/9/6 | 87/9/10 | تن |  |  |
| 1380 | 3.8.4.4 | آرماتوربندي تيرهاي طبقه اول | 5d | 2008-12-29 | 2009-01-02 | 1366 | 61d | 0d | 87/10/9 | 87/10/13 | تن |  |  |
| 1381 | 3.8.4.5 | آرماتوربندي تيرهاي طبقه دوم | 5d | 2009-01-31 | 2009-02-04 | 1367 | 68d | 0d | 87/11/12 | 87/11/16 | تن | 87/07/25 | 87/08/04 |
| 1382 | 3.8.4.6 | آرماتوربندي تيرها ي طبقه سوم | 5d | 2009-03-05 | 2009-03-09 | 1368 | 75d | 0d | 87/12/15 | 87/12/19 | تن | 87/08/28 | 87/09/07 |
| 1383 | 3.8.4.7 | آرماتوربندي تيرهاي طبقه چهارم | 5d | 2009-04-16 | 2009-04-20 | 1369 | 82d | 0d | 88/1/27 | 88/1/31 | تن | 87/10/01 | 87/10/10 |
| 1384 | 3.8.4.8 | آرماتوربندي تيرهاي طبقه پنجم | 5d | 2009-05-19 | 2009-05-23 | 1370 | 88d | 0d | 88/2/29 | 88/3/2 | تن | 87/11/04 | 87/11/13 |
| 1385 | 3.8.4.9 | آرماتوربندي تيرهاي طبقه ششم | 5d | 2009-06-21 | 2009-06-25 | 1371 | 88d | 0d | 88/3/31 | 88/4/4 | تن | 87/12/07 | 87/12/16 |
| 1386 | 3.8.4.10 | آرماتوربندي تيرهاي طبقه هفتم | 5d | 2009-07-24 | 2009-07-28 | 1372 | 93d | 0d | 88/5/2 | 88/5/6 | تن | 88/01/10 | 88/01/19 |
| 1387 | 3.8.4.11 | آرماتوربندي تيرهاي طبقه هشتم | 5d | 2009-08-26 | 2009-08-30 | 1373 | 100d | 0d | 88/6/4 | 88/6/8 | تن | 88/02/12 | 88/02/21 |
| 1388 | 3.8.4.12 | آرماتوربندي تيرهاي طبقه نهم | 5d | 2009-09-28 | 2009-10-02 | 1374 | 107d | 0d | 88/7/6 | 88/7/10 | تن | 88/03/10 | 88/03/19 |
| 1389 | 3.8.4.13 | آرماتوربندي تيرهاي طبقه دهم و خرپشته | 5d | 2009-10-31 | 2009-11-04 | 1375 | 114d | 0d | 88/8/9 | 88/8/13 | تن | 88/04/12 | 88/04/21 |
| 1390 | 3.8.5 | **قالب بندي تيرها** | 401d | 2008-09-22 | 2009-11-05 |  | 0d |  | 87/7/1 | 88/8/14 |  |  |  |
| 1391 | 3.8.5.1 | قالب بندي تيرها زيرزمين دوم | 5d | 2008-09-22 | 2008-09-26 | 1377SS+1d | 0d |  | 87/7/1 | 87/7/5 | مترمربع |  |  |
| 1392 | 3.8.5.2 | قالب بندي تيرهاي زيرزمين اول | 5d | 2008-10-25 | 2008-10-29 | 1378SS+1d | 54d | 0d | 87/8/4 | 87/8/8 | مترمربع |  |  |
| 1393 | 3.8.5.3 | قالب بندي تيرهاي همكف | 5d | 2008-11-27 | 2008-12-01 | 1379SS+1d | 54d | 0d | 87/9/7 | 87/9/11 | مترمربع |  |  |
| 1394 | 3.8.5.4 | قالب بندي تيرهاي طبقه اول | 5d | 2008-12-30 | 2009-01-03 | 1380SS+1d | 61d | 0d | 87/10/10 | 87/10/14 | مترمربع |  |  |
| 1395 | 3.8.5.5 | قالب بندي تيرهاي طبقه دوم | 5d | 2009-02-01 | 2009-02-05 | 1381SS+1d | 68d | 0d | 87/11/13 | 87/11/17 | مترمربع | 87/07/26 | 87/07/30 |
| 1396 | 3.8.5.6 | قالب بندي تيرهاي طبقه سوم | 5d | 2009-03-06 | 2009-03-10 | 1382SS+1d | 75d | 0d | 87/12/16 | 87/12/20 | مترمربع |  |  |
| 1397 | 3.8.5.7 | قالب بندي تيرهاي طبقه چهارم | 5d | 2009-04-17 | 2009-04-21 | 1383SS+1d | 82d | 0d | 88/1/28 | 88/2/1 | مترمربع | 87/10/02 | 87/10/06 |
| 1398 | 3.8.5.8 | قالب بندي تيرهاي طبقه پنجم | 5d | 2009-05-20 | 2009-05-24 | 1384SS+1d | 88d | 0d | 88/2/30 | 88/3/3 | مترمربع | 87/11/05 | 87/11/09 |
| 1399 | 3.8.5.9 | قالب بندي تيرهاي طبقه ششم | 5d | 2009-06-22 | 2009-06-26 | 1385SS+1d | 88d | 0d | 88/4/1 | 88/4/5 | مترمربع | 87/12/08 | 87/12/12 |
| 1400 | 3.8.5.10 | قالب بندي تيرهاي طبقه هفتم | 5d | 2009-07-25 | 2009-07-29 | 1386SS+1d | 93d | 0d | 88/5/3 | 88/5/7 | مترمربع | 88/01/11 | 88/01/15 |
| 1401 | 3.8.5.11 | قالب بندي تيرهاي طبقه هشتم | 5d | 2009-08-27 | 2009-08-31 | 1387SS+1d | 100d | 0d | 88/6/5 | 88/6/9 | مترمربع | 88/02/13 | 88/02/17 |
| 1402 | 3.8.5.12 | قالب بندي تيرهاي طبقه نهم | 5d | 2009-09-29 | 2009-10-03 | 1388SS+1d | 107d | 0d | 88/7/7 | 88/7/11 | مترمربع | 88/03/11 | 88/03/15 |
| 1403 | 3.8.5.13 | قالب بندي تيرهاي طبقه دهم و خرپشته | 5d | 2009-11-01 | 2009-11-05 | 1389SS+1d | 114d | 0d | 88/8/10 | 88/8/14 | مترمربع | 88/04/13 | 88/04/17 |

| ID | WBS | Task | Duration | Start | Finish | Predecessors | Total slack | Free slack | Plan Start | Plan Finish | واحد | Text1 | Text2 |
| --- | --- | --- | --- | --- | --- | --- | --- | --- | --- | --- | --- | --- | --- |
| 1404 | 3.8.6 | **بتن ريزي تيرها** | 398d | 2008-09-27 | 2009-11-07 |  | 0d |  | 87/7/6 | 88/8/16 |  |  |  |
| 1405 | 3.8.6.1 | بتن ريزي تيرهاي زيرزمين دوم | 2d | 2008-09-27 | 2008-09-28 | 1391 | 0d |  | 87/7/6 | 87/7/7 | مترمکعب |  |  |
| 1406 | 3.8.6.2 | بتن ريزي تيرهاي زيرزمين اول | 2d | 2008-10-30 | 2008-10-31 | 1392 | 54d | 0d | 87/8/9 | 87/8/10 | مترمکعب |  |  |
| 1407 | 3.8.6.3 | بتن ريزي تيرهاي همكف | 2d | 2008-12-02 | 2008-12-03 | 1393 | 54d | 0d | 87/9/12 | 87/9/13 | مترمکعب |  |  |
| 1408 | 3.8.6.4 | بتن ريزي تيرها طبقه اول | 2d | 2009-01-04 | 2009-01-05 | 1394 | 61d | 0d | 87/10/15 | 87/10/16 | مترمکعب |  |  |
| 1409 | 3.8.6.5 | بتن ريزي تيرهاي طبقه دوم | 2d | 2009-02-06 | 2009-02-07 | 1395 | 68d | 0d | 87/11/18 | 87/11/19 | مترمکعب |  |  |
| 1410 | 3.8.6.6 | بتن ريزي تيرهاي طبقه سوم | 2d | 2009-03-11 | 2009-03-12 | 1396 | 75d | 0d | 87/12/21 | 87/12/22 | مترمکعب |  |  |
| 1411 | 3.8.6.7 | بتن ريزي تيرهاي طبقه چهارم | 2d | 2009-04-22 | 2009-04-23 | 1397 | 82d | 0d | 88/2/2 | 88/2/3 | مترمکعب |  |  |
| 1412 | 3.8.6.8 | بتن ريزي تيرهاي طبقه پنجم | 2d | 2009-05-25 | 2009-05-26 | 1398 | 88d | 0d | 88/3/4 | 88/3/5 | مترمکعب |  |  |
| 1413 | 3.8.6.9 | بتن ريزي تيرهاي طبقه ششم | 2d | 2009-06-27 | 2009-06-28 | 1399 | 88d | 0d | 88/4/6 | 88/4/7 | مترمکعب |  |  |
| 1414 | 3.8.6.10 | بتن ريزي تيرهاي طبقه هفتم | 2d | 2009-07-30 | 2009-07-31 | 1400 | 93d | 0d | 88/5/8 | 88/5/9 | مترمکعب |  |  |
| 1415 | 3.8.6.11 | بتن ريزي تيرهاي طبقه هشتم | 2d | 2009-09-01 | 2009-09-02 | 1401 | 100d | 0d | 88/6/10 | 88/6/11 | مترمکعب |  |  |
| 1416 | 3.8.6.12 | بتن ريزي تيرهاي طبقه نهم | 2d | 2009-10-04 | 2009-10-05 | 1402 | 107d | 0d | 88/7/12 | 88/7/13 | مترمکعب |  |  |
| 1417 | 3.8.6.13 | بتن ريزي تيرهاي طبقه دهم و خرپشته | 2d | 2009-11-06 | 2009-11-07 | 1403 | 114d | 0d | 88/8/15 | 88/8/16 | مترمکعب |  |  |
| 1418 | 3.9 | **اجراي سقف سازه** | 406d | 2008-10-06 | 2009-11-24 |  | 0d |  | 87/7/15 | 88/9/3 | درصد |  |  |
| 1419 | 3.9.1 | **ساخت تيرچه و تيرچه گذاري** | 399d | 2008-10-06 | 2009-11-17 |  | 0d |  | 87/7/15 | 88/8/26 |  |  |  |
| 1420 | 3.9.1.1 | ساخت تيرچه و تيرچه گذاري زيرزمين دوم | 3d | 2008-10-06 | 2008-10-08 | 1405FS+7d | 0d |  | 87/7/15 | 87/7/17 |  |  |  |
| 1421 | 3.9.1.2 | ساخت تيرچه و تيرچه گذاري زيرزمين اول | 3d | 2008-11-08 | 2008-11-10 | 1406FS+7d | 54d | 0d | 87/8/18 | 87/8/20 |  | 87/04/25 | 87/05/03 |
| 1422 | 3.9.1.3 | ساخت تيرچه و تيرچه گذاري همكف | 3d | 2008-12-11 | 2008-12-13 | 1407FS+7d | 54d | 0d | 87/9/21 | 87/9/23 |  | 87/05/27 | 87/06/05 |
| 1423 | 3.9.1.4 | ساخت تيرچه و تيرچه گذاري طبقه اول | 3d | 2009-01-13 | 2009-01-15 | 1408FS+7d | 61d | 0d | 87/10/24 | 87/10/26 |  | 87/06/29 | 87/07/07 |
| 1424 | 3.9.1.5 | ساخت تيرچه و تيرچه گذاري طبقه دوم | 3d | 2009-02-15 | 2009-02-17 | 1409FS+7d | 68d | 0d | 87/11/27 | 87/11/29 |  | 87/08/01 | 87/08/10 |
| 1425 | 3.9.1.6 | ساخت تيرچه و تيرچه گذاري طبقه سوم | 3d | 2009-03-29 | 2009-03-31 | 1410FS+7d | 75d | 0d | 88/1/9 | 88/1/11 |  | 87/09/04 | 87/09/13 |
| 1426 | 3.9.1.7 | ساخت تيرچه و تيرچه گذاري طبقه چهارم | 3d | 2009-05-01 | 2009-05-03 | 1411FS+7d | 82d | 0d | 88/2/11 | 88/2/13 |  | 87/10/07 | 87/10/16 |
| 1427 | 3.9.1.8 | ساخت تيرچه و تيرچه گذاري طبقه پنجم | 3d | 2009-06-03 | 2009-06-05 | 1412FS+7d | 88d | 0d | 88/3/13 | 88/3/15 |  | 87/11/10 | 87/11/19 |
| 1428 | 3.9.1.9 | ساخت تيرچه و تيرچه گذاري طبقه ششم | 3d | 2009-07-06 | 2009-07-08 | 1413FS+7d | 88d | 0d | 88/4/15 | 88/4/17 |  | 87/12/13 | 87/12/22 |
| 1429 | 3.9.1.10 | ساخت تيرچه و تيرچه گذاري طبقه هفتم | 3d | 2009-08-08 | 2009-08-10 | 1414FS+7d | 93d | 0d | 88/5/17 | 88/5/19 |  | 88/01/16 | 88/01/25 |
| 1430 | 3.9.1.11 | ساخت تيرچه و تيرچه گذاري طبقه هشتم | 3d | 2009-09-10 | 2009-09-12 | 1415FS+7d | 100d | 0d | 88/6/19 | 88/6/21 |  | 88/02/18 | 88/02/27 |
| 1431 | 3.9.1.12 | ساخت تيرچه و تيرچه گذاري طبقه نهم | 3d | 2009-10-13 | 2009-10-15 | 1416FS+7d | 107d | 0d | 88/7/21 | 88/7/23 |  | 88/03/16 | 88/03/25 |
| 1432 | 3.9.1.13 | ساخت تيرچه و تيرچه گذاري طبقه دهم و خرپشته | 3d | 2009-11-15 | 2009-11-17 | 1417FS+7d | 114d | 0d | 88/8/24 | 88/8/26 |  | 88/04/18 | 88/04/27 |

| ID | WBS | Task | Duration | Start | Finish | Predecessors | Total slack | Free slack | Plan Start | Plan Finish | واحد | Text1 | Text2 |
| --- | --- | --- | --- | --- | --- | --- | --- | --- | --- | --- | --- | --- | --- |
| 1433 | 3.9.2 | **آرماتور بندي سقف و راه پله** | 402d | 2008-10-07 | 2009-11-21 |  | 0d |  | 87/7/16 | 88/8/30 |  |  |  |
| 1434 | 3.9.2.1 | آرماتور بندي سقف و راه پله زيرزمين دوم | 6d | 2008-10-07 | 2008-10-12 | 1420SS+1d | 0d |  | 87/7/16 | 87/7/21 | تن |  |  |
| 1435 | 3.9.2.2 | آرماتور بندي سقف و راه پله زيرزمين اول | 6d | 2008-11-09 | 2008-11-14 | 1421SS+1d | 54d | 0d | 87/8/19 | 87/8/24 | تن | 87/04/27 | 87/05/05 |
| 1436 | 3.9.2.3 | آرماتور بندي سقف و راه پله همكف | 6d | 2008-12-12 | 2008-12-17 | 1422SS+1d | 54d | 0d | 87/9/22 | 87/9/27 | تن | 87/05/29 | 87/06/07 |
| 1437 | 3.9.2.4 | آرماتور بندي سقف و راه پله طبقه اول | 6d | 2009-01-14 | 2009-01-19 | 1423SS+1d | 61d | 0d | 87/10/25 | 87/10/30 | تن | 87/06/31 | 87/07/09 |
| 1438 | 3.9.2.5 | آرماتور بندي سقف و راه پله طبقه دوم | 6d | 2009-02-16 | 2009-02-21 | 1424SS+1d | 68d | 0d | 87/11/28 | 87/12/3 | تن | 87/08/03 | 87/08/12 |
| 1439 | 3.9.2.6 | آرماتور بندي سقف و راه پله طبقه سوم | 6d | 2009-03-30 | 2009-04-04 | 1425SS+1d | 75d | 0d | 88/1/10 | 88/1/15 | تن | 87/09/06 | 87/09/15 |
| 1440 | 3.9.2.7 | آرماتور بندي سقف و راه پله طبقه چهارم | 6d | 2009-05-02 | 2009-05-07 | 1426SS+1d | 82d | 0d | 88/2/12 | 88/2/17 | تن | 87/10/09 | 87/10/18 |
| 1441 | 3.9.2.8 | آرماتور بندي سقف و راه پله طبقه پنجم | 6d | 2009-06-04 | 2009-06-09 | 1427SS+1d | 88d | 0d | 88/3/14 | 88/3/19 | تن | 87/11/12 | 87/11/21 |
| 1442 | 3.9.2.9 | آرماتور بندي سقف و راه پله طبقه ششم | 6d | 2009-07-07 | 2009-07-12 | 1428SS+1d | 88d | 0d | 88/4/16 | 88/4/21 | تن | 87/12/15 | 87/12/24 |
| 1443 | 3.9.2.10 | آرماتور بندي سقف و راه پله طبقه هفتم | 6d | 2009-08-09 | 2009-08-14 | 1429SS+1d | 93d | 0d | 88/5/18 | 88/5/23 | تن | 88/01/18 | 88/01/27 |
| 1444 | 3.9.2.11 | آرماتور بندي سقف و راه پله طبقه هشتم | 6d | 2009-09-11 | 2009-09-16 | 1430SS+1d | 100d | 0d | 88/6/20 | 88/6/25 | تن | 88/02/20 | 88/02/29 |
| 1445 | 3.9.2.12 | آرماتور بندي سقف و راه پله طبقه نهم | 6d | 2009-10-14 | 2009-10-19 | 1431SS+1d | 107d | 0d | 88/7/22 | 88/7/27 | تن | 88/03/18 | 88/03/27 |
| 1446 | 3.9.2.13 | آرماتور بندي سقف و راه پله طبقه دهم | 6d | 2009-11-16 | 2009-11-21 | 1432SS+1d | 114d | 0d | 88/8/25 | 88/8/30 | تن | 88/04/20 | 88/04/29 |
| 1447 | 3.9.3 | **قالب بندي سقف و راه پله** | 401d | 2008-10-08 | 2009-11-21 |  | 0d |  | 87/7/17 | 88/8/30 |  |  |  |
| 1448 | 3.9.3.1 | قالب بندي سقف و راه پله زيرزمين دوم | 5d | 2008-10-08 | 2008-10-12 | 1434SS+1d | 0d |  | 87/7/17 | 87/7/21 | مترمربع |  |  |
| 1449 | 3.9.3.2 | قالب بندي سقف و راه پله زيرزمين اول | 5d | 2008-11-10 | 2008-11-14 | 1435SS+1d | 54d | 0d | 87/8/20 | 87/8/24 | مترمربع | 87/05/06 | 87/05/10 |
| 1450 | 3.9.3.3 | قالب بندي سقف و راه پله همكف | 5d | 2008-12-13 | 2008-12-17 | 1436SS+1d | 54d | 0d | 87/9/23 | 87/9/27 | مترمربع | 87/06/07 | 87/06/07 |
| 1451 | 3.9.3.4 | قالب بندي سقف و راه پله طبقه اول | 5d | 2009-01-15 | 2009-01-19 | 1437SS+1d | 61d | 0d | 87/10/26 | 87/10/30 | مترمربع | 87/07/09 | 87/07/09 |
| 1452 | 3.9.3.5 | قالب بندي سقف و راه پله طبقه دوم | 5d | 2009-02-17 | 2009-02-21 | 1438SS+1d | 68d | 0d | 87/11/29 | 87/12/3 | مترمربع | 87/08/12 | 87/08/12 |
| 1453 | 3.9.3.6 | قالب بندي سقف و راه پله طبقه سوم | 5d | 2009-03-31 | 2009-04-04 | 1439SS+1d | 75d | 0d | 88/1/11 | 88/1/15 | مترمربع | 87/09/15 | 87/09/15 |
| 1454 | 3.9.3.7 | قالب بندي سقف و راه پله طبقه چهارم | 5d | 2009-05-03 | 2009-05-07 | 1440SS+1d | 82d | 0d | 88/2/13 | 88/2/17 | مترمربع | 87/10/18 | 87/10/18 |
| 1455 | 3.9.3.8 | قالب بندي سقف و راه پله طبقه پنجم | 5d | 2009-06-05 | 2009-06-09 | 1441SS+1d | 88d | 0d | 88/3/15 | 88/3/19 | مترمربع | 87/11/21 | 87/11/21 |
| 1456 | 3.9.3.9 | قالب بندي سقف و راه پله طبقه ششم | 5d | 2009-07-08 | 2009-07-12 | 1442SS+1d | 88d | 0d | 88/4/17 | 88/4/21 | مترمربع | 87/12/24 | 87/12/24 |
| 1457 | 3.9.3.10 | قالب بندي سقف و راه پله طبقه هفتم | 5d | 2009-08-10 | 2009-08-14 | 1443SS+1d | 93d | 0d | 88/5/19 | 88/5/23 | مترمربع | 88/01/27 | 88/01/27 |
| 1458 | 3.9.3.11 | قالب بندي سقف و راه پله طبقه هشتم | 5d | 2009-09-12 | 2009-09-16 | 1444SS+1d | 100d | 0d | 88/6/21 | 88/6/25 | مترمربع | 88/02/30 | 88/02/30 |
| 1459 | 3.9.3.12 | قالب بندي سقف و راه پله طبقه نهم | 5d | 2009-10-15 | 2009-10-19 | 1445SS+1d | 107d | 0d | 88/7/23 | 88/7/27 | مترمربع | 88/03/27 | 88/03/27 |
| 1460 | 3.9.3.13 | قالب بندي سقف و راه پله طبقه دهم | 5d | 2009-11-17 | 2009-11-21 | 1446SS+1d | 114d | 0d | 88/8/26 | 88/8/30 | مترمربع | 88/04/29 | 88/04/29 |

| ID | WBS | Task | Duration | Start | Finish | Predecessors | Total slack | Free slack | Plan Start | Plan Finish | واحد | Text1 | Text2 |
| --- | --- | --- | --- | --- | --- | --- | --- | --- | --- | --- | --- | --- | --- |
| 1461 | 3.9.4 | **بتن ريزي سقف و راه پله** | 399d | 2008-10-13 | 2009-11-24 |  | 0d |  | 87/7/22 | 88/9/3 |  |  |  |
| 1462 | 3.9.4.1 | بتن ريزي سقف و راه پله زيرزمين دوم | 3d | 2008-10-13 | 2008-10-15 | 1448 | 0d |  | 87/7/22 | 87/7/24 | مترمکعب |  |  |
| 1463 | 3.9.4.2 | بتن ريزي سقف و راه پله زيرزمين اول | 3d | 2008-11-15 | 2008-11-17 | 1449 | 54d | 0d | 87/8/25 | 87/8/27 | مترمکعب |  |  |
| 1464 | 3.9.4.3 | بتن ريزي سقف و راه پله همكف | 3d | 2008-12-18 | 2008-12-20 | 1450 | 54d | 0d | 87/9/28 | 87/9/30 | مترمکعب | 87/06/08 | 87/06/12 |
| 1465 | 3.9.4.4 | بتن ريزي سقف و راه پله طبقه اول | 3d | 2009-01-20 | 2009-01-22 | 1451 | 61d | 0d | 87/11/1 | 87/11/3 | مترمکعب | 87/07/10 | 87/07/14 |
| 1466 | 3.9.4.5 | بتن ريزي سقف و راه پله طبقه دوم | 3d | 2009-02-22 | 2009-02-24 | 1452 | 68d | 0d | 87/12/4 | 87/12/6 | مترمکعب | 87/08/13 | 87/08/17 |
| 1467 | 3.9.4.6 | بتن ريزي سقف و راه پله طبقه سوم | 3d | 2009-04-05 | 2009-04-07 | 1453 | 75d | 0d | 88/1/16 | 88/1/18 | مترمکعب | 87/09/16 | 87/09/20 |
| 1468 | 3.9.4.7 | بتن ريزي سقف و راه پله طبقه چهارم | 3d | 2009-05-08 | 2009-05-10 | 1454 | 82d | 0d | 88/2/18 | 88/2/20 | مترمکعب | 87/10/19 | 87/10/23 |
| 1469 | 3.9.4.8 | بتن ريزي سقف و راه پله طبقه پنجم | 3d | 2009-06-10 | 2009-06-12 | 1455 | 88d | 0d | 88/3/20 | 88/3/22 | مترمکعب | 87/11/22 | 87/11/26 |
| 1470 | 3.9.4.9 | بتن ريزي سقف و راه پله طبقه ششم | 3d | 2009-07-13 | 2009-07-15 | 1456 | 88d | 0d | 88/4/22 | 88/4/24 | مترمکعب | 87/12/25 | 87/12/29 |
| 1471 | 3.9.4.10 | بتن ريزي سقف و راه پله طبقه هفتم | 3d | 2009-08-15 | 2009-08-17 | 1457 | 93d | 0d | 88/5/24 | 88/5/26 | مترمکعب | 88/01/28 | 88/02/01 |
| 1472 | 3.9.4.11 | بتن ريزي سقف و راه پله طبقه هشتم | 3d | 2009-09-17 | 2009-09-19 | 1458 | 100d | 0d | 88/6/26 | 88/6/28 | مترمکعب | 88/02/26 | 88/02/30 |
| 1473 | 3.9.4.12 | بتن ريزي سقف و راه پله طبقه نهم | 3d | 2009-10-20 | 2009-10-22 | 1459 | 107d | 0d | 88/7/28 | 88/7/30 | مترمکعب | 88/03/28 | 88/04/01 |
| 1474 | 3.9.4.13 | بتن ريزي سقف و راه پله طبقه دهم | 3d | 2009-11-22 | 2009-11-24 | 1460 | 114d | 0d | 88/9/1 | 88/9/3 | مترمکعب |  |  |
| 1475 | 3.10 | **سفت كاري** | 729d | 2008-10-23 | 2010-11-07 |  | 0d |  | 87/8/2 | 89/8/16 | درصد | 87/07/30 | 88/07/04 |
| 1476 | 3.10.1 | **نبشي كشي نما** | 333d | 2008-12-28 | 2009-12-04 |  | 240d | 18d | 87/10/8 | 88/9/13 |  |  |  |
| 1477 | 3.10.1.1 | نبشي كشي نماي همكف | 3d | 2008-12-28 | 2008-12-30 | 1464FS+7d | 570d |  | 87/10/8 | 87/10/10 |  |  |  |
| 1478 | 3.10.1.2 | نبشي كشي نماي طبقه اول | 3d | 2009-01-30 | 2009-02-01 | 1465FS+7d | 537d |  | 87/11/11 | 87/11/13 |  |  |  |
| 1479 | 3.10.1.3 | نبشي كشي نماي طبقه دوم | 3d | 2009-03-04 | 2009-03-06 | 1466FS+7d | 504d |  | 87/12/14 | 87/12/16 |  |  |  |
| 1480 | 3.10.1.4 | نبشي كشي نماي طبقه سوم | 3d | 2009-04-15 | 2009-04-17 | 1467FS+7d | 471d |  | 88/1/26 | 88/1/28 |  |  |  |
| 1481 | 3.10.1.5 | نبشي كشي نماي طبقه چهارم | 3d | 2009-05-18 | 2009-05-20 | 1468FS+7d | 438d |  | 88/2/28 | 88/2/30 |  |  |  |
| 1482 | 3.10.1.6 | نبشي كشي نماي طبقه پنجم | 3d | 2009-06-20 | 2009-06-22 | 1469FS+7d | 405d |  | 88/3/30 | 88/4/1 |  |  |  |
| 1483 | 3.10.1.7 | نبشي كشي نماي طبقه ششم | 3d | 2009-07-23 | 2009-07-25 | 1470FS+7d | 372d |  | 88/5/1 | 88/5/3 |  |  |  |
| 1484 | 3.10.1.8 | نبشي كشي نماي طبقه هفتم | 3d | 2009-08-25 | 2009-08-27 | 1471FS+7d | 339d |  | 88/6/3 | 88/6/5 |  |  |  |
| 1485 | 3.10.1.9 | نبشي كشي نماي طبقه هشتم | 3d | 2009-09-27 | 2009-09-29 | 1472FS+7d | 306d |  | 88/7/5 | 88/7/7 |  |  |  |
| 1486 | 3.10.1.10 | نبشي كشي نماي طبقه نهم | 3d | 2009-10-30 | 2009-11-01 | 1473FS+7d | 273d |  | 88/8/8 | 88/8/10 |  |  |  |
| 1487 | 3.10.1.11 | نبشي كشي نماي طبقه دهم و خرپشته | 3d | 2009-12-02 | 2009-12-04 | 1474FS+7d | 240d |  | 88/9/11 | 88/9/13 |  |  |  |

| ID | WBS | Task | Duration | Start | Finish | Predecessors | Total slack | Free slack | Text1 | Text2 | واحد | Plan Start | Plan Finish |
| --- | --- | --- | --- | --- | --- | --- | --- | --- | --- | --- | --- | --- | --- |
| 1488 | 3.10.2 | **اجراي ديوارهاي طبقات** | 410d | 2008-10-23 | 2009-12-15 |  | 0d |  | 87/11/16 | 88/07/04 | درصد | 87/8/2 | 88/9/24 |
| 1489 | 3.10.2.1 | اجراي ديوارهاي طبقه زيرزمين دوم | 14d | 2008-10-23 | 2008-11-05 | 1462FS+7d | 0d |  |  |  | مترمربع | 87/8/2 | 87/8/15 |
| 1490 | 3.10.2.2 | اجراي ديوارهاي طبقه زيرزمين اول | 14d | 2008-11-25 | 2008-12-08 | 1463FS+7d, 1489 | 57d | 0d | 87/11/16 | 87/12/05 | مترمربع | 87/9/5 | 87/9/18 |
| 1491 | 3.10.2.3 | اجراي ديوارهاي طبقه همكف | 14d | 2008-12-28 | 2009-01-10 | 1464FS+7d, 1490 | 54d | 0d | 87/12/06 | 87/12/25 | مترمربع | 87/10/8 | 87/10/21 |
| 1492 | 3.10.2.4 | اجراي ديوارهاي طبقه اول | 14d | 2009-01-30 | 2009-02-12 | 1465FS+7d, 1491 | 61d | 0d | 87/12/26 | 88/01/15 | مترمربع | 87/11/11 | 87/11/24 |
| 1493 | 3.10.2.5 | اجراي ديوارهاي طبقه دوم | 14d | 2009-03-04 | 2009-03-17 | 1466FS+7d, 1492 | 68d | 0d | 88/01/16 | 88/02/04 | مترمربع | 87/12/14 | 87/12/27 |
| 1494 | 3.10.2.6 | اجراي ديوارهاي طبقه سوم | 14d | 2009-04-15 | 2009-04-28 | 1467FS+7d, 1493 | 75d | 0d | 88/02/05 | 88/02/24 | مترمربع | 88/1/26 | 88/2/8 |
| 1495 | 3.10.2.7 | اجراي ديوارهاي طبقه چهارم | 14d | 2009-05-18 | 2009-05-31 | 1468FS+7d, 1494 | 82d | 0d | 88/02/25 | 88/03/13 | مترمربع | 88/2/28 | 88/3/10 |
| 1496 | 3.10.2.8 | اجراي ديوارهاي طبقه پنجم | 14d | 2009-06-20 | 2009-07-03 | 1469FS+7d, 1495 | 89d | 0d | 88/03/14 | 88/04/02 | مترمربع | 88/3/30 | 88/4/12 |
| 1497 | 3.10.2.9 | اجراي ديوارهاي طبقه ششم | 14d | 2009-07-23 | 2009-08-05 | 1470FS+7d, 1496 | 88d | 0d | 88/04/03 | 88/04/22 | مترمربع | 88/5/1 | 88/5/14 |
| 1498 | 3.10.2.10 | اجراي ديوارهاي طبقه هفتم | 14d | 2009-08-25 | 2009-09-07 | 1471FS+7d, 1497 | 93d | 0d | 88/04/23 | 88/05/11 | مترمربع | 88/6/3 | 88/6/16 |
| 1499 | 3.10.2.11 | اجراي ديوارهاي طبقه هشتم | 14d | 2009-09-27 | 2009-10-10 | 1472FS+7d, 1498 | 100d | 0d | 88/05/12 | 88/05/31 | مترمربع | 88/7/5 | 88/7/18 |
| 1500 | 3.10.2.12 | اجراي ديوارهاي طبقه نهم | 14d | 2009-10-30 | 2009-11-12 | 1473FS+7d, 1499 | 107d | 0d | 88/06/01 | 88/06/20 | مترمربع | 88/8/8 | 88/8/21 |
| 1501 | 3.10.2.13 | اجراي ديوارهاي طبقه دهم | 14d | 2009-12-02 | 2009-12-15 | 1474FS+7d, 1500 | 114d | 0d | 88/06/21 | 88/07/04 | مترمربع | 88/9/11 | 88/9/24 |
| 1502 | 3.10.3 | **ساخت و نصب چهارجوب درب ها و نعل درگاهها** | 400d | 2008-11-03 | 2009-12-16 |  | 322d |  |  |  |  | 87/8/13 | 88/9/25 |
| 1503 | 3.10.3.1 | ساخت و نصب چهارجوب درب ها و نعل درگاههاي طبقه زير زمين دوم | 4d | 2008-11-03 | 2008-11-06 | 1489FF+1d | 718d |  |  |  |  | 87/8/13 | 87/8/16 |
| 1504 | 3.10.3.2 | ساخت و نصب چهارجوب درب ها و نعل درگاههاي طبقه زيرزمين اول | 4d | 2008-12-06 | 2008-12-09 | 1490FF+1d | 685d |  |  |  |  | 87/9/16 | 87/9/19 |
| 1505 | 3.10.3.3 | ساخت و نصب چهارجوب درب ها و نعل درگاههاي طبقه همكف | 4d | 2009-01-08 | 2009-01-11 | 1491FF+1d | 652d |  |  |  |  | 87/10/19 | 87/10/22 |
| 1506 | 3.10.3.4 | ساخت و نصب چهارجوب درب ها و نعل درگاههاي طبقه اول | 4d | 2009-02-10 | 2009-02-13 | 1492FF+1d | 619d |  |  |  |  | 87/11/22 | 87/11/25 |
| 1507 | 3.10.3.5 | ساخت و نصب چهارجوب درب ها و نعل درگاههاي طبقه دوم | 4d | 2009-03-15 | 2009-03-18 | 1493FF+1d | 586d |  |  |  |  | 87/12/25 | 87/12/28 |
| 1508 | 3.10.3.6 | ساخت و نصب چهارجوب درب ها و نعل درگاههاي طبقه سوم | 4d | 2009-04-26 | 2009-04-29 | 1494FF+1d | 553d |  |  |  |  | 88/2/6 | 88/2/9 |
| 1509 | 3.10.3.7 | ساخت و نصب چهارجوب درب ها و نعل درگاههاي طبقه چهارم | 4d | 2009-05-29 | 2009-06-01 | 1495FF+1d | 520d |  |  |  |  | 88/3/8 | 88/3/11 |
| 1510 | 3.10.3.8 | ساخت و نصب چهارجوب درب ها و نعل درگاههاي طبقه پنجم | 4d | 2009-07-01 | 2009-07-04 | 1496FF+1d | 487d |  |  |  |  | 88/4/10 | 88/4/13 |
| 1511 | 3.10.3.9 | ساخت و نصب چهارجوب درب ها و نعل درگاههاي طبقه ششم | 4d | 2009-08-03 | 2009-08-06 | 1497FF+1d | 454d |  |  |  |  | 88/5/12 | 88/5/15 |
| 1512 | 3.10.3.10 | ساخت و نصب چهارجوب درب ها و نعل درگاههاي طبقه هفتم | 4d | 2009-09-05 | 2009-09-08 | 1498FF+1d | 421d |  |  |  |  | 88/6/14 | 88/6/17 |
| 1513 | 3.10.3.11 | ساخت و نصب چهارجوب درب ها و نعل درگاههاي طبقه هشتم | 4d | 2009-10-08 | 2009-10-11 | 1499FF+1d | 388d |  |  |  |  | 88/7/16 | 88/7/19 |
| 1514 | 3.10.3.12 | ساخت و نصب چهارجوب درب ها و نعل درگاههاي طبقه نهم | 4d | 2009-11-10 | 2009-11-13 | 1500FF+1d | 355d |  |  |  |  | 88/8/19 | 88/8/22 |
| 1515 | 3.10.3.13 | ساخت و نصب چهارجوب درب ها و نعل درگاههاي طبقه دهم و خرپشته | 4d | 2009-12-13 | 2009-12-16 | 1501FF+1d | 322d |  |  |  |  | 88/9/22 | 88/9/25 |

| ID | WBS | Task | Duration | Start | Finish | Predecessors | Total slack | Free slack | Text1 | Text2 | واحد | Plan Start | Plan Finish |
| --- | --- | --- | --- | --- | --- | --- | --- | --- | --- | --- | --- | --- | --- |
| 1516 | 3.10.4 | **اجراي گچ و خاك طبقات** | 396d | 2009-01-11 | 2010-02-19 |  | 54d |  | 87/12/06 | 88/08/09 | درصد | 87/10/22 | 88/11/30 |
| 1517 | 3.10.4.1 | اجراي گچ و خاك طبقه همكف | 30d | 2009-01-11 | 2009-02-09 | 1491, 1673 | 54d | 0d | 88/01/06 | 88/01/25 | مترمربع | 87/10/22 | 87/11/21 |
| 1518 | 3.10.4.2 | اجراي گچ و خاك طبقه اول | 30d | 2009-02-13 | 2009-03-14 | 1492, 1517 | 61d | 0d | 88/01/26 | 88/02/14 | مترمربع | 87/11/25 | 87/12/24 |
| 1519 | 3.10.4.3 | اجراي گچ و خاك طبقه دوم | 30d | 2009-03-18 | 2009-04-25 | 1493, 1518 | 68d | 0d | 88/02/15 | 88/03/03 | مترمربع | 87/12/28 | 88/2/5 |
| 1520 | 3.10.4.4 | اجراي گچ و خاك طبقه سوم | 30d | 2009-04-29 | 2009-05-28 | 1494, 1519 | 75d | 0d | 88/03/04 | 88/03/23 | مترمربع | 88/2/9 | 88/3/7 |
| 1521 | 3.10.4.5 | اجراي گچ و خاك طبقه چهارم | 30d | 2009-06-01 | 2009-06-30 | 1495, 1520 | 82d | 0d | 88/03/24 | 88/04/12 | مترمربع | 88/3/11 | 88/4/9 |
| 1522 | 3.10.4.6 | اجراي گچ و خاك طبقه پنجم | 30d | 2009-07-04 | 2009-08-02 | 1496, 1521 | 89d | 0d | 88/04/13 | 88/05/01 | مترمربع | 88/4/13 | 88/5/11 |
| 1523 | 3.10.4.7 | اجراي گچ و خاك طبقه ششم | 38d | 2009-08-06 | 2009-09-12 | 1497, 1522 | 88d | 0d | 88/05/02 | 88/05/21 | مترمربع | 88/5/15 | 88/6/21 |
| 1524 | 3.10.4.8 | اجراي گچ و خاك طبقه هفتم | 40d | 2009-09-13 | 2009-10-22 | 1498, 1523 | 88d | 0d | 88/05/22 | 88/06/10 | مترمربع | 88/6/22 | 88/7/30 |
| 1525 | 3.10.4.9 | اجراي گچ و خاك طبقه هشتم | 40d | 2009-10-23 | 2009-12-01 | 1499, 1524 | 88d | 0d | 88/06/11 | 88/06/30 | مترمربع | 88/8/1 | 88/9/10 |
| 1526 | 3.10.4.10 | اجراي گچ و خاك طبقه نهم | 40d | 2009-12-02 | 2010-01-10 | 1500, 1525 | 88d | 0d | 88/06/31 | 88/07/19 | مترمربع | 88/9/11 | 88/10/20 |
| 1527 | 3.10.4.11 | اجراي گچ و خاك طبقه دهم و خرپشته | 40d | 2010-01-11 | 2010-02-19 | 1501, 1526 | 88d | 0d | 88/07/20 | 88/08/09 | مترمربع | 88/10/21 | 88/11/30 |
| 1528 | 3.10.5 | **اجراي سقف كاذب طبقات** | 163d | 2010-05-29 | 2010-11-07 |  | 0d |  | 88/02/15 | 88/09/19 | درصد | 89/3/8 | 89/8/16 |
| 1529 | 3.10.5.1 | اجراي سقف كاذب همکف | 20d | 2010-05-29 | 2010-06-17 | 1724, 1752, 1764 | 0d |  | 88/02/15 | 88/03/03 | مترمربع | 89/3/8 | 89/3/27 |
| 1530 | 3.10.5.2 | اجراي سقف كاذب طبقه 1 | 20d | 2010-06-05 | 2010-06-24 | 1725, 1753, 1765 | 140d |  | 88/03/04 | 88/03/23 | مترمربع | 89/3/15 | 89/4/3 |
| 1531 | 3.10.5.3 | اجراي سقف كاذب طبقه 2 | 20d | 2010-06-17 | 2010-07-06 | 1726, 1754, 1766 | 128d |  | 88/03/24 | 88/04/12 | مترمربع | 89/3/27 | 89/4/15 |
| 1532 | 3.10.5.4 | اجراي سقف كاذب طبقه 3 | 20d | 2010-07-02 | 2010-07-21 | 1727, 1755, 1767 | 113d |  | 88/04/13 | 88/05/01 | مترمربع | 89/4/11 | 89/4/30 |
| 1533 | 3.10.5.5 | اجراي سقف كاذب طبقه 4 | 20d | 2010-07-17 | 2010-08-05 | 1728, 1756, 1768 | 98d |  | 88/05/02 | 88/05/21 | مترمربع | 89/4/26 | 89/5/14 |
| 1534 | 3.10.5.6 | اجراي سقف كاذب طبقه 5 | 20d | 2010-08-01 | 2010-08-20 | 1729, 1757, 1769 | 83d |  | 88/05/22 | 88/06/10 | مترمربع | 89/5/10 | 89/5/29 |
| 1535 | 3.10.5.7 | اجراي سقف كاذب طبقه 6 | 20d | 2010-08-16 | 2010-09-04 | 1730, 1758, 1770 | 68d |  | 88/06/11 | 88/06/30 | مترمربع | 89/5/25 | 89/6/13 |
| 1536 | 3.10.5.8 | اجراي سقف كاذب طبقه 7 | 20d | 2010-08-31 | 2010-09-19 | 1731, 1759, 1771 | 53d |  | 88/06/31 | 88/07/19 | مترمربع | 89/6/9 | 89/6/28 |
| 1537 | 3.10.5.9 | اجراي سقف كاذب طبقه 8 | 20d | 2010-09-15 | 2010-10-04 | 1732, 1760, 1772 | 38d |  | 88/07/20 | 88/08/09 | مترمربع | 89/6/24 | 89/7/12 |
| 1538 | 3.10.5.10 | اجراي سقف كاذب طبقه 9 | 20d | 2010-09-30 | 2010-10-19 | 1733, 1761, 1773 | 23d |  | 88/08/10 | 88/08/29 | مترمربع | 89/7/8 | 89/7/27 |
| 1539 | 3.10.5.11 | اجراي سقف كاذب طبقه10 | 22d | 2010-10-17 | 2010-11-07 | 1734, 1762, 1774 | 4d |  | 88/08/30 | 88/09/19 | مترمربع | 89/7/25 | 89/8/16 |

| ID | WBS | Task | Duration | Start | Finish | Predecessors | Total slack | Free slack | Text1 | Text2 | واحد | Plan Start | Plan Finish |
| --- | --- | --- | --- | --- | --- | --- | --- | --- | --- | --- | --- | --- | --- |
| 1540 | 3.10.6 | **اجراي كف سازي نهائی طبقات** | 222d | 2010-02-14 | 2010-10-01 |  | 0d |  | 87/10/06 | 88/10/24 | درصد | 88/11/25 | 89/7/9 |
| 1541 | 3.10.6.1 | اجراي كف سازي طبقه زيرزمين دوم | 20d | 2010-02-14 | 2010-03-05 | 1599 | 0d |  | 88/01/16 | 88/02/04 | مترمربع | 88/11/25 | 88/12/14 |
| 1542 | 3.10.6.2 | اجراي كف سازي طبقه زيرزمين اول | 20d | 2010-03-01 | 2010-03-28 | 1600, 1643 | 218d | 0d | 88/01/16 | 88/02/04 | مترمربع | 88/12/10 | 89/1/8 |
| 1543 | 3.10.6.3 | اجراي كف سازي طبقه همكف | 20d | 2010-04-04 | 2010-04-23 | 1675SS, 1601 | 0d |  | 88/03/24 | 88/04/02 | مترمربع | 89/1/15 | 89/2/3 |
| 1544 | 3.10.6.4 | اجراي كف سازي طبقه اول | 20d | 2010-04-11 | 2010-04-30 | 1676SS, 1601 | 44d | 0d | 88/04/13 | 88/04/22 | مترمربع | 89/1/22 | 89/2/10 |
| 1545 | 3.10.6.5 | اجراي كف سازي طبقه 2 | 20d | 2010-04-23 | 2010-05-12 | 1677SS, 1602 | 42d | 0d | 88/05/02 | 88/05/11 | مترمربع | 89/2/3 | 89/2/22 |
| 1546 | 3.10.6.6 | اجراي كف سازي طبقه 3 | 20d | 2010-05-08 | 2010-05-27 | 1678SS, 1603 | 37d | 0d | 88/05/22 | 88/05/31 | مترمربع | 89/2/18 | 89/3/6 |
| 1547 | 3.10.6.7 | اجراي كف سازي طبقه 4 | 20d | 2010-05-23 | 2010-06-11 | 1679SS, 1604 | 32d | 0d | 88/06/11 | 88/06/20 | مترمربع | 89/3/2 | 89/3/21 |
| 1548 | 3.10.6.8 | اجراي كف سازي طبقه 5 | 20d | 2010-06-07 | 2010-06-26 | 1680SS, 1605 | 27d | 0d | 88/06/31 | 88/07/09 | مترمربع | 89/3/17 | 89/4/5 |
| 1549 | 3.10.6.9 | اجراي كف سازي طبقه 6 | 20d | 2010-06-22 | 2010-07-11 | 1681SS, 1606 | 22d | 0d | 88/07/20 | 88/07/29 | مترمربع | 89/4/1 | 89/4/20 |
| 1550 | 3.10.6.10 | اجراي كف سازي طبقه 7 | 20d | 2010-07-07 | 2010-07-26 | 1682SS, 1607 | 17d | 0d | 88/08/10 | 88/08/19 | مترمربع | 89/4/16 | 89/5/4 |
| 1551 | 3.10.6.11 | اجراي كف سازي طبقه 8 | 20d | 2010-07-22 | 2010-08-10 | 1683SS, 1608 | 12d | 0d | 88/08/30 | 88/09/09 | مترمربع | 89/4/31 | 89/5/19 |
| 1552 | 3.10.6.12 | اجراي كف سازي طبقه 9 | 20d | 2010-08-06 | 2010-08-25 | 1684SS, 1609 | 7d | 0d | 88/09/20 | 88/09/29 | مترمربع | 89/5/15 | 89/6/3 |
| 1553 | 3.10.6.13 | اجراي كف سازي طبقه 10 و خرپشته | 20d | 2010-08-23 | 2010-09-11 | 1685SS, 1610 | 0d |  |  |  | مترمربع | 89/6/1 | 89/6/20 |
| 1554 | 3.10.6.14 | اجراي كف سازي بام | 20d | 2010-09-12 | 2010-10-01 | 1553 | 41d |  | 88/10/10 | 88/10/24 | درصد | 89/6/21 | 89/7/9 |
| 1555 | 3.11 | **فاز اول تاسيسات مكانيكي طبقات** | 558d | 2009-01-25 | 2010-08-22 |  | 0d |  | 87/12/06 | 88/08/19 | درصد | 87/11/6 | 89/5/31 |
| 1556 | 3.11.1 | **لوله كشي فاضلاب ، آب باران ، ونت** | 511d | 2009-01-25 | 2010-07-06 |  | 0d |  | 87/12/06 | 88/07/29 | درصد | 87/11/6 | 89/4/15 |
| 1557 | 3.11.1.1 | لوله كشي زيرزمين دوم | 30d | 2009-01-25 | 2009-02-23 | 1672FS+60d | 0d |  |  |  | مترطول | 87/11/6 | 87/12/5 |
| 1558 | 3.11.1.2 | لوله كشي زيرزمين اول | 30d | 2009-03-06 | 2009-04-13 | 1557FS+10d, 1673FS+10d | 0d |  | 87/12/06 | 87/12/25 | مترطول | 87/12/16 | 88/1/24 |
| 1559 | 3.11.1.3 | لوله كشي طبقه همكف | 30d | 2009-04-24 | 2009-05-23 | 1517FS+10d, 1558FS+10d | 0d |  | 87/12/26 | 88/01/15 | مترطول | 88/2/4 | 88/3/2 |
| 1560 | 3.11.1.4 | لوله كشي طبقه اول | 30d | 2009-06-03 | 2009-07-02 | 1518FS+10d, 1559FS+10d | 0d |  | 88/01/16 | 88/02/04 | مترطول | 88/3/13 | 88/4/11 |
| 1561 | 3.11.1.5 | لوله كشي طبقه دوم | 30d | 2009-07-13 | 2009-08-11 | 1519FS+10d, 1560FS+10d | 0d |  | 88/02/05 | 88/02/24 | مترطول | 88/4/22 | 88/5/20 |
| 1562 | 3.11.1.6 | لوله كشي طبقه سوم | 30d | 2009-08-22 | 2009-09-20 | 1520FS+10d, 1561FS+10d | 0d |  | 88/02/25 | 88/03/13 | مترطول | 88/5/31 | 88/6/29 |
| 1563 | 3.11.1.7 | لوله كشي طبقه چهارم | 30d | 2009-10-01 | 2009-10-30 | 1521FS+10d, 1562FS+10d | 0d |  | 88/03/14 | 88/04/02 | مترطول | 88/7/9 | 88/8/8 |
| 1564 | 3.11.1.8 | لوله كشي طبقه پنجم | 30d | 2009-11-10 | 2009-12-09 | 1522FS+10d, 1563FS+10d | 0d |  | 88/04/03 | 88/04/22 | مترطول | 88/8/19 | 88/9/18 |
| 1565 | 3.11.1.9 | لوله كشي طبقه ششم | 30d | 2009-12-20 | 2010-01-18 | 1523FS+10d, 1564FS+10d | 0d |  | 88/04/23 | 88/05/11 | مترطول | 88/9/29 | 88/10/28 |
| 1566 | 3.11.1.10 | لوله كشي طبقه هفتم | 30d | 2010-01-29 | 2010-02-27 | 1524FS+10d, 1565FS+10d | 0d |  | 88/05/12 | 88/05/31 | مترطول | 88/11/9 | 88/12/8 |
| 1567 | 3.11.1.11 | لوله كشي طبقه هشتم | 30d | 2010-03-10 | 2010-04-16 | 1525FS+10d, 1566FS+10d | 0d |  | 88/06/01 | 88/06/20 | مترطول | 88/12/19 | 89/1/27 |
| 1568 | 3.11.1.12 | لوله كشي طبقه نهم | 30d | 2010-04-27 | 2010-05-26 | 1526FS+10d, 1567FS+10d | 0d |  | 88/06/21 | 88/07/09 | مترطول | 89/2/7 | 89/3/5 |
| 1569 | 3.11.1.13 | لوله كشي طبقه دهم | 31d | 2010-06-06 | 2010-07-06 | 1527FS+10d, 1568FS+10d | 0d |  | 88/07/10 | 88/07/29 | درصد | 89/3/16 | 89/4/15 |

| ID | WBS | Task | Duration | Start | Finish | Predecessors | Total slack | Free slack | Text1 | Text2 | واحد | Plan Start | Plan Finish |
| --- | --- | --- | --- | --- | --- | --- | --- | --- | --- | --- | --- | --- | --- |
| 1570 | 3.11.2 | **لوله كشي تهويه طبقات** | 516d | 2009-01-30 | 2010-07-16 |  | 118d |  | 87/12/06 | 88/07/29 | درصد | 87/11/11 | 89/4/25 |
| 1571 | 3.11.2.1 | لوله كشي تهويه طبقه زيرزمين دوم | 30d | 2009-01-30 | 2009-02-28 | 1557SS+5d | 604d |  |  |  | مترطول | 87/11/11 | 87/12/10 |
| 1572 | 3.11.2.2 | لوله كشي تهويه طبقه زيرزمين اول | 30d | 2009-03-16 | 2009-04-23 | 1558SS+10d | 559d |  | 87/12/06 | 87/12/25 | مترطول | 87/12/26 | 88/2/3 |
| 1573 | 3.11.2.3 | لوله كشي تهويه طبقه همكف | 30d | 2009-05-04 | 2009-06-02 | 1559SS+10d | 297d |  | 87/12/26 | 88/01/15 | مترطول | 88/2/14 | 88/3/12 |
| 1574 | 3.11.2.4 | لوله كشي تهويه طبقه اول | 30d | 2009-06-13 | 2009-07-12 | 1560SS+10d | 308d | 264d | 88/01/16 | 88/02/04 | مترطول | 88/3/23 | 88/4/21 |
| 1575 | 3.11.2.5 | لوله كشي تهويه طبقه دوم | 30d | 2009-07-23 | 2009-08-21 | 1561SS+10d | 278d | 236d | 88/02/05 | 88/02/24 | مترطول | 88/5/1 | 88/5/30 |
| 1576 | 3.11.2.6 | لوله كشي تهويه طبقه سوم | 30d | 2009-09-01 | 2009-09-30 | 1562SS+10d | 248d | 211d | 88/02/25 | 88/03/13 | مترطول | 88/6/10 | 88/7/8 |
| 1577 | 3.11.2.7 | لوله كشي تهويه طبقه چهارم | 30d | 2009-10-11 | 2009-11-09 | 1563SS+10d | 218d | 186d | 88/03/14 | 88/04/02 | مترطول | 88/7/19 | 88/8/18 |
| 1578 | 3.11.2.8 | لوله كشي تهويه طبقه پنجم | 30d | 2009-11-20 | 2009-12-19 | 1564SS+10d | 188d | 161d | 88/04/03 | 88/04/22 | مترطول | 88/8/29 | 88/9/28 |
| 1579 | 3.11.2.9 | لوله كشي تهويه طبقه ششم | 30d | 2009-12-30 | 2010-01-28 | 1565SS+10d | 158d | 136d | 88/04/23 | 88/05/11 | مترطول | 88/10/9 | 88/11/8 |
| 1580 | 3.11.2.10 | لوله كشي تهويه طبقه هفتم | 30d | 2010-02-08 | 2010-03-09 | 1566SS+10d | 128d | 111d | 88/05/12 | 88/05/31 | مترطول | 88/11/19 | 88/12/18 |
| 1581 | 3.11.2.11 | لوله كشي تهويه طبقه هشتم | 30d | 2010-03-28 | 2010-04-26 | 1567SS+10d | 98d | 86d | 88/06/01 | 88/06/20 | مترطول | 89/1/8 | 89/2/6 |
| 1582 | 3.11.2.12 | لوله كشي تهويه طبقه نهم | 30d | 2010-05-07 | 2010-06-05 | 1568SS+10d | 68d | 61d | 88/06/21 | 88/07/09 | مترطول | 89/2/17 | 89/3/15 |
| 1583 | 3.11.2.13 | لوله كشي تهويه طبقه دهم | 31d | 2010-06-16 | 2010-07-16 | 1569SS+10d | 37d |  | 88/07/10 | 88/07/29 | درصد | 89/3/26 | 89/4/25 |
| 1584 | 3.11.3 | **اجراي لوله كشي آتش نشاني و نصب جعبه ها** | 91d | 2010-03-06 | 2010-06-12 |  | 0d |  | 87/12/06 | 88/07/29 | درصد | 88/12/15 | 89/3/22 |
| 1585 | 3.11.3.1 | اجراي لوله آتش نشاني و نصب جعبه هاي زيرزمين دوم | 7d | 2010-03-06 | 2010-03-12 | 1541 | 0d |  |  |  | درصد | 88/12/15 | 88/12/21 |
| 1586 | 3.11.3.2 | اجراي لوله آتش نشاني و نصب جعبه هاي زيرزمين اول | 7d | 2010-03-13 | 2010-03-27 | 1585, 1673 | 0d |  | 87/12/06 | 87/12/25 | درصد | 88/12/22 | 89/1/7 |
| 1587 | 3.11.3.3 | اجراي لوله آتش نشاني و نصب جعبه هاي طبقه همكف | 7d | 2010-03-28 | 2010-04-03 | 1517, 1586 | 0d |  | 87/12/26 | 88/01/15 | درصد | 89/1/8 | 89/1/14 |
| 1588 | 3.11.3.4 | اجراي لوله آتش نشاني و نصب جعبه هاي طبقه اول | 7d | 2010-04-04 | 2010-04-10 | 1518, 1587 | 44d | 0d | 88/01/16 | 88/02/04 | درصد | 89/1/15 | 89/1/21 |
| 1589 | 3.11.3.5 | اجراي لوله آتش نشاني و نصب جعبه هاي طبقه دوم | 7d | 2010-04-11 | 2010-04-17 | 1519, 1588 | 47d | 0d | 88/02/05 | 88/02/24 | درصد | 89/1/22 | 89/1/28 |
| 1590 | 3.11.3.6 | اجراي لوله آتش نشاني و نصب جعبه هاي طبقه سوم | 7d | 2010-04-18 | 2010-04-24 | 1520, 1589 | 50d | 0d | 88/02/25 | 88/03/13 | درصد | 89/1/29 | 89/2/4 |
| 1591 | 3.11.3.7 | اجراي لوله آتش نشاني و نصب جعبه هاي طبقه جهارم | 7d | 2010-04-25 | 2010-05-01 | 1521, 1590 | 53d | 0d | 88/03/14 | 88/04/02 | درصد | 89/2/5 | 89/2/11 |
| 1592 | 3.11.3.8 | اجراي لوله آتش نشاني و نصب جعبه هاي طبقه پنجم | 7d | 2010-05-02 | 2010-05-08 | 1522, 1591 | 56d | 0d | 88/04/03 | 88/04/22 | درصد | 89/2/12 | 89/2/18 |
| 1593 | 3.11.3.9 | اجراي لوله آتش نشاني و نصب جعبه هاي طبقه ششم | 7d | 2010-05-09 | 2010-05-15 | 1523, 1592 | 59d | 0d | 88/04/23 | 88/05/11 | درصد | 89/2/19 | 89/2/25 |
| 1594 | 3.11.3.10 | اجراي لوله آتش نشاني و نصب جعبه هاي طبقه هفتم | 7d | 2010-05-16 | 2010-05-22 | 1524, 1593 | 62d | 0d | 88/05/12 | 88/05/31 | درصد | 89/2/26 | 89/3/1 |
| 1595 | 3.11.3.11 | اجراي لوله آتش نشاني و نصب جعبه هاي طبقه هشتم | 7d | 2010-05-23 | 2010-05-29 | 1525, 1594 | 65d | 0d | 88/06/01 | 88/06/20 | درصد | 89/3/2 | 89/3/8 |
| 1596 | 3.11.3.12 | اجراي لوله آتش نشاني و نصب جعبه هاي طبقه نهم | 7d | 2010-05-30 | 2010-06-05 | 1526, 1595 | 68d | 0d | 88/06/21 | 88/07/09 | درصد | 89/3/9 | 89/3/15 |
| 1597 | 3.11.3.13 | اجراي لوله آتش نشاني و نصب جعبه هاي طبقه دهم | 7d | 2010-06-06 | 2010-06-12 | 1527, 1596 | 71d |  | 88/07/10 | 88/07/29 | درصد | 89/3/16 | 89/3/22 |

| ID | WBS | Task | Duration | Start | Finish | Predecessors | Total slack | Text1 | Text2 | واحد | Plan Start | Plan Finish |
| --- | --- | --- | --- | --- | --- | --- | --- | --- | --- | --- | --- | --- |
| 1598 | 3.11.4 | **لوله كشي سرد و گرم طبقات** | 197d | 2010-01-30 | 2010-08-22 |  | 0d | 87/12/06 | 88/07/29 | درصد | 88/11/10 | 89/5/31 |
| 1599 | 3.11.4.1 | لوله كشي سرد و گرم زيرزمين دوم | 15d | 2010-01-30 | 2010-02-14 | 1672, 1656, 1600SF | 0d |  |  | مترطول | 88/11/10 | 88/11/25 |
| 1600 | 3.11.4.2 | لوله كشي سرد و گرم زيرزمين اول | 15d | 2010-02-14 | 2010-03-01 | 1673, 1657, 1601SF | 0d | 87/12/06 | 87/12/25 | مترطول | 88/11/25 | 88/12/10 |
| 1601 | 3.11.4.3 | لوله كشي سرد و گرم طبقه همكف | 15d | 2010-03-01 | 2010-03-16 | 1517, 1658, 1602SF | 0d | 87/12/26 | 88/01/15 | مترطول | 88/12/10 | 88/12/25 |
| 1602 | 3.11.4.4 | لوله كشي سرد و گرم طبقه اول | 15d | 2010-03-16 | 2010-04-08 | 1518, 1659, 1603SF | 0d | 88/01/16 | 88/02/04 | مترطول | 88/12/25 | 89/1/19 |
| 1603 | 3.11.4.5 | لوله كشي سرد و گرم طبقه دوم | 15d | 2010-04-08 | 2010-04-23 | 1519, 1660, 1604SF | 0d | 88/02/05 | 88/02/24 | مترطول | 89/1/19 | 89/2/3 |
| 1604 | 3.11.4.6 | لوله كشي سرد و گرم طبقه سوم | 15d | 2010-04-23 | 2010-05-08 | 1520, 1661, 1605SF | 0d | 88/02/25 | 88/03/13 | مترطول | 89/2/3 | 89/2/18 |
| 1605 | 3.11.4.7 | لوله كشي سرد و گرم طبقه چهارم | 15d | 2010-05-08 | 2010-05-23 | 1521, 1662, 1606SF | 0d | 88/03/14 | 88/04/02 | مترطول | 89/2/18 | 89/3/2 |
| 1606 | 3.11.4.8 | لوله كشي سرد و گرم طبقه پنجم | 15d | 2010-05-23 | 2010-06-07 | 1522, 1663, 1607SF | 0d | 88/04/03 | 88/04/22 | مترطول | 89/3/2 | 89/3/17 |
| 1607 | 3.11.4.9 | لوله كشي سرد و گرم طبقه ششم | 15d | 2010-06-07 | 2010-06-22 | 1523, 1664, 1608SF | 0d | 88/04/23 | 88/05/11 | مترطول | 89/3/17 | 89/4/1 |
| 1608 | 3.11.4.10 | لوله كشي سرد و گرم طبقه هفتم | 15d | 2010-06-22 | 2010-07-07 | 1524, 1665, 1609SF | 0d | 88/05/12 | 88/05/31 | مترطول | 89/4/1 | 89/4/16 |
| 1609 | 3.11.4.11 | لوله كشي سرد و گرم طبقه هشتم | 15d | 2010-07-07 | 2010-07-22 | 1525, 1666, 1610SF | 0d | 88/06/01 | 88/06/20 | مترطول | 89/4/16 | 89/4/31 |
| 1610 | 3.11.4.12 | لوله كشي سرد و گرم طبقه نهم | 15d | 2010-07-22 | 2010-08-06 | 1526, 1667, 1611SF | 0d | 88/06/21 | 88/07/09 | مترطول | 89/4/31 | 89/5/15 |
| 1611 | 3.11.4.13 | لوله كشي سرد و گرم طبقه دهم | 17d | 2010-08-06 | 2010-08-22 | 1527, 1668 | 0d | 88/07/10 | 88/07/29 | مترطول | 89/5/15 | 89/5/31 |
| 1612 | 3.11.5 | **لوله كشي گرمايش طبقات** | 197d | 2010-01-30 | 2010-08-22 |  | 0d | 87/12/06 | 88/07/29 | درصد | 88/11/10 | 89/5/31 |
| 1613 | 3.11.5.1 | لوله كشي گرمايش زيرزمين دوم | 15d | 2010-01-30 | 2010-02-13 | 1599SS | 0d |  |  | مترطول | 88/11/10 | 88/11/24 |
| 1614 | 3.11.5.2 | لوله كشي گرمايش زيرزمين اول | 15d | 2010-02-14 | 2010-02-28 | 1600SS, 1613, 1673 | 0d | 87/12/06 | 87/12/25 | مترطول | 88/11/25 | 88/12/9 |
| 1615 | 3.11.5.3 | لوله كشي گرمايش طبقه همكف | 15d | 2010-03-01 | 2010-03-15 | 1517, 1601SS, 1614 | 0d | 87/12/26 | 88/01/15 | مترطول | 88/12/10 | 88/12/24 |
| 1616 | 3.11.5.4 | لوله كشي گرمايش طبقه اول | 15d | 2010-03-16 | 2010-04-07 | 1518, 1602SS, 1615 | 0d | 88/01/16 | 88/02/04 | مترطول | 88/12/25 | 89/1/18 |
| 1617 | 3.11.5.5 | لوله كشي گرمايش طبقه دوم | 15d | 2010-04-08 | 2010-04-22 | 1519, 1603SS, 1616 | 0d | 88/02/05 | 88/02/24 | مترطول | 89/1/19 | 89/2/2 |
| 1618 | 3.11.5.6 | لوله كشي گرمايش طبقه سوم | 15d | 2010-04-23 | 2010-05-07 | 1520, 1604SS, 1617 | 0d | 88/02/25 | 88/03/13 | مترطول | 89/2/3 | 89/2/17 |
| 1619 | 3.11.5.7 | لوله كشي گرمايش طبقه چهارم | 15d | 2010-05-08 | 2010-05-22 | 1521, 1605SS, 1618 | 0d | 88/03/14 | 88/04/02 | مترطول | 89/2/18 | 89/3/1 |
| 1620 | 3.11.5.8 | لوله كشي گرمايش طبقه پنجم | 15d | 2010-05-23 | 2010-06-06 | 1522, 1606SS, 1619 | 0d | 88/04/03 | 88/04/22 | مترطول | 89/3/2 | 89/3/16 |
| 1621 | 3.11.5.9 | لوله كشي گرمايش طبقه ششم | 15d | 2010-06-07 | 2010-06-21 | 1523, 1607SS, 1620 | 0d | 88/04/23 | 88/05/11 | مترطول | 89/3/17 | 89/3/31 |
| 1622 | 3.11.5.10 | لوله كشي گرمايش طبقه هفتم | 15d | 2010-06-22 | 2010-07-06 | 1524, 1608SS, 1621 | 0d | 88/05/12 | 88/05/31 | مترطول | 89/4/1 | 89/4/15 |
| 1623 | 3.11.5.11 | لوله كشي گرمايش طبقه هشتم | 15d | 2010-07-07 | 2010-07-21 | 1525, 1609SS, 1622 | 0d | 88/06/01 | 88/06/20 | مترطول | 89/4/16 | 89/4/30 |
| 1624 | 3.11.5.12 | لوله كشي گرمايش طبقه نهم | 15d | 2010-07-22 | 2010-08-05 | 1526, 1610SS, 1623 | 0d | 88/06/21 | 88/07/09 | مترطول | 89/4/31 | 89/5/14 |
| 1625 | 3.11.5.13 | لوله كشي گرمايش طبقه دهم | 17d | 2010-08-06 | 2010-08-22 | 1527, 1611SS, 1624 | 0d | 88/07/10 | 88/07/29 | مترطول | 89/5/15 | 89/5/31 |

| ID | WBS | Task | Duration | Start | Finish | Predecessors | Total slack | Free slack | Text1 | Text2 | واحد | Plan Start | Plan Finish |
| --- | --- | --- | --- | --- | --- | --- | --- | --- | --- | --- | --- | --- | --- |
| 1626 | 3.11.6 | **لوله كشي سرمايش(سيستم اسپليت) طبقات** | 197d | 2010-01-30 | 2010-08-22 |  | 0d |  | 87/12/06 | 88/07/29 | درصد | 88/11/10 | 89/5/31 |
| 1627 | 3.11.6.1 | لوله كشي سرمايش(سيستم اسپليت) زيرزمين دوم | 15d | 2010-01-30 | 2010-02-13 | 1613SS, 1672 | 0d |  |  |  | مترطول | 88/11/10 | 88/11/24 |
| 1628 | 3.11.6.2 | لوله كشي سرمايش(سيستم اسپليت )زيرزمين اول | 15d | 2010-02-14 | 2010-02-28 | 1627, 1673 | 0d |  | 87/12/06 | 87/12/25 | مترطول | 88/11/25 | 88/12/9 |
| 1629 | 3.11.6.3 | لوله كشي سرمايش(سيستم اسپليت ) طبقه همكف | 15d | 2010-03-01 | 2010-03-15 | 1517, 1628 | 0d |  | 87/12/26 | 88/01/15 | مترطول | 88/12/10 | 88/12/24 |
| 1630 | 3.11.6.4 | لوله كشي سرمايش(سيستم اسپليت )طبقه اول | 15d | 2010-03-16 | 2010-04-07 | 1518, 1629 | 0d |  | 88/01/16 | 88/02/04 | مترطول | 88/12/25 | 89/1/18 |
| 1631 | 3.11.6.5 | لوله كشي سرمايش(سيستم اسپليت ) طبقه دوم | 15d | 2010-04-08 | 2010-04-22 | 1519, 1630 | 0d |  | 88/02/05 | 88/02/24 | مترطول | 89/1/19 | 89/2/2 |
| 1632 | 3.11.6.6 | لوله كشي سرمايش(سيستم اسپليت ) طبقه سوم | 15d | 2010-04-23 | 2010-05-07 | 1520, 1631 | 0d |  | 88/02/25 | 88/03/13 | مترطول | 89/2/3 | 89/2/17 |
| 1633 | 3.11.6.7 | لوله كشي سرمايش(سيستم اسپليت ) طبقه چهارم | 15d | 2010-05-08 | 2010-05-22 | 1521, 1632 | 0d |  | 88/03/14 | 88/04/02 | مترطول | 89/2/18 | 89/3/1 |
| 1634 | 3.11.6.8 | لوله كشي سرمايش(سيستم اسپليت )طبقه پنجم | 15d | 2010-05-23 | 2010-06-06 | 1522, 1633 | 0d |  | 88/04/03 | 88/04/22 | مترطول | 89/3/2 | 89/3/16 |
| 1635 | 3.11.6.9 | لوله كشي سرمايش(سيستم اسپليت ) طبقه ششم | 15d | 2010-06-07 | 2010-06-21 | 1523, 1634 | 0d |  | 88/04/23 | 88/05/11 | مترطول | 89/3/17 | 89/3/31 |
| 1636 | 3.11.6.10 | لوله كشي سرمايش(سيستم اسپليت ) طبقه هفتم | 15d | 2010-06-22 | 2010-07-06 | 1524, 1635 | 0d |  | 88/05/12 | 88/05/31 | مترطول | 89/4/1 | 89/4/15 |
| 1637 | 3.11.6.11 | لوله كشي سرمايش(سيستم اسپليت )طبقه هشتم | 15d | 2010-07-07 | 2010-07-21 | 1525, 1636 | 0d |  | 88/06/01 | 88/06/20 | مترطول | 89/4/16 | 89/4/30 |
| 1638 | 3.11.6.12 | لوله كشي سرمايش(سيستم اسپليت )طبقه نهم | 15d | 2010-07-22 | 2010-08-05 | 1526, 1637 | 0d |  | 88/06/21 | 88/07/09 | مترطول | 89/4/31 | 89/5/14 |
| 1639 | 3.11.6.13 | لوله كشي سرمايش(سيستم اسپليت )طبقه دهم | 17d | 2010-08-06 | 2010-08-22 | 1527, 1638 | 0d |  | 88/07/10 | 88/07/29 | مترطول | 89/5/15 | 89/5/31 |
| 1640 | 3.12 | **فاز اول تاسيسات برقي طبقات** | 601d | 2008-11-26 | 2010-08-05 |  | 17d |  | 87/12/06 | 88/07/29 | درصد | 87/9/6 | 89/5/14 |
| 1641 | 3.12.1 | **اجراي سيستم ارت بندي طبقات** | 457d | 2008-11-26 | 2010-03-06 |  | 161d |  |  |  |  | 87/9/6 | 88/12/15 |
| 1642 | 3.12.1.1 | اجراي سيستم ارت بندي( زيرزمين دوم ) | 15d | 2008-11-26 | 2008-12-10 | 1672 | 423d | 18d |  |  | درصد | 87/9/6 | 87/9/20 |
| 1643 | 3.12.1.2 | اجراي سيستم ارت بندي( زيرزمين اول ) | 15d | 2008-12-29 | 2009-01-12 | 1642, 1673 | 405d | 28d | 87/12/06 | 87/12/25 | درصد | 87/10/9 | 87/10/23 |
| 1644 | 3.12.1.3 | اجراي سيستم ارت بندي( همكف ) | 15d | 2009-02-10 | 2009-02-24 | 1517, 1643 | 377d | 18d | 87/12/26 | 88/01/15 | درصد | 87/11/22 | 87/12/6 |
| 1645 | 3.12.1.4 | اجراي سيستم ارت بندي طبقه اول | 15d | 2009-03-15 | 2009-04-07 | 1518, 1644 | 359d | 18d | 88/01/16 | 88/02/04 | درصد | 87/12/25 | 88/1/18 |
| 1646 | 3.12.1.5 | اجراي سيستم ارت بندي طبقه دوم | 15d | 2009-04-26 | 2009-05-10 | 1519, 1645 | 341d | 18d | 88/02/05 | 88/02/24 | درصد | 88/2/6 | 88/2/20 |
| 1647 | 3.12.1.6 | اجراي سيستم ارت بندي طبقه سوم | 15d | 2009-05-29 | 2009-06-12 | 1520, 1646 | 323d | 18d | 88/02/25 | 88/03/13 | درصد | 88/3/8 | 88/3/22 |
| 1648 | 3.12.1.7 | اجراي سيستم ارت بندي طبقه چهارم | 15d | 2009-07-01 | 2009-07-15 | 1521, 1647 | 305d | 18d | 88/03/14 | 88/04/02 | درصد | 88/4/10 | 88/4/24 |
| 1649 | 3.12.1.8 | اجراي سيستم ارت بندي طبقه پنجم | 15d | 2009-08-03 | 2009-08-17 | 1522, 1648 | 287d | 26d | 88/04/03 | 88/04/22 | درصد | 88/5/12 | 88/5/26 |
| 1650 | 3.12.1.9 | اجراي سيستم ارت بندي طبقه ششم | 15d | 2009-09-13 | 2009-09-27 | 1523, 1649 | 261d | 25d | 88/04/23 | 88/05/11 | درصد | 88/6/22 | 88/7/5 |
| 1651 | 3.12.1.10 | اجراي سيستم ارت بندي طبقه هفتم | 15d | 2009-10-23 | 2009-11-06 | 1524, 1650 | 236d | 25d | 88/05/12 | 88/05/31 | درصد | 88/8/1 | 88/8/15 |
| 1652 | 3.12.1.11 | اجراي سيستم ارت بندي طبقه هشتم | 15d | 2009-12-02 | 2009-12-16 | 1525, 1651 | 211d | 25d | 88/06/01 | 88/06/20 | درصد | 88/9/11 | 88/9/25 |
| 1653 | 3.12.1.12 | اجراي سيستم ارت بندي طبقه نهم | 15d | 2010-01-11 | 2010-01-25 | 1526, 1652 | 186d | 25d | 88/06/21 | 88/07/09 | درصد | 88/10/21 | 88/11/5 |
| 1654 | 3.12.1.13 | اجراي سيستم ارت بندي طبقه دهم | 15d | 2010-02-20 | 2010-03-06 | 1527, 1653 | 161d |  | 88/07/10 | 88/07/29 | درصد | 88/12/1 | 88/12/15 |

| ID | WBS | Task | Duration | Start | Finish | Predecessors | Total slack | Free slack | Plan Start | Plan Finish | واحد | Text1 | Text2 |
| --- | --- | --- | --- | --- | --- | --- | --- | --- | --- | --- | --- | --- | --- |
| 1655 | 3.12.2 | **لوله گذاري و نصب قوطي كليد و پريز طبقات** | 481d | 2009-04-04 | 2010-08-05 |  | 0d |  | 88/1/15 | 89/5/14 |  |  |  |
| 1656 | 3.12.2.1 | لوله گذاري و نصب قوطي كليد و پريز( زيرزمين دوم ) | 30d | 2009-04-04 | 2009-05-03 | 1557, 1672FS+120d | 91d | 0d | 88/1/15 | 88/2/13 | درصد |  |  |
| 1657 | 3.12.2.2 | لوله گذاري و نصب قوطي كليد و پريز( زيرزمين اول ) | 30d | 2009-05-04 | 2009-06-02 | 1558, 1656, 1673FS+10d | 91d | 0d | 88/2/14 | 88/3/12 | درصد | 87/12/06 | 87/12/25 |
| 1658 | 3.12.2.3 | لوله گذاري و نصب قوطي كليد و پريز( همكف ) | 30d | 2009-06-03 | 2009-07-02 | 1517FS+10d, 1559, 1657 | 91d | 0d | 88/3/13 | 88/4/11 | درصد | 87/12/26 | 88/01/15 |
| 1659 | 3.12.2.4 | لوله گذاري و نصب قوطي كليد و پريز 1 | 30d | 2009-07-03 | 2009-08-01 | 1518FS+10d, 1560, 1658 | 91d | 10d | 88/4/12 | 88/5/10 | درصد | 88/01/16 | 88/02/04 |
| 1660 | 3.12.2.5 | لوله گذاري و نصب قوطي كليد و پريز 2 | 30d | 2009-08-12 | 2009-09-10 | 1519FS+10d, 1561, 1659 | 81d | 10d | 88/5/21 | 88/6/19 | درصد | 88/02/05 | 88/02/24 |
| 1661 | 3.12.2.6 | لوله گذاري و نصب قوطي كليد و پريز 3 | 30d | 2009-09-21 | 2009-10-20 | 1520FS+10d, 1562, 1660 | 71d | 10d | 88/6/30 | 88/7/28 | درصد | 88/02/25 | 88/03/13 |
| 1662 | 3.12.2.7 | لوله گذاري و نصب قوطي كليد و پريز 4 | 30d | 2009-10-31 | 2009-11-29 | 1521FS+10d, 1563, 1661 | 61d | 10d | 88/8/9 | 88/9/8 | درصد | 88/03/14 | 88/04/02 |
| 1663 | 3.12.2.8 | لوله گذاري و نصب قوطي كليد و پريز 5 | 30d | 2009-12-10 | 2010-01-08 | 1522FS+10d, 1564, 1662 | 51d | 10d | 88/9/19 | 88/10/18 | درصد | 88/04/03 | 88/04/22 |
| 1664 | 3.12.2.9 | لوله گذاري و نصب قوطي كليد و پريز 6 | 30d | 2010-01-19 | 2010-02-17 | 1523FS+10d, 1565, 1663 | 41d | 10d | 88/10/29 | 88/11/28 | درصد | 88/04/23 | 88/05/11 |
| 1665 | 3.12.2.10 | لوله گذاري و نصب قوطي كليد و پريز 7 | 30d | 2010-02-28 | 2010-04-06 | 1524FS+10d, 1566, 1664 | 31d | 10d | 88/12/9 | 89/1/17 | درصد | 88/05/12 | 88/05/31 |
| 1666 | 3.12.2.11 | لوله گذاري و نصب قوطي كليد و پريز 8 | 30d | 2010-04-17 | 2010-05-16 | 1525FS+10d, 1567, 1665 | 21d | 10d | 89/1/28 | 89/2/26 | درصد | 88/06/01 | 88/06/20 |
| 1667 | 3.12.2.12 | لوله گذاري و نصب قوطي كليد و پريز 9 | 30d | 2010-05-27 | 2010-06-25 | 1526FS+10d, 1568, 1666 | 11d |  | 89/3/6 | 89/4/4 | درصد | 88/06/21 | 88/07/09 |
| 1668 | 3.12.2.13 | لوله گذاري و نصب قوطي كليد و پريز 10 | 30d | 2010-07-07 | 2010-08-05 | 1527FS+10d, 1569, 1667 | 0d |  | 89/4/16 | 89/5/14 | درصد | 88/07/10 | 88/07/29 |
| 1669 | 3.13 | **نازك كاري** | 711d | 2008-11-06 | 2010-11-03 |  | 0d |  | 87/8/16 | 89/8/12 | درصد | 87/10/06 | 88/12/04 |
| 1670 | 3.13.1 | اجراي بتن كف پاركينگ و كفسازي | 10d | 2010-02-14 | 2010-02-23 | 1599, 1642 | 233d | 0d | 88/11/25 | 88/12/4 | درصد | 87/10/06 | 88/02/04 |
| 1671 | 3.13.2 | **سيمانكاري آستر و رويه زيرزمين پاركينگ** | 53d | 2008-11-06 | 2008-12-28 |  | 0d |  | 87/8/16 | 87/10/8 |  |  |  |
| 1672 | 3.13.2.1 | سيمانكاري آستر و رويه زيرزمين دوم | 20d | 2008-11-06 | 2008-11-25 | 1489 | 0d |  | 87/8/16 | 87/9/5 | مترمربع |  |  |
| 1673 | 3.13.2.2 | سيمانكاري آستر و رويه زيرزمين اول | 20d | 2008-12-09 | 2008-12-28 | 1490, 1672 | 57d | 0d | 87/9/19 | 87/10/8 | مترمربع | 87/12/06 | 87/12/25 |
| 1674 | 3.13.3 | **پلاستر سيمان سرويسها،آشپزخانه ها،،بالكن هاو…** | 151d | 2010-04-04 | 2010-09-01 |  | 0d |  | 89/1/15 | 89/6/10 |  |  |  |
| 1675 | 3.13.3.1 | پلاستر سيمان سرويسها،آشپزخانه هاو،بالكن هاي طبقه همكف | 10d | 2010-04-04 | 2010-04-13 | 1559, 1573, 1587, 1601, 1615, 1629, 1644, 1658 | 0d |  | 89/1/15 | 89/1/24 | متر مربع |  |  |
| 1676 | 3.13.3.2 | پلاستر سيمان سرويسها،آشپزخانه هاو،بالكن هاي طبقه اول | 10d | 2010-04-11 | 2010-04-20 | 1560, 1574, 1588, 1602, 1616, 1630, 1645, 1659 | 44d | 0d | 89/1/22 | 89/1/31 | متر مربع |  |  |
| 1677 | 3.13.3.3 | پلاستر سيمان سرويسها،آشپزخانه هاو،بالكن هاي طبقه دوم | 10d | 2010-04-23 | 2010-05-02 | 1561, 1575, 1589, 1603, 1617, 1631, 1646, 1660 | 42d | 0d | 89/2/3 | 89/2/12 | متر مربع |  |  |
| 1678 | 3.13.3.4 | پلاستر سيمان سرويسها،آشپزخانه هاو،بالكن هاي طبقه سوم | 10d | 2010-05-08 | 2010-05-17 | 1562, 1576, 1590, 1604, 1618, 1632, 1647, 1661 | 37d | 0d | 89/2/18 | 89/2/27 | متر مربع |  |  |
| 1679 | 3.13.3.5 | پلاستر سيمان سرويسها،آشپزخانه هاو،بالكن هاي طبقه چهارم | 10d | 2010-05-23 | 2010-06-01 | 1563, 1577, 1591, 1605, 1619, 1633, 1648, 1662 | 32d | 0d | 89/3/2 | 89/3/11 | متر مربع |  |  |
| 1680 | 3.13.3.6 | پلاستر سيمان سرويسها،آشپزخانه هاو،بالكن هاي طبقه پنجم | 10d | 2010-06-07 | 2010-06-16 | 1564, 1578, 1592, 1606, 1620, 1634, 1649, 1663 | 27d | 0d | 89/3/17 | 89/3/26 | متر مربع |  |  |
| 1681 | 3.13.3.7 | پلاستر سيمان سرويسها،آشپزخانه هاو،بالكن هاي طبقه ششم | 10d | 2010-06-22 | 2010-07-01 | 1565, 1579, 1593, 1607, 1621, 1635, 1650, 1664 | 22d | 0d | 89/4/1 | 89/4/10 | متر مربع |  |  |
| 1682 | 3.13.3.8 | پلاستر سيمان سرويسها،آشپزخانه هاو،بالكن هاي طبقه هفتم | 10d | 2010-07-07 | 2010-07-16 | 1566, 1580, 1594, 1608, 1622, 1636, 1651, 1665 | 17d | 0d | 89/4/16 | 89/4/25 | متر مربع |  |  |
| 1683 | 3.13.3.9 | پلاستر سيمان سرويسها،آشپزخانه هاو،بالكن هاي طبقه هشتم | 10d | 2010-07-22 | 2010-07-31 | 1567, 1581, 1595, 1609, 1623, 1637, 1652, 1666 | 12d | 0d | 89/4/31 | 89/5/9 | متر مربع |  |  |
| 1684 | 3.13.3.10 | پلاستر سيمان سرويسها،آشپزخانه هاو،بالكن هاي طبقه نهم | 10d | 2010-08-06 | 2010-08-15 | 1568, 1582, 1596, 1610, 1624, 1638, 1653, 1667 | 7d | 0d | 89/5/15 | 89/5/24 | متر مربع |  |  |
| 1685 | 3.13.3.11 | پلاستر سيمان سرويسها،آشپزخانه هاو،بالكن هاي طبقه دهم | 10d | 2010-08-23 | 2010-09-01 | 1569, 1583, 1597, 1611, 1625, 1639, 1654, 1668 | 0d |  | 89/6/1 | 89/6/10 | متر مربع |  |  |

| ID | WBS | Task | Duration | Start | Finish | Predecessors | Total slack | Free slack | Plan Start | Plan Finish | Text1 | Text2 | واحد |
| --- | --- | --- | --- | --- | --- | --- | --- | --- | --- | --- | --- | --- | --- |
| 1686 | 3.13.4 | **نصب پنجره ها و شيشه هاي طبقات** | 146d | 2010-04-04 | 2010-08-27 |  | 76d | 0d | 89/1/15 | 89/6/5 |  |  |  |
| 1687 | 3.13.4.1 | نصب پنجره ها و شيشه هاي طبقه همكف | 5d | 2010-04-04 | 2010-04-08 | 1675SS | 217d |  | 89/1/15 | 89/1/19 |  |  |  |
| 1688 | 3.13.4.2 | نصب پنجره ها و شيشه هاي طبقه اول | 5d | 2010-04-11 | 2010-04-15 | 1676SS | 210d |  | 89/1/22 | 89/1/26 |  |  |  |
| 1689 | 3.13.4.3 | نصب پنجره ها و شيشه هاي طبقه دوم | 5d | 2010-04-23 | 2010-04-27 | 1677SS | 198d |  | 89/2/3 | 89/2/7 |  |  |  |
| 1690 | 3.13.4.4 | نصب پنجره ها و شيشه هاي طبقه سوم | 5d | 2010-05-08 | 2010-05-12 | 1678SS | 183d |  | 89/2/18 | 89/2/22 |  |  |  |
| 1691 | 3.13.4.5 | نصب پنجره ها و شيشه هاي طبقه چهارم | 5d | 2010-05-23 | 2010-05-27 | 1679SS | 168d |  | 89/3/2 | 89/3/6 |  |  |  |
| 1692 | 3.13.4.6 | نصب پنجره ها و شيشه هاي طبقه پنجم | 5d | 2010-06-07 | 2010-06-11 | 1680SS | 153d |  | 89/3/17 | 89/3/21 |  |  |  |
| 1693 | 3.13.4.7 | نصب پنجره ها و شيشه هاي طبقه ششم | 5d | 2010-06-22 | 2010-06-26 | 1681SS | 138d |  | 89/4/1 | 89/4/5 |  |  |  |
| 1694 | 3.13.4.8 | نصب پنجره ها و شيشه هاي طبقه هفتم | 5d | 2010-07-07 | 2010-07-11 | 1682SS | 123d |  | 89/4/16 | 89/4/20 |  |  |  |
| 1695 | 3.13.4.9 | نصب پنجره ها و شيشه هاي طبقه هشتم | 5d | 2010-07-22 | 2010-07-26 | 1683SS | 108d |  | 89/4/31 | 89/5/4 |  |  |  |
| 1696 | 3.13.4.10 | نصب پنجره ها و شيشه هاي طبقه نهم | 5d | 2010-08-06 | 2010-08-10 | 1684SS | 93d |  | 89/5/15 | 89/5/19 |  |  |  |
| 1697 | 3.13.4.11 | نصب پنجره ها و شيشه هاي طبقه دهم | 5d | 2010-08-23 | 2010-08-27 | 1685SS | 76d |  | 89/6/1 | 89/6/5 |  |  |  |
| 1698 | 3.13.5 | نماسازي | 94d | 2009-12-23 | 2010-04-04 | 1476, 1686SF | 222d |  | 88/10/2 | 89/1/15 | 88/05/14 | 88/12/01 | مترمربع |
| 1699 | 3.13.6 | **عايق كاري سرويسها،آشپزخانه ها،بالكن ها و پشت بام** | 146d | 2010-04-24 | 2010-09-16 |  | 0d |  | 89/2/4 | 89/6/25 |  |  |  |
| 1700 | 3.13.6.1 | عايق كاري سرويسها،آشپزخانه هاو،بالكن هاي طبقه همكف | 5d | 2010-04-24 | 2010-04-28 | 1543, 1675 | 0d |  | 89/2/4 | 89/2/8 |  |  | مترمربع |
| 1701 | 3.13.6.2 | عايق كاري سرويسها،آشپزخانه هاو،بالكن هاي طبقه اول | 5d | 2010-05-01 | 2010-05-05 | 1544, 1676 | 44d | 0d | 89/2/11 | 89/2/15 |  |  | مترمربع |
| 1702 | 3.13.6.3 | عايق كاري سرويسها،آشپزخانه هاو،بالكن هاي طبقه دوم | 5d | 2010-05-13 | 2010-05-17 | 1545, 1677 | 42d | 0d | 89/2/23 | 89/2/27 |  |  | مترمربع |
| 1703 | 3.13.6.4 | عايق كاري سرويسها،آشپزخانه هاو،بالكن هاي طبقه سوم | 5d | 2010-05-28 | 2010-06-01 | 1546, 1678 | 37d | 0d | 89/3/7 | 89/3/11 |  |  | مترمربع |
| 1704 | 3.13.6.5 | عايق كاري سرويسها،آشپزخانه هاو،بالكن هاي طبقه چهارم | 5d | 2010-06-12 | 2010-06-16 | 1547, 1679 | 32d | 0d | 89/3/22 | 89/3/26 |  |  | مترمربع |
| 1705 | 3.13.6.6 | عايق كاري سرويسها،آشپزخانه هاو،بالكن هاي طبقه پنجم | 5d | 2010-06-27 | 2010-07-01 | 1548, 1680 | 27d | 0d | 89/4/6 | 89/4/10 |  |  | مترمربع |
| 1706 | 3.13.6.7 | عايق كاري سرويسها،آشپزخانه هاو،بالكن هاي طبقه ششم | 5d | 2010-07-12 | 2010-07-16 | 1549, 1681 | 22d | 0d | 89/4/21 | 89/4/25 |  |  | مترمربع |
| 1707 | 3.13.6.8 | عايق كاري سرويسها،آشپزخانه هاو،بالكن هاي طبقه هفتم | 5d | 2010-07-27 | 2010-07-31 | 1550, 1682 | 17d | 0d | 89/5/5 | 89/5/9 |  |  | مترمربع |
| 1708 | 3.13.6.9 | عايق كاري سرويسها،آشپزخانه هاو،بالكن هاي طبقه هشتم | 5d | 2010-08-11 | 2010-08-15 | 1551, 1683 | 12d | 0d | 89/5/20 | 89/5/24 |  |  | مترمربع |
| 1709 | 3.13.6.10 | عايق كاري سرويسها،آشپزخانه هاو،بالكن هاي طبقه نهم | 5d | 2010-08-26 | 2010-08-30 | 1552, 1684 | 7d | 0d | 89/6/4 | 89/6/8 |  |  | مترمربع |
| 1710 | 3.13.6.11 | عايق كاري سرويسها،آشپزخانه هاو،بالكن هاي طبقه دهم | 5d | 2010-09-12 | 2010-09-16 | 1553, 1685 | 0d |  | 89/6/21 | 89/6/25 |  |  | مترمربع |

| ID | WBS | Task | Duration | Start | Finish | Predecessors | Total slack | Free slack | Plan Start | Plan Finish | واحد | Text1 | Text2 |
| --- | --- | --- | --- | --- | --- | --- | --- | --- | --- | --- | --- | --- | --- |
| 1711 | 3.13.7 | **سراميك كاري سرويسها و آشپزخانه هاوپذيرايي و اتاق خوابها** | 161d | 2010-04-29 | 2010-10-06 |  | 0d |  | 89/2/9 | 89/7/14 |  |  |  |
| 1712 | 3.13.7.1 | سراميك كاري سرويسها و آشپزخانه هاوپذيرايي و اتاق خوابهاي همكف | 20d | 2010-04-29 | 2010-05-18 | 1700 | 0d |  | 89/2/9 | 89/2/28 | مترمربع |  |  |
| 1713 | 3.13.7.2 | سراميك كاري سرويسها و آشپزخانه هاوپذيرايي و اتاق خوابهاي طبقه اول | 20d | 2010-05-06 | 2010-05-25 | 1701 | 44d | 0d | 89/2/16 | 89/3/4 | مترمربع |  |  |
| 1714 | 3.13.7.3 | سراميك كاري سرويسها و آشپزخانه هاوپذيرايي و اتاق خوابهاي طبقه دوم | 20d | 2010-05-18 | 2010-06-06 | 1702 | 42d | 0d | 89/2/28 | 89/3/16 | مترمربع |  |  |
| 1715 | 3.13.7.4 | سراميك كاري سرويسها و آشپزخانه هاوپذيرايي و اتاق خوابهاي طبقه سوم | 20d | 2010-06-02 | 2010-06-21 | 1703 | 37d | 0d | 89/3/12 | 89/3/31 | مترمربع |  |  |
| 1716 | 3.13.7.5 | سراميك كاري سرويسها و آشپزخانه هاوپذيرايي و اتاق خوابهاي طبقه چهارم | 20d | 2010-06-17 | 2010-07-06 | 1704 | 32d | 0d | 89/3/27 | 89/4/15 | مترمربع |  |  |
| 1717 | 3.13.7.6 | سراميك كاري سرويسها و آشپزخانه هاوپذيرايي و اتاق خوابهاي طبقه پنجم | 20d | 2010-07-02 | 2010-07-21 | 1705 | 27d | 0d | 89/4/11 | 89/4/30 | مترمربع |  |  |
| 1718 | 3.13.7.7 | سراميك كاري سرويسها و آشپزخانه هاوپذيرايي و اتاق خوابهاي طبقه ششم | 20d | 2010-07-17 | 2010-08-05 | 1706 | 22d | 0d | 89/4/26 | 89/5/14 | مترمربع |  |  |
| 1719 | 3.13.7.8 | سراميك كاري سرويسها و آشپزخانه هاوپذيرايي و اتاق خوابهاي طبقه هفتم | 20d | 2010-08-01 | 2010-08-20 | 1707 | 17d | 0d | 89/5/10 | 89/5/29 | مترمربع |  |  |
| 1720 | 3.13.7.9 | سراميك كاري سرويسها و آشپزخانه هاوپذيرايي و اتاق خوابهاي طبقه هشتم | 20d | 2010-08-16 | 2010-09-04 | 1708 | 12d | 0d | 89/5/25 | 89/6/13 | مترمربع |  |  |
| 1721 | 3.13.7.10 | سراميك كاري سرويسها و آشپزخانه هاوپذيرايي و اتاق خوابهاي طبقه نهم | 20d | 2010-08-31 | 2010-09-19 | 1709 | 7d | 0d | 89/6/9 | 89/6/28 | مترمربع |  |  |
| 1722 | 3.13.7.11 | سراميك كاري سرويسها و آشپزخانه هاوپذيرايي و اتاق خوابهاي طبقه دهم | 20d | 2010-09-17 | 2010-10-06 | 1710 | 0d |  | 89/6/26 | 89/7/14 | مترمربع |  |  |
| 1723 | 3.13.8 | **كاشيكاري سرويسها و آشپزخانه ها** | 161d | 2010-05-09 | 2010-10-16 |  | 0d |  | 89/2/19 | 89/7/24 |  | 87/12/06 | 88/08/10 |
| 1724 | 3.13.8.1 | كاشيكاري سرويسها و آشپزخانه هاي طبقه همكف | 20d | 2010-05-09 | 2010-05-28 | 1712SS+10d | 0d |  | 89/2/19 | 89/3/7 | مترمربع |  |  |
| 1725 | 3.13.8.2 | كاشيكاري سرويسها و آشپزخانه هاي طبقه اول | 20d | 2010-05-16 | 2010-06-04 | 1713SS+10d | 140d | 0d | 89/2/26 | 89/3/14 | مترمربع | 87/12/06 | 87/12/25 |
| 1726 | 3.13.8.3 | كاشيكاري سرويسها و آشپزخانه هاي طبقه دوم | 20d | 2010-05-28 | 2010-06-16 | 1714SS+10d | 128d | 0d | 89/3/7 | 89/3/26 | مترمربع | 88/01/26 | 88/02/14 |
| 1727 | 3.13.8.4 | كاشيكاري سرويسها و آشپزخانه هاي طبقه سوم | 20d | 2010-06-12 | 2010-07-01 | 1715SS+10d | 113d | 0d | 89/3/22 | 89/4/10 | مترمربع | 88/02/15 | 88/03/03 |
| 1728 | 3.13.8.5 | كاشيكاري سرويسها و آشپزخانه هاي طبقه چهارم | 20d | 2010-06-27 | 2010-07-16 | 1716SS+10d | 98d | 0d | 89/4/6 | 89/4/25 | مترمربع | 88/03/04 | 88/03/23 |
| 1729 | 3.13.8.6 | كاشيكاري سرويسها و آشپزخانه هاي طبقه پنجم | 20d | 2010-07-12 | 2010-07-31 | 1717SS+10d | 83d | 0d | 89/4/21 | 89/5/9 | مترمربع | 88/03/24 | 88/04/12 |
| 1730 | 3.13.8.7 | كاشيكاري سرويسها و آشپزخانه هاي طبقه ششم | 20d | 2010-07-27 | 2010-08-15 | 1718SS+10d | 68d | 0d | 89/5/5 | 89/5/24 | مترمربع | 88/04/13 | 88/05/01 |
| 1731 | 3.13.8.8 | كاشيكاري سرويسها و آشپزخانه هاي طبقه هفتم | 20d | 2010-08-11 | 2010-08-30 | 1719SS+10d | 53d | 0d | 89/5/20 | 89/6/8 | مترمربع | 88/05/02 | 88/05/21 |
| 1732 | 3.13.8.9 | كاشيكاري سرويسها و آشپزخانه هاي طبقه هشتم | 20d | 2010-08-26 | 2010-09-14 | 1720SS+10d | 38d | 0d | 89/6/4 | 89/6/23 | مترمربع | 88/05/22 | 88/06/10 |
| 1733 | 3.13.8.10 | كاشيكاري سرويسها و آشپزخانه هاي طبقه نهم | 20d | 2010-09-10 | 2010-09-29 | 1721SS+10d | 23d | 0d | 89/6/19 | 89/7/7 | مترمربع | 88/06/11 | 88/06/30 |
| 1734 | 3.13.8.11 | كاشيكاري سرويسها و آشپزخانه هاي طبقه دهم | 20d | 2010-09-27 | 2010-10-16 | 1722SS+10d | 4d | 0d | 89/7/5 | 89/7/24 | مترمربع | 88/06/31 | 88/07/19 |

| ID | WBS | Task | Duration | Start | Finish | Predecessors | Total slack | Free slack | Plan Start | Plan Finish | واحد |
| --- | --- | --- | --- | --- | --- | --- | --- | --- | --- | --- | --- |
| 1735 | 3.13.9 | **اجراي سنگ كف و اجراي پله ها** | 187d | 2010-02-14 | 2010-08-27 |  | 66d |  | 88/11/25 | 89/6/5 |  |
| 1736 | 3.13.9.1 | اجراي سنگ كف و اجراي پله هاي طبقه زيرزمين دوم | 5d | 2010-02-14 | 2010-02-18 | 1599, 1642 | 238d | 5d | 88/11/25 | 88/11/29 | مترمربع |
| 1737 | 3.13.9.2 | اجراي سنگ كف و اجراي پله هاي طبقه زيرزمين اول | 5d | 2010-03-01 | 2010-03-05 | 1600, 1643 | 233d | 15d | 88/12/10 | 88/12/14 | مترمربع |
| 1738 | 3.13.9.3 | اجراي سنگ كف و اجراي پله هاي طبقه همكف | 5d | 2010-04-04 | 2010-04-08 | 1675SS | 40d | 15d | 89/1/15 | 89/1/19 | مترمربع |
| 1739 | 3.13.9.4 | اجراي سنگ كف و اجراي پله هاي طبقه اول | 5d | 2010-04-11 | 2010-04-15 | 1676SS | 180d | 15d | 89/1/22 | 89/1/26 | مترمربع |
| 1740 | 3.13.9.5 | اجراي سنگ كف و اجراي پله هاي طبقه دوم | 5d | 2010-04-23 | 2010-04-27 | 1677SS | 168d | 15d | 89/2/3 | 89/2/7 | مترمربع |
| 1741 | 3.13.9.6 | اجراي سنگ كف و اجراي پله هاي طبقه سوم | 5d | 2010-05-08 | 2010-05-12 | 1678SS | 153d | 15d | 89/2/18 | 89/2/22 | مترمربع |
| 1742 | 3.13.9.7 | اجراي سنگ كف و اجراي پله هاي طبقه چهارم | 5d | 2010-05-23 | 2010-05-27 | 1679SS | 138d | 15d | 89/3/2 | 89/3/6 | مترمربع |
| 1743 | 3.13.9.8 | اجراي سنگ كف و اجراي پله هاي طبقه پنجم | 5d | 2010-06-07 | 2010-06-11 | 1680SS | 123d | 15d | 89/3/17 | 89/3/21 | مترمربع |
| 1744 | 3.13.9.9 | اجراي سنگ كف و اجراي پله هاي طبقه ششم | 5d | 2010-06-22 | 2010-06-26 | 1681SS | 108d | 15d | 89/4/1 | 89/4/5 | مترمربع |
| 1745 | 3.13.9.10 | اجراي سنگ كف و اجراي پله هاي طبقه هفتم | 5d | 2010-07-07 | 2010-07-11 | 1682SS | 93d | 15d | 89/4/16 | 89/4/20 | مترمربع |
| 1746 | 3.13.9.11 | اجراي سنگ كف و اجراي پله هاي طبقه هشتم | 5d | 2010-07-22 | 2010-07-26 | 1683SS | 78d | 15d | 89/4/31 | 89/5/4 | مترمربع |
| 1747 | 3.13.9.12 | اجراي سنگ كف و اجراي پله هاي طبقه نهم | 5d | 2010-08-06 | 2010-08-10 | 1684SS | 63d | 15d | 89/5/15 | 89/5/19 | مترمربع |
| 1748 | 3.13.9.13 | اجراي سنگ كف و اجراي پله هاي طبقه دهم | 5d | 2010-08-23 | 2010-08-27 | 1685SS | 44d | 15d | 89/6/1 | 89/6/5 | مترمربع |
| 1749 | 3.13.10 | **اجراي سنگ بدنه در راهروها و راه پله ها** | 202d | 2010-02-24 | 2010-09-21 |  | 51d |  | 88/12/5 | 89/6/30 |  |
| 1750 | 3.13.10.1 | اجراي سنگ بدنه در راهروها و راه پله هاي طبقه زيرزمين دوم | 10d | 2010-02-24 | 2010-03-05 | 1670, 1736 | 233d | 0d | 88/12/5 | 88/12/14 | مترمربع |
| 1751 | 3.13.10.2 | اجراي سنگ بدنه در راهروها و راه پله هاي طبقه زيرزمين اول | 10d | 2010-03-29 | 2010-04-07 | 1542, 1737 | 218d |  | 89/1/9 | 89/1/18 | مترمربع |
| 1752 | 3.13.10.3 | اجراي سنگ بدنه در راهروها و راه پله هاي طبقه همكف | 10d | 2010-04-24 | 2010-05-03 | 1543, 1738 | 25d |  | 89/2/4 | 89/2/13 | مترمربع |
| 1753 | 3.13.10.4 | اجراي سنگ بدنه در راهروها و راه پله هاي طبقه اول | 10d | 2010-05-01 | 2010-05-10 | 1544, 1739 | 165d | 25d | 89/2/11 | 89/2/20 | مترمربع |
| 1754 | 3.13.10.5 | اجراي سنگ بدنه در راهروها و راه پله هاي طبقه دوم | 10d | 2010-05-13 | 2010-05-22 | 1545, 1740 | 153d | 25d | 89/2/23 | 89/3/1 | مترمربع |
| 1755 | 3.13.10.6 | اجراي سنگ بدنه در راهروها و راه پله هاي طبقه سوم | 10d | 2010-05-28 | 2010-06-06 | 1546, 1741 | 138d | 25d | 89/3/7 | 89/3/16 | مترمربع |
| 1756 | 3.13.10.7 | اجراي سنگ بدنه در راهروها و راه پله هاي طبقه چهارم | 10d | 2010-06-12 | 2010-06-21 | 1547, 1742 | 123d | 25d | 89/3/22 | 89/3/31 | مترمربع |
| 1757 | 3.13.10.8 | اجراي سنگ بدنه در راهروها و راه پله هاي طبقه پنجم | 10d | 2010-06-27 | 2010-07-06 | 1548, 1743 | 108d | 25d | 89/4/6 | 89/4/15 | مترمربع |
| 1758 | 3.13.10.9 | اجراي سنگ بدنه در راهروها و راه پله هاي طبقه ششم | 10d | 2010-07-12 | 2010-07-21 | 1549, 1744 | 93d | 25d | 89/4/21 | 89/4/30 | مترمربع |
| 1759 | 3.13.10.10 | اجراي سنگ بدنه در راهروها و راه پله هاي طبقه هفتم | 10d | 2010-07-27 | 2010-08-05 | 1550, 1745 | 78d | 25d | 89/5/5 | 89/5/14 | مترمربع |
| 1760 | 3.13.10.11 | اجراي سنگ بدنه در راهروها و راه پله هاي طبقه هشتم | 10d | 2010-08-11 | 2010-08-20 | 1551, 1746 | 63d | 25d | 89/5/20 | 89/5/29 | مترمربع |
| 1761 | 3.13.10.12 | اجراي سنگ بدنه در راهروها و راه پله هاي طبقه نهم | 10d | 2010-08-26 | 2010-09-04 | 1552, 1747 | 48d | 25d | 89/6/4 | 89/6/13 | مترمربع |
| 1762 | 3.13.10.13 | اجراي سنگ بدنه در راهروها و راه پله هاي طبقه دهم | 10d | 2010-09-12 | 2010-09-21 | 1553, 1748 | 29d | 25d | 89/6/21 | 89/6/30 | مترمربع |

| ID | WBS | Task | Duration | Start | Finish | Predecessors | Total slack | Free slack | Plan Start | Plan Finish | واحد |
| --- | --- | --- | --- | --- | --- | --- | --- | --- | --- | --- | --- |
| 1763 | 3.13.11 | **اجراي موزاييك و قرنيز ديوارها** | 151d | 2010-04-24 | 2010-09-21 |  | 25d |  | 89/2/4 | 89/6/30 |  |
| 1764 | 3.13.11.1 | اجراي موزاييك و قرنيز ديوارها طبقه همكف | 10d | 2010-04-24 | 2010-05-03 | 1543, 1738 | 25d |  | 89/2/4 | 89/2/13 | مترمربع |
| 1765 | 3.13.11.2 | اجراي موزاييك و قرنيز ديوارهاي طبقه اول | 10d | 2010-05-01 | 2010-05-10 | 1544, 1739 | 165d | 25d | 89/2/11 | 89/2/20 | مترمربع |
| 1766 | 3.13.11.3 | اجراي موزاييك و قرنيز ديوارهاي طبقه دوم | 10d | 2010-05-13 | 2010-05-22 | 1545, 1740 | 153d | 25d | 89/2/23 | 89/3/1 | مترمربع |
| 1767 | 3.13.11.4 | اجراي موزاييك و قرنيز ديوارهاي طبقه سوم | 10d | 2010-05-28 | 2010-06-06 | 1546, 1741 | 138d | 25d | 89/3/7 | 89/3/16 | مترمربع |
| 1768 | 3.13.11.5 | اجراي موزاييك و قرنيز ديوارهاي طبقه چهارم | 10d | 2010-06-12 | 2010-06-21 | 1547, 1742 | 123d | 25d | 89/3/22 | 89/3/31 | مترمربع |
| 1769 | 3.13.11.6 | اجراي موزاييك و قرنيز ديوارهاي طبقه پنجم | 10d | 2010-06-27 | 2010-07-06 | 1548, 1743 | 108d | 25d | 89/4/6 | 89/4/15 | مترمربع |
| 1770 | 3.13.11.7 | اجراي موزاييك و قرنيز ديوارهاي طبقه ششم | 10d | 2010-07-12 | 2010-07-21 | 1549, 1744 | 93d | 25d | 89/4/21 | 89/4/30 | مترمربع |
| 1771 | 3.13.11.8 | اجراي موزاييك و قرنيز ديوارهاي طبقه هفتم | 10d | 2010-07-27 | 2010-08-05 | 1550, 1745 | 78d | 25d | 89/5/5 | 89/5/14 | مترمربع |
| 1772 | 3.13.11.9 | اجراي موزاييك و قرنيز ديوارهاي طبقه هشتم | 10d | 2010-08-11 | 2010-08-20 | 1551, 1746 | 63d | 25d | 89/5/20 | 89/5/29 | مترمربع |
| 1773 | 3.13.11.10 | اجراي موزاييك و قرنيز ديوارهاي طبقه نهم | 10d | 2010-08-26 | 2010-09-04 | 1552, 1747 | 48d | 25d | 89/6/4 | 89/6/13 | مترمربع |
| 1774 | 3.13.11.11 | اجراي موزاييك و قرنيز ديوارهاي طبقه دهم | 10d | 2010-09-12 | 2010-09-21 | 1553, 1748 | 29d | 25d | 89/6/21 | 89/6/30 | مترمربع |
| 1775 | 3.13.12 | **اجراي كارهاي چوبي درهاي ورودي وادها،اتاق خوابها و …** | 110d | 2010-06-28 | 2010-10-15 |  | 1d |  | 89/4/7 | 89/7/23 |  |
| 1776 | 3.13.12.1 | اجراي كارهاي چوبي درهاي ورودي وادها،اتاق خوابهاي طبقه همكف | 10d | 2010-06-28 | 2010-07-07 | 1800 | 99d | 0d | 89/4/7 | 89/4/16 |  |
| 1777 | 3.13.12.2 | اجراي كارهاي چوبي درهاي ورودي وادها،اتاق خوابهاي طبقه اول | 10d | 2010-07-08 | 2010-07-17 | 1801 | 89d | 0d | 89/4/17 | 89/4/26 |  |
| 1778 | 3.13.12.3 | اجراي كارهاي چوبي درهاي ورودي وادها،اتاق خوابهاي طبقه دوم | 10d | 2010-07-18 | 2010-07-27 | 1802 | 79d | 0d | 89/4/27 | 89/5/5 |  |
| 1779 | 3.13.12.4 | اجراي كارهاي چوبي درهاي ورودي وادها،اتاق خوابهاي طبقه سوم | 10d | 2010-07-28 | 2010-08-06 | 1803 | 69d | 0d | 89/5/6 | 89/5/15 |  |
| 1780 | 3.13.12.5 | اجراي كارهاي چوبي درهاي ورودي وادها،اتاق خوابهاي طبقه چهارم | 10d | 2010-08-07 | 2010-08-16 | 1804 | 59d | 0d | 89/5/16 | 89/5/25 |  |
| 1781 | 3.13.12.6 | اجراي كارهاي چوبي درهاي ورودي وادها،اتاق خوابهاي طبقه پنجم | 10d | 2010-08-17 | 2010-08-26 | 1805 | 49d | 0d | 89/5/26 | 89/6/4 |  |
| 1782 | 3.13.12.7 | اجراي كارهاي چوبي درهاي ورودي وادها،اتاق خوابهاي طبقه ششم | 10d | 2010-08-27 | 2010-09-05 | 1806 | 39d | 0d | 89/6/5 | 89/6/14 |  |
| 1783 | 3.13.12.8 | اجراي كارهاي چوبي درهاي ورودي وادها،اتاق خوابهاي طبقه هفتم | 10d | 2010-09-06 | 2010-09-15 | 1807 | 29d | 0d | 89/6/15 | 89/6/24 |  |
| 1784 | 3.13.12.9 | اجراي كارهاي چوبي درهاي ورودي وادها،اتاق خوابهاي طبقه هشتم | 10d | 2010-09-16 | 2010-09-25 | 1808 | 19d | 0d | 89/6/25 | 89/7/3 |  |
| 1785 | 3.13.12.10 | اجراي كارهاي چوبي درهاي ورودي وادها،اتاق خوابهاي طبقه نهم | 10d | 2010-09-26 | 2010-10-05 | 1809 | 9d | 0d | 89/7/4 | 89/7/13 |  |
| 1786 | 3.13.12.11 | اجراي كارهاي چوبي درهاي ورودي وادها،اتاق خوابهاي طبقه دهم | 10d | 2010-10-06 | 2010-10-15 | 1810 | 1d |  | 89/7/14 | 89/7/23 |  |

| ID | WBS | Task | Duration | Start | Finish | Predecessors | Total slack | Text1 | Text2 | واحد | Plan Start | Plan Finish |
| --- | --- | --- | --- | --- | --- | --- | --- | --- | --- | --- | --- | --- |
| 1787 | 3.13.13 | **اجراي سقف كاذب سرويسهاي طبقات** | 156d | 2010-05-29 | 2010-10-31 |  | 11d | 88/02/15 | 88/09/19 | درصد | 89/3/8 | 89/8/9 |
| 1788 | 3.13.13.1 | اجراي سقف كاذب سرويسهاي طبقه همكف | 15d | 2010-05-29 | 2010-06-12 | 1724 | 152d | 88/02/15 | 88/03/03 | مترمربع | 89/3/8 | 89/3/22 |
| 1789 | 3.13.13.2 | اجراي سقف كاذب سرويسهاي طبقه اول | 15d | 2010-06-05 | 2010-06-19 | 1725 | 145d | 88/03/04 | 88/03/23 | مترمربع | 89/3/15 | 89/3/29 |
| 1790 | 3.13.13.3 | اجراي سقف كاذب سرويسهاي طبقه دوم | 15d | 2010-06-17 | 2010-07-01 | 1726 | 133d | 88/03/24 | 88/04/12 | مترمربع | 89/3/27 | 89/4/10 |
| 1791 | 3.13.13.4 | اجراي سقف كاذب سرويسهاي طبقه سوم | 15d | 2010-07-02 | 2010-07-16 | 1727 | 118d | 88/04/13 | 88/05/01 | مترمربع | 89/4/11 | 89/4/25 |
| 1792 | 3.13.13.5 | اجراي سقف كاذب سرويسهاي طبقه چهارم | 15d | 2010-07-17 | 2010-07-31 | 1728 | 103d | 88/05/02 | 88/05/21 | مترمربع | 89/4/26 | 89/5/9 |
| 1793 | 3.13.13.6 | اجراي سقف كاذب سرويسهاي طبقه پنجم | 15d | 2010-08-01 | 2010-08-15 | 1729 | 88d | 88/05/22 | 88/06/10 | مترمربع | 89/5/10 | 89/5/24 |
| 1794 | 3.13.13.7 | اجراي سقف كاذب سرويسهاي طبقه ششم | 15d | 2010-08-16 | 2010-08-30 | 1730 | 73d | 88/06/11 | 88/06/30 | مترمربع | 89/5/25 | 89/6/8 |
| 1795 | 3.13.13.8 | اجراي سقف كاذب سرويسهاي طبقه هفتم | 15d | 2010-08-31 | 2010-09-14 | 1731 | 58d | 88/06/31 | 88/07/19 | مترمربع | 89/6/9 | 89/6/23 |
| 1796 | 3.13.13.9 | اجراي سقف كاذب سرويسهاي طبقه هشتم | 15d | 2010-09-15 | 2010-09-29 | 1732 | 43d | 88/07/20 | 88/08/09 | مترمربع | 89/6/24 | 89/7/7 |
| 1797 | 3.13.13.10 | اجراي سقف كاذب سرويسهاي طبقه نهم | 15d | 2010-09-30 | 2010-10-14 | 1733 | 28d | 88/08/10 | 88/08/29 | مترمربع | 89/7/8 | 89/7/22 |
| 1798 | 3.13.13.11 | اجراي سقف كاذب سرويسهاي طبقه دهم | 15d | 2010-10-17 | 2010-10-31 | 1734 | 11d | 88/08/30 | 88/09/19 | مترمربع | 89/7/25 | 89/8/9 |
| 1799 | 3.13.14 | **اجراي سفيدكاري** | 110d | 2010-06-18 | 2010-10-05 |  | 0d | 87/12/26 | 88/10/09 | درصد | 89/3/28 | 89/7/13 |
| 1800 | 3.13.14.1 | اجراي سفيدکاري همکف | 10d | 2010-06-18 | 2010-06-27 | 1517, 1529 | 0d | 88/03/04 | 88/03/23 | مترمربع | 89/3/28 | 89/4/6 |
| 1801 | 3.13.14.2 | اجراي سفيدكاري طبقه 1 | 10d | 2010-06-28 | 2010-07-07 | 1800 | 0d | 88/03/24 | 88/04/12 | مترمربع | 89/4/7 | 89/4/16 |
| 1802 | 3.13.14.3 | اجراي سفيدكاري طبقه 2 | 10d | 2010-07-08 | 2010-07-17 | 1801 | 0d | 88/04/13 | 88/05/01 | مترمربع | 89/4/17 | 89/4/26 |
| 1803 | 3.13.14.4 | اجراي سفيدكاري طبقه 3 | 10d | 2010-07-18 | 2010-07-27 | 1802 | 0d | 88/05/02 | 88/05/21 | مترمربع | 89/4/27 | 89/5/5 |
| 1804 | 3.13.14.5 | اجراي سفيدكاري طبقه 4 | 10d | 2010-07-28 | 2010-08-06 | 1803 | 0d | 88/05/22 | 88/06/10 | مترمربع | 89/5/6 | 89/5/15 |
| 1805 | 3.13.14.6 | اجراي سفيدكاري طبقه 5 | 10d | 2010-08-07 | 2010-08-16 | 1804 | 0d | 88/06/11 | 88/06/30 | مترمربع | 89/5/16 | 89/5/25 |
| 1806 | 3.13.14.7 | اجراي سفيدكاري طبقه 6 | 10d | 2010-08-17 | 2010-08-26 | 1805 | 0d | 88/06/31 | 88/07/19 | مترمربع | 89/5/26 | 89/6/4 |
| 1807 | 3.13.14.8 | اجراي سفيدكاري طبقه 7 | 10d | 2010-08-27 | 2010-09-05 | 1806 | 0d | 88/07/20 | 88/08/09 | مترمربع | 89/6/5 | 89/6/14 |
| 1808 | 3.13.14.9 | اجراي سفيدكاري طبقه 8 | 10d | 2010-09-06 | 2010-09-15 | 1807 | 0d | 88/08/10 | 88/08/29 | مترمربع | 89/6/15 | 89/6/24 |
| 1809 | 3.13.14.10 | اجراي سفيدكاري طبقه 9 | 10d | 2010-09-16 | 2010-09-25 | 1808 | 0d | 88/08/30 | 88/09/19 | مترمربع | 89/6/25 | 89/7/3 |
| 1810 | 3.13.14.11 | اجراي سفيدكاري طبقه 10 وخرپشته | 10d | 2010-09-26 | 2010-10-05 | 1809 | 0d | 88/09/20 | 88/10/09 | مترمربع | 89/7/4 | 89/7/13 |

| ID | WBS | Task | Duration | Start | Finish | Predecessors | Total slack | Free slack | Plan Start | Plan Finish |
| --- | --- | --- | --- | --- | --- | --- | --- | --- | --- | --- |
| 1811 | 3.13.15 | **نصب دربهاي اصلي ساختمان** | 105d | 2010-06-28 | 2010-10-10 |  | 4d |  | 89/4/7 | 89/7/18 |
| 1812 | 3.13.15.1 | نصب دربهاي اصلي ساختمان طبقه همكف | 5d | 2010-06-28 | 2010-07-02 | 1800 | 104d | 5d | 89/4/7 | 89/4/11 |
| 1813 | 3.13.15.2 | نصب دربهاي اصلي طبقه اول | 5d | 2010-07-08 | 2010-07-12 | 1801 | 94d | 5d | 89/4/17 | 89/4/21 |
| 1814 | 3.13.15.3 | نصب دربهاي اصلي طبقه دوم | 5d | 2010-07-18 | 2010-07-22 | 1802 | 84d | 5d | 89/4/27 | 89/4/31 |
| 1815 | 3.13.15.4 | نصب دربهاي اصلي طبقه سوم | 5d | 2010-07-28 | 2010-08-01 | 1803 | 74d | 5d | 89/5/6 | 89/5/10 |
| 1816 | 3.13.15.5 | نصب دربهاي اصلي طبقه چهارم | 5d | 2010-08-07 | 2010-08-11 | 1804 | 64d | 5d | 89/5/16 | 89/5/20 |
| 1817 | 3.13.15.6 | نصب دربهاي اصلي طبقه پنجم | 5d | 2010-08-17 | 2010-08-21 | 1805 | 54d | 5d | 89/5/26 | 89/5/30 |
| 1818 | 3.13.15.7 | نصب دربهاي اصلي طبقه ششم | 5d | 2010-08-27 | 2010-08-31 | 1806 | 44d | 5d | 89/6/5 | 89/6/9 |
| 1819 | 3.13.15.8 | نصب دربهاي اصلي طبقه هفتم | 5d | 2010-09-06 | 2010-09-10 | 1807 | 34d | 5d | 89/6/15 | 89/6/19 |
| 1820 | 3.13.15.9 | نصب دربهاي اصلي طبقه هشتم | 5d | 2010-09-16 | 2010-09-20 | 1808 | 24d | 5d | 89/6/25 | 89/6/29 |
| 1821 | 3.13.15.10 | نصب دربهاي اصلي طبقه نهم | 5d | 2010-09-26 | 2010-09-30 | 1809 | 14d | 5d | 89/7/4 | 89/7/8 |
| 1822 | 3.13.15.11 | نصب دربهاي اصلي طبقه دهم | 5d | 2010-10-06 | 2010-10-10 | 1810 | 0d |  | 89/7/14 | 89/7/18 |
| 1823 | 3.13.16 | **نصب كابينت طبقات** | 110d | 2010-06-28 | 2010-10-15 |  | 1d |  | 89/4/7 | 89/7/23 |
| 1824 | 3.13.16.1 | نصب كابينت طبقه همكف | 10d | 2010-06-28 | 2010-07-07 | 1800 | 99d | 0d | 89/4/7 | 89/4/16 |
| 1825 | 3.13.16.2 | نصب كابينت طبقه اول | 10d | 2010-07-08 | 2010-07-17 | 1801 | 89d | 0d | 89/4/17 | 89/4/26 |
| 1826 | 3.13.16.3 | نصب كابينت طبقه دوم | 10d | 2010-07-18 | 2010-07-27 | 1802 | 79d | 0d | 89/4/27 | 89/5/5 |
| 1827 | 3.13.16.4 | نصب كابينت طبقه سوم | 10d | 2010-07-28 | 2010-08-06 | 1803 | 69d | 0d | 89/5/6 | 89/5/15 |
| 1828 | 3.13.16.5 | نصب كابينت طبقه چهارم | 10d | 2010-08-07 | 2010-08-16 | 1804 | 59d | 0d | 89/5/16 | 89/5/25 |
| 1829 | 3.13.16.6 | نصب كابينت طبقه پنجم | 10d | 2010-08-17 | 2010-08-26 | 1805 | 49d | 0d | 89/5/26 | 89/6/4 |
| 1830 | 3.13.16.7 | نصب كابينت طبقه ششم | 10d | 2010-08-27 | 2010-09-05 | 1806 | 39d | 0d | 89/6/5 | 89/6/14 |
| 1831 | 3.13.16.8 | نصب كابينت طبقه هفتم | 10d | 2010-09-06 | 2010-09-15 | 1807 | 29d | 0d | 89/6/15 | 89/6/24 |
| 1832 | 3.13.16.9 | نصب كابينت طبقه هشتم | 10d | 2010-09-16 | 2010-09-25 | 1808 | 19d | 0d | 89/6/25 | 89/7/3 |
| 1833 | 3.13.16.10 | نصب كابينت طبقه نهم | 10d | 2010-09-26 | 2010-10-05 | 1809 | 9d | 0d | 89/7/4 | 89/7/13 |
| 1834 | 3.13.16.11 | نصب كابينت طبقه دهم | 10d | 2010-10-06 | 2010-10-15 | 1810 | 1d |  | 89/7/14 | 89/7/23 |

| ID | WBS | Task | Duration | Start | Finish | Predecessors | Total slack | Free slack | Plan Start | Plan Finish | Text1 | Text2 | واحد |
| --- | --- | --- | --- | --- | --- | --- | --- | --- | --- | --- | --- | --- | --- |
| 1835 | 3.13.17 | **نصب نرده طبقات** | 105d | 2010-06-28 | 2010-10-10 |  | 6d |  | 89/4/7 | 89/7/18 |  |  |  |
| 1836 | 3.13.17.1 | نصب نرده طبقه همكف | 5d | 2010-06-28 | 2010-07-02 | 1800 | 104d | 5d | 89/4/7 | 89/4/11 |  |  |  |
| 1837 | 3.13.17.2 | نصب نرده طبقه اول | 5d | 2010-07-08 | 2010-07-12 | 1801 | 94d | 5d | 89/4/17 | 89/4/21 |  |  |  |
| 1838 | 3.13.17.3 | نصب نرده طبقه دوم | 5d | 2010-07-18 | 2010-07-22 | 1802 | 84d | 5d | 89/4/27 | 89/4/31 |  |  |  |
| 1839 | 3.13.17.4 | نصب نرده طبقه سوم | 5d | 2010-07-28 | 2010-08-01 | 1803 | 74d | 5d | 89/5/6 | 89/5/10 |  |  |  |
| 1840 | 3.13.17.5 | نصب نرده طبقه چهارم | 5d | 2010-08-07 | 2010-08-11 | 1804 | 64d | 5d | 89/5/16 | 89/5/20 |  |  |  |
| 1841 | 3.13.17.6 | نصب نرده طبقه پنجم | 5d | 2010-08-17 | 2010-08-21 | 1805 | 54d | 5d | 89/5/26 | 89/5/30 |  |  |  |
| 1842 | 3.13.17.7 | نصب نرده طبقه ششم | 5d | 2010-08-27 | 2010-08-31 | 1806 | 44d | 5d | 89/6/5 | 89/6/9 |  |  |  |
| 1843 | 3.13.17.8 | نصب نرده طبقه هفتم | 5d | 2010-09-06 | 2010-09-10 | 1807 | 34d | 5d | 89/6/15 | 89/6/19 |  |  |  |
| 1844 | 3.13.17.9 | نصب نرده طبقه هشتم | 5d | 2010-09-16 | 2010-09-20 | 1808 | 24d | 5d | 89/6/25 | 89/6/29 |  |  |  |
| 1845 | 3.13.17.10 | نصب نرده طبقه نهم | 5d | 2010-09-26 | 2010-09-30 | 1809 | 14d | 5d | 89/7/4 | 89/7/8 |  |  |  |
| 1846 | 3.13.17.11 | نصب نرده طبقه دهم | 5d | 2010-10-06 | 2010-10-10 | 1810 | 6d |  | 89/7/14 | 89/7/18 |  |  |  |
| 1847 | 3.13.18 | **نقاشي** | 119d | 2010-07-08 | 2010-11-03 |  | 0d |  | 89/4/17 | 89/8/12 | 88/02/05 | 88/11/14 | درصد |
| 1848 | 3.13.18.1 | نقاشي طبفه همكف | 18d | 2010-07-08 | 2010-07-25 | 1776, 1812, 1824, 1836, 1862, 1901 | 99d | 0d | 89/4/17 | 89/5/3 | 88/04/03 | 88/04/22 | مترمربع |
| 1849 | 3.13.18.2 | نقاشي طبقه 1 | 18d | 2010-07-18 | 2010-08-04 | 1777, 1813, 1825, 1837, 1863, 1902 | 89d | 0d | 89/4/27 | 89/5/13 | 88/04/23 | 88/05/11 | مترمربع |
| 1850 | 3.13.18.3 | نقاشي طبقه 2 | 18d | 2010-07-28 | 2010-08-14 | 1778, 1814, 1826, 1838, 1903, 1863 | 79d | 0d | 89/5/6 | 89/5/23 | 88/05/12 | 88/05/31 | مترمربع |
| 1851 | 3.13.18.4 | نقاشي طبقه 3 | 18d | 2010-08-07 | 2010-08-24 | 1779, 1815, 1827, 1839, 1904, 1864 | 69d | 0d | 89/5/16 | 89/6/2 | 88/06/01 | 88/06/20 | مترمربع |
| 1852 | 3.13.18.5 | نقاشي طبقه 4 | 18d | 2010-08-17 | 2010-09-03 | 1780, 1816, 1828, 1840, 1905, 1865 | 59d | 0d | 89/5/26 | 89/6/12 | 88/06/21 | 88/07/09 | مترمربع |
| 1853 | 3.13.18.6 | نقاشي طبقه 5 | 18d | 2010-08-27 | 2010-09-13 | 1781, 1817, 1829, 1841, 1906, 1866 | 49d | 0d | 89/6/5 | 89/6/22 | 88/07/10 | 88/07/29 | مترمربع |
| 1854 | 3.13.18.7 | نقاشي طبقه 6 | 18d | 2010-09-06 | 2010-09-23 | 1782, 1818, 1830, 1842, 1867, 1907 | 39d | 0d | 89/6/15 | 89/7/1 | 88/07/30 | 88/08/19 | مترمربع |
| 1855 | 3.13.18.8 | نقاشي طبقه 7 | 18d | 2010-09-16 | 2010-10-03 | 1783, 1819, 1831, 1843, 1868, 1908 | 29d | 0d | 89/6/25 | 89/7/11 | 88/08/20 | 88/09/09 | مترمربع |
| 1856 | 3.13.18.9 | نقاشي طبقه 8 | 18d | 2010-09-26 | 2010-10-13 | 1784, 1820, 1832, 1844, 1869, 1909 | 19d | 0d | 89/7/4 | 89/7/21 | 88/09/10 | 88/09/29 | مترمربع |
| 1857 | 3.13.18.10 | نقاشي طبقه 9 | 18d | 2010-10-06 | 2010-10-23 | 1785, 1821, 1833, 1845, 1870, 1910 | 9d | 0d | 89/7/14 | 89/8/1 | 88/09/30 | 88/10/19 | مترمربع |
| 1858 | 3.13.18.11 | نقاشي طبقه 10 | 18d | 2010-10-17 | 2010-11-03 | 1786, 1822, 1834, 1846, 1871, 1911 | 0d |  | 89/7/25 | 89/8/12 | 88/10/25 | 88/11/14 | مترمربع |

| ID | WBS | Task | Duration | Start | Finish | Predecessors | Total slack | Free slack | Plan Start | Plan Finish | Text1 | Text2 | واحد |
| --- | --- | --- | --- | --- | --- | --- | --- | --- | --- | --- | --- | --- | --- |
| 1859 | 3.14 | **فاز دوم تاسيسات مكانيكي** | 243d | 2010-03-06 | 2010-11-11 |  | 0d |  | 88/12/15 | 89/8/20 |  |  |  |
| 1860 | 3.14.1 | نصب سيستم آتشنشاني در موتورخانه | 10d | 2010-03-06 | 2010-03-15 | 1750 | 233d |  | 88/12/15 | 88/12/24 |  |  |  |
| 1861 | 3.14.2 | **اجراي لوله گاز** | 110d | 2010-06-20 | 2010-10-07 |  | 19d |  | 89/3/30 | 89/7/15 | 87/12/26 | 88/08/19 | درصد |
| 1862 | 3.14.2.1 | لوله كشي گاز طبقه همکف | 10d | 2010-06-20 | 2010-06-29 | 1800SS+2d | 19d | 0d | 89/3/30 | 89/4/8 | 88/01/16 | 88/02/04 | درصد |
| 1863 | 3.14.2.2 | لوله كشي گاز طبقه اول | 10d | 2010-06-30 | 2010-07-09 | 1801SS+2d, 1862 | 19d | 0d | 89/4/9 | 89/4/18 | 88/02/05 | 88/02/24 | درصد |
| 1864 | 3.14.2.3 | لوله كشي گاز طبقه دوم | 10d | 2010-07-10 | 2010-07-19 | 1802SS+2d, 1863 | 19d | 0d | 89/4/19 | 89/4/28 | 88/02/25 | 88/03/13 | درصد |
| 1865 | 3.14.2.4 | لوله كشي گاز طبقه سوم | 10d | 2010-07-20 | 2010-07-29 | 1803SS+2d, 1864 | 19d | 0d | 89/4/29 | 89/5/7 | 88/03/14 | 88/04/02 | درصد |
| 1866 | 3.14.2.5 | لوله كشي گاز طبقه چهارم | 10d | 2010-07-30 | 2010-08-08 | 1804SS+2d, 1865 | 19d | 0d | 89/5/8 | 89/5/17 | 88/04/03 | 88/04/22 | درصد |
| 1867 | 3.14.2.6 | لوله كشي گاز طبقه پنجم | 10d | 2010-08-09 | 2010-08-18 | 1805SS+2d, 1866 | 19d | 0d | 89/5/18 | 89/5/27 | 88/04/23 | 88/05/11 | درصد |
| 1868 | 3.14.2.7 | لوله كشي گاز طبقه ششم | 10d | 2010-08-19 | 2010-08-28 | 1806SS+2d, 1867 | 19d | 0d | 89/5/28 | 89/6/6 | 88/05/12 | 88/05/31 | درصد |
| 1869 | 3.14.2.8 | لوله كشي گاز طبقه هفتم | 10d | 2010-08-29 | 2010-09-07 | 1807SS+2d, 1868 | 19d | 0d | 89/6/7 | 89/6/16 | 88/06/01 | 88/06/20 | درصد |
| 1870 | 3.14.2.9 | لوله كشي گاز طبقه هشتم | 10d | 2010-09-08 | 2010-09-17 | 1808SS+2d, 1869 | 19d | 0d | 89/6/17 | 89/6/26 | 88/06/21 | 88/07/09 | درصد |
| 1871 | 3.14.2.10 | لوله كشي گاز طبقه نهم | 10d | 2010-09-18 | 2010-09-27 | 1809SS+2d, 1870 | 19d | 0d | 89/6/27 | 89/7/5 | 88/07/10 | 88/07/29 | درصد |
| 1872 | 3.14.2.11 | لوله كشي گاز طبقه 10 و بام | 10d | 2010-09-28 | 2010-10-07 | 1810SS+2d, 1871 | 35d |  | 89/7/6 | 89/7/15 | 88/07/30 | 88/08/19 | درصد |
| 1873 | 3.14.3 | **نصب شيرآلات و رادياتورهاي طبقات** | 109d | 2010-07-26 | 2010-11-11 |  | 0d |  | 89/5/4 | 89/8/20 |  |  |  |
| 1874 | 3.14.3.1 | نصب شيرآلات و رادياتورهاي طبقه همكف | 8d | 2010-07-26 | 2010-08-02 | 1848 | 101d |  | 89/5/4 | 89/5/11 |  |  |  |
| 1875 | 3.14.3.2 | نصب شيرآلات و رادياتورهاي طبقه اول | 8d | 2010-08-05 | 2010-08-12 | 1849 | 91d |  | 89/5/14 | 89/5/21 |  |  |  |
| 1876 | 3.14.3.3 | نصب شيرآلات و رادياتورهاي طبقه دوم | 8d | 2010-08-15 | 2010-08-22 | 1850 | 81d |  | 89/5/24 | 89/5/31 |  |  |  |
| 1877 | 3.14.3.4 | نصب شيرآلات و رادياتورهاي طبقه سوم | 8d | 2010-08-25 | 2010-09-01 | 1851 | 71d |  | 89/6/3 | 89/6/10 |  |  |  |
| 1878 | 3.14.3.5 | نصب شيرآلات و رادياتورهاي طبقه چهارم | 8d | 2010-09-04 | 2010-09-11 | 1852 | 61d |  | 89/6/13 | 89/6/20 |  |  |  |
| 1879 | 3.14.3.6 | نصب شيرآلات و رادياتورهاي طبقه پنجم | 8d | 2010-09-14 | 2010-09-21 | 1853 | 51d |  | 89/6/23 | 89/6/30 |  |  |  |
| 1880 | 3.14.3.7 | نصب شيرآلات و رادياتورهاي طبقه ششم | 8d | 2010-09-24 | 2010-10-01 | 1854 | 41d |  | 89/7/2 | 89/7/9 |  |  |  |
| 1881 | 3.14.3.8 | نصب شيرآلات و رادياتورهاي طبقه هفتم | 8d | 2010-10-04 | 2010-10-11 | 1855 | 31d |  | 89/7/12 | 89/7/19 |  |  |  |
| 1882 | 3.14.3.9 | نصب شيرآلات و رادياتورهاي طبقه هشتم | 8d | 2010-10-14 | 2010-10-21 | 1856 | 21d |  | 89/7/22 | 89/7/29 |  |  |  |
| 1883 | 3.14.3.10 | نصب شيرآلات و رادياتورهاي طبقه نهم | 8d | 2010-10-24 | 2010-10-31 | 1857 | 11d |  | 89/8/2 | 89/8/9 |  |  |  |
| 1884 | 3.14.3.11 | نصب شيرآلات و رادياتورهاي طبقه دهم | 8d | 2010-11-04 | 2010-11-11 | 1858 | 0d |  | 89/8/13 | 89/8/20 |  |  |  |

| ID | WBS | Task | Duration | Start | Finish | Predecessors | Total slack | Free slack | Plan Start | Plan Finish |
| --- | --- | --- | --- | --- | --- | --- | --- | --- | --- | --- |
| 1885 | 3.14.4 | **نصب پكيج هاي طبقات** | 109d | 2010-07-26 | 2010-11-11 |  | 0d |  | 89/5/4 | 89/8/20 |
| 1886 | 3.14.4.1 | نصب پكيج هاي طبقه همكف | 10d | 2010-07-26 | 2010-08-04 | 1848 | 99d |  | 89/5/4 | 89/5/13 |
| 1887 | 3.14.4.2 | نصب پكيج هاي طبقه اول | 10d | 2010-08-05 | 2010-08-14 | 1849 | 89d |  | 89/5/14 | 89/5/23 |
| 1888 | 3.14.4.3 | نصب پكيج هاي طبقه دوم | 10d | 2010-08-15 | 2010-08-24 | 1850 | 79d |  | 89/5/24 | 89/6/2 |
| 1889 | 3.14.4.4 | نصب پكيج هاي طبقه سوم | 10d | 2010-08-25 | 2010-09-03 | 1851 | 69d |  | 89/6/3 | 89/6/12 |
| 1890 | 3.14.4.5 | نصب پكيج هاي طبقه چهارم | 10d | 2010-09-04 | 2010-09-13 | 1852 | 59d |  | 89/6/13 | 89/6/22 |
| 1891 | 3.14.4.6 | نصب پكيج هاي طبقه پنجم | 10d | 2010-09-14 | 2010-09-23 | 1853 | 49d |  | 89/6/23 | 89/7/1 |
| 1892 | 3.14.4.7 | نصب پكيج هاي طبقه ششم | 10d | 2010-09-24 | 2010-10-03 | 1854 | 39d |  | 89/7/2 | 89/7/11 |
| 1893 | 3.14.4.8 | نصب پكيج هاي طبقه هفتم | 10d | 2010-10-04 | 2010-10-13 | 1855 | 29d |  | 89/7/12 | 89/7/21 |
| 1894 | 3.14.4.9 | نصب پكيج هاي طبقه هشتم | 10d | 2010-10-14 | 2010-10-23 | 1856 | 19d |  | 89/7/22 | 89/8/1 |
| 1895 | 3.14.4.10 | نصب پكيج هاي طبقه نهم | 10d | 2010-10-24 | 2010-11-02 | 1857 | 9d |  | 89/8/2 | 89/8/11 |
| 1896 | 3.14.4.11 | نصب پكيج هاي طبقه دهم | 8d | 2010-11-04 | 2010-11-11 | 1858 | 0d |  | 89/8/13 | 89/8/20 |
| 1897 | 3.15 | **فاز دوم تاسيسات برقي** | 177d | 2010-05-19 | 2010-11-11 |  | 0d |  | 89/2/29 | 89/8/20 |
| 1898 | 3.15.1 | **سيم كشي طبقات** | 171d | 2010-05-19 | 2010-11-05 |  | 0d |  | 89/2/29 | 89/8/14 |
| 1899 | 3.15.1.1 | سيم كشي زيرزمين دوم | 10d | 2010-10-27 | 2010-11-05 | 1900 | 0d |  | 89/8/5 | 89/8/14 |
| 1900 | 3.15.1.2 | سيم كشي زيرزمين اول | 10d | 2010-10-17 | 2010-10-26 | 1911 | 0d |  | 89/7/25 | 89/8/4 |
| 1901 | 3.15.1.3 | سيم كشي طبقه همكف | 10d | 2010-05-19 | 2010-05-28 | 1712 | 41d | 0d | 89/2/29 | 89/3/7 |
| 1902 | 3.15.1.4 | سيم كشي طبقه اول | 10d | 2010-05-29 | 2010-06-07 | 1713, 1901 | 41d | 0d | 89/3/8 | 89/3/17 |
| 1903 | 3.15.1.5 | سيم كشي طبقه دوم | 10d | 2010-06-08 | 2010-06-17 | 1714, 1902 | 41d | 4d | 89/3/18 | 89/3/27 |
| 1904 | 3.15.1.6 | سيم كشي طبقه سوم | 10d | 2010-06-22 | 2010-07-01 | 1715, 1903 | 37d | 5d | 89/4/1 | 89/4/10 |
| 1905 | 3.15.1.7 | سيم كشي طبقه چهارم | 10d | 2010-07-07 | 2010-07-16 | 1716, 1904 | 32d | 5d | 89/4/16 | 89/4/25 |
| 1906 | 3.15.1.8 | سيم كشي طبقه پنجم | 10d | 2010-07-22 | 2010-07-31 | 1717, 1905 | 27d | 5d | 89/4/31 | 89/5/9 |
| 1907 | 3.15.1.9 | سيم كشي طبقه ششم | 10d | 2010-08-06 | 2010-08-15 | 1718, 1906 | 22d | 5d | 89/5/15 | 89/5/24 |
| 1908 | 3.15.1.10 | سيم كشي طبقه هفتم | 10d | 2010-08-21 | 2010-08-30 | 1719, 1907 | 17d | 5d | 89/5/30 | 89/6/8 |
| 1909 | 3.15.1.11 | سيم كشي طبقه هشتم | 10d | 2010-09-05 | 2010-09-14 | 1720, 1908 | 12d | 5d | 89/6/14 | 89/6/23 |
| 1910 | 3.15.1.12 | سيم كشي طبقه نهم | 10d | 2010-09-20 | 2010-09-29 | 1721, 1909 | 7d | 6d | 89/6/29 | 89/7/7 |
| 1911 | 3.15.1.13 | سيم كشي طبقه دهم و خرپشته | 10d | 2010-10-07 | 2010-10-16 | 1722, 1910 | 0d |  | 89/7/15 | 89/7/24 |

| ID | WBS | Task | Duration | Start | Finish | Predecessors | Total slack | Plan Start | Plan Finish |
| --- | --- | --- | --- | --- | --- | --- | --- | --- | --- |
| 1912 | 3.15.2 | **نصب كليد و پريز لوازم برقي و هواكش** | 109d | 2010-07-26 | 2010-11-11 |  | 0d | 89/5/4 | 89/8/20 |
| 1913 | 3.15.2.1 | نصب كليد و پريز لوازم برقي و هواكش زيرزمين دوم | 6d | 2010-11-06 | 2010-11-11 | 1899 | 0d | 89/8/15 | 89/8/20 |
| 1914 | 3.15.2.2 | نصب كليد و پريز لوازم برقي و هواكش زيرزمين اول | 10d | 2010-10-27 | 2010-11-05 | 1900 | 6d | 89/8/5 | 89/8/14 |
| 1915 | 3.15.2.3 | نصب كليد و پريز لوازم برقي و هواكش طبقه همكف | 10d | 2010-07-26 | 2010-08-04 | 1848 | 99d | 89/5/4 | 89/5/13 |
| 1916 | 3.15.2.4 | نصب كليد و پريز لوازم برقي و هواكش طبقه اول | 10d | 2010-08-05 | 2010-08-14 | 1849 | 89d | 89/5/14 | 89/5/23 |
| 1917 | 3.15.2.5 | نصب كليد و پريز لوازم برقي و هواكش طبقه دوم | 10d | 2010-08-15 | 2010-08-24 | 1850 | 79d | 89/5/24 | 89/6/2 |
| 1918 | 3.15.2.6 | نصب كليد و پريز لوازم برقي و هواكش طبقه سوم | 10d | 2010-08-25 | 2010-09-03 | 1851 | 69d | 89/6/3 | 89/6/12 |
| 1919 | 3.15.2.7 | نصب كليد و پريز لوازم برقي و هواكش طبقه چهارم | 10d | 2010-09-04 | 2010-09-13 | 1852 | 59d | 89/6/13 | 89/6/22 |
| 1920 | 3.15.2.8 | نصب كليد و پريز لوازم برقي و هواكش طبقه پنجم | 10d | 2010-09-14 | 2010-09-23 | 1853 | 49d | 89/6/23 | 89/7/1 |
| 1921 | 3.15.2.9 | نصب كليد و پريز لوازم برقي و هواكش طبقه ششم | 10d | 2010-09-24 | 2010-10-03 | 1854 | 39d | 89/7/2 | 89/7/11 |
| 1922 | 3.15.2.10 | نصب كليد و پريز لوازم برقي و هواكش طبقه هفتم | 10d | 2010-10-04 | 2010-10-13 | 1855 | 29d | 89/7/12 | 89/7/21 |
| 1923 | 3.15.2.11 | نصب كليد و پريز لوازم برقي و هواكش طبقه هشتم | 10d | 2010-10-14 | 2010-10-23 | 1856 | 19d | 89/7/22 | 89/8/1 |
| 1924 | 3.15.2.12 | نصب كليد و پريز لوازم برقي و هواكش طبقه نهم | 10d | 2010-10-24 | 2010-11-02 | 1857 | 9d | 89/8/2 | 89/8/11 |
| 1925 | 3.15.2.13 | نصب كليد و پريز لوازم برقي و هواكش طبقه دهم | 6d | 2010-11-04 | 2010-11-09 | 1858 | 2d | 89/8/13 | 89/8/18 |
| 1926 | 3.15.3 | **ساخت و نصب تابلوهاي برقي** | 109d | 2010-07-26 | 2010-11-11 |  | 0d | 89/5/4 | 89/8/20 |
| 1927 | 3.15.3.1 | ساخت و نصب تابلوهاي برقي زيرزمين دوم | 6d | 2010-11-06 | 2010-11-11 | 1899 | 0d | 89/8/15 | 89/8/20 |
| 1928 | 3.15.3.2 | ساخت و نصب تابلوهاي برقي زيرزمين اول | 10d | 2010-10-27 | 2010-11-05 | 1900 | 6d | 89/8/5 | 89/8/14 |
| 1929 | 3.15.3.3 | ساخت و نصب تابلوهاي برقي طبقه همكف | 10d | 2010-07-26 | 2010-08-04 | 1848 | 99d | 89/5/4 | 89/5/13 |
| 1930 | 3.15.3.4 | ساخت و نصب تابلوهاي برقي طبقه اول | 10d | 2010-08-05 | 2010-08-14 | 1849 | 89d | 89/5/14 | 89/5/23 |
| 1931 | 3.15.3.5 | ساخت و نصب تابلوهاي برقي طبقه دوم | 10d | 2010-08-15 | 2010-08-24 | 1850 | 79d | 89/5/24 | 89/6/2 |
| 1932 | 3.15.3.6 | ساخت و نصب تابلوهاي برقي طبقه سوم | 10d | 2010-08-25 | 2010-09-03 | 1851 | 69d | 89/6/3 | 89/6/12 |
| 1933 | 3.15.3.7 | ساخت و نصب تابلوهاي برقي طبقه چهارم | 10d | 2010-09-04 | 2010-09-13 | 1852 | 59d | 89/6/13 | 89/6/22 |
| 1934 | 3.15.3.8 | ساخت و نصب تابلوهاي برقي طبقه پنجم | 10d | 2010-09-14 | 2010-09-23 | 1853 | 49d | 89/6/23 | 89/7/1 |
| 1935 | 3.15.3.9 | ساخت و نصب تابلوهاي برقي طبقه ششم | 10d | 2010-09-24 | 2010-10-03 | 1854 | 39d | 89/7/2 | 89/7/11 |
| 1936 | 3.15.3.10 | ساخت و نصب تابلوهاي برقي طبقه هفتم | 10d | 2010-10-04 | 2010-10-13 | 1855 | 29d | 89/7/12 | 89/7/21 |
| 1937 | 3.15.3.11 | ساخت و نصب تابلوهاي برقي طبقه هشتم | 10d | 2010-10-14 | 2010-10-23 | 1856 | 19d | 89/7/22 | 89/8/1 |
| 1938 | 3.15.3.12 | ساخت و نصب تابلوهاي برقي طبقه نهم | 10d | 2010-10-24 | 2010-11-02 | 1857 | 9d | 89/8/2 | 89/8/11 |
| 1939 | 3.15.3.13 | ساخت و نصب تابلوهاي برقي طبقه دهم | 8d | 2010-11-04 | 2010-11-11 | 1858 | 0d | 89/8/13 | 89/8/20 |

| ID | WBS | Task | Type | Duration | Start | Finish | Predecessors | Total slack | Free slack | Plan Start | Plan Finish |
| --- | --- | --- | --- | --- | --- | --- | --- | --- | --- | --- | --- |
| 1940 | 3.15.4 | **نصب و راه اندازي سيستم اعلام حريق و درب بازكن** |  | 109d | 2010-07-26 | 2010-11-11 |  | 0d |  | 89/5/4 | 89/8/20 |
| 1941 | 3.15.4.1 | نصب و راه اندازي سيستم اعلام حريق و درب بازكن زيرزمين دوم |  | 6d | 2010-11-06 | 2010-11-11 | 1899 | 0d |  | 89/8/15 | 89/8/20 |
| 1942 | 3.15.4.2 | نصب و راه اندازي سيستم اعلام حريق و درب بازكن زيرزمين اول |  | 10d | 2010-10-27 | 2010-11-05 | 1900 | 6d |  | 89/8/5 | 89/8/14 |
| 1943 | 3.15.4.3 | نصب و راه اندازي سيستم اعلام حريق و درب بازكن طبقه همكف |  | 10d | 2010-07-26 | 2010-08-04 | 1848 | 99d |  | 89/5/4 | 89/5/13 |
| 1944 | 3.15.4.4 | نصب و راه اندازي سيستم اعلام حريق و درب بازكن طبقه اول |  | 10d | 2010-08-05 | 2010-08-14 | 1849 | 89d |  | 89/5/14 | 89/5/23 |
| 1945 | 3.15.4.5 | نصب و راه اندازي سيستم اعلام حريق و درب بازكن طبقه دوم |  | 10d | 2010-08-15 | 2010-08-24 | 1850 | 79d |  | 89/5/24 | 89/6/2 |
| 1946 | 3.15.4.6 | نصب و راه اندازي سيستم اعلام حريق و درب بازكن طبقه سوم |  | 10d | 2010-08-25 | 2010-09-03 | 1851 | 69d |  | 89/6/3 | 89/6/12 |
| 1947 | 3.15.4.7 | نصب و راه اندازي سيستم اعلام حريق و درب بازكن طبقه چهارم |  | 10d | 2010-09-04 | 2010-09-13 | 1852 | 59d |  | 89/6/13 | 89/6/22 |
| 1948 | 3.15.4.8 | نصب و راه اندازي سيستم اعلام حريق و درب بازكن طبقه پنجم |  | 10d | 2010-09-14 | 2010-09-23 | 1853 | 49d |  | 89/6/23 | 89/7/1 |
| 1949 | 3.15.4.9 | نصب و راه اندازي سيستم اعلام حريق و درب بازكن طبقه ششم |  | 10d | 2010-09-24 | 2010-10-03 | 1854 | 39d |  | 89/7/2 | 89/7/11 |
| 1950 | 3.15.4.10 | نصب و راه اندازي سيستم اعلام حريق و درب بازكن طبقه هفتم |  | 10d | 2010-10-04 | 2010-10-13 | 1855 | 29d |  | 89/7/12 | 89/7/21 |
| 1951 | 3.15.4.11 | نصب و راه اندازي سيستم اعلام حريق و درب بازكن طبقه هشتم |  | 10d | 2010-10-14 | 2010-10-23 | 1856 | 19d |  | 89/7/22 | 89/8/1 |
| 1952 | 3.15.4.12 | نصب و راه اندازي سيستم اعلام حريق و درب بازكن طبقه نهم |  | 10d | 2010-10-24 | 2010-11-02 | 1857 | 9d |  | 89/8/2 | 89/8/11 |
| 1953 | 3.15.4.13 | نصب و راه اندازي سيستم اعلام حريق و درب بازكن طبقه دهم |  | 8d | 2010-11-04 | 2010-11-11 | 1858 | 0d |  | 89/8/13 | 89/8/20 |
| 1954 | 3.16 | **نصب و راه اندازي آسانسور و ژنراتور** |  | 70d | 2010-09-01 | 2010-11-09 |  | 0d |  | 89/6/10 | 89/8/18 |
| 1955 | 3.16.1 | آهن كشي آسانسور |  | 20d | 2010-09-01 | 2010-09-20 | 1956FF-20d | 50d |  | 89/6/10 | 89/6/29 |
| 1956 | 3.16.2 | نصب درب و ريل |  | 20d | 2010-09-21 | 2010-10-10 | 1822FF | 0d |  | 89/6/30 | 89/7/18 |
| 1957 | 3.16.3 | نصب و راه اندازي كامل آسانسور |  | 20d | 2010-10-11 | 2010-10-30 | 1956 | 0d |  | 89/7/19 | 89/8/8 |
| 1958 | 3.16.4 | نصب و راه اندازي ژنراتور |  | 10d | 2010-10-31 | 2010-11-09 | 1957 | 0d |  | 89/8/9 | 89/8/18 |
| 1959 | 3.17 | **محوطه سازي** |  | 215d | 2010-03-04 | 2010-10-12 |  | 30d |  | 88/12/13 | 89/7/20 |
| 1960 | 3.17.1 | ديواركشي پيرامون |  | 40d | 2010-05-11 | 2010-06-19 | 1961FF-70d | 145d | 0d | 89/2/21 | 89/3/29 |
| 1961 | 3.17.2 | محوطه سازي مجتمع |  | 60d | 2010-06-30 | 2010-08-28 | 1962FF-45d | 75d | 0d | 89/4/9 | 89/6/6 |
| 1962 | 3.17.3 | اجراي تاسيسات محوطه |  | 35d | 2010-09-08 | 2010-10-12 | 1964FF-30d | 30d | 0d | 89/6/17 | 89/7/20 |
| 1963 | 3.17.4 | اجرا ساختمان نگهباني و سردرب |  | 50d | 2010-03-04 | 2010-04-30 | 1960FF-50d | 195d |  | 88/12/13 | 89/2/10 |
| 1964 | 3.18 | برچيدن كارگاه بلوك 1 |  | 10d | 2010-11-02 | 2010-11-11 | 1954FS-8d | 0d |  | 89/8/11 | 89/8/20 |
| 1965 | 3.19 | اتمام بلوك 1 | milestone | 0d | 2010-11-11 | 2010-11-11 | 1964 | 0d |  | 89/8/20 | 89/8/20 |

| ID | WBS | Task | Duration | Start | Finish | Predecessors | Total slack | Free slack | Plan Start | Plan Finish | Text1 | Text2 | واحد |
| --- | --- | --- | --- | --- | --- | --- | --- | --- | --- | --- | --- | --- | --- |
| 1966 | 4 | **بلوك 4** | 900d | 2008-05-09 | 2010-11-11 |  | 0d |  | 87/2/20 | 89/8/20 |  |  |  |
| 1967 | 4.1 | **طراحي پروژه** | 70d | 2008-05-09 | 2008-07-17 |  | 0d |  | 87/2/20 | 87/4/27 |  |  |  |
| 1968 | 4.1.1 | طراحي فاز 1 و تاييد شهرداري | 35d | 2008-05-09 | 2008-06-12 |  | 0d |  | 87/2/20 | 87/3/23 |  |  |  |
| 1969 | 4.1.2 | طراحي كامل (فاز 2) و تاييد شهرداري | 35d | 2008-06-13 | 2008-07-17 | 1968 | 0d |  | 87/3/24 | 87/4/27 |  |  |  |
| 1970 | 4.2 | اخذ پروانه | 5d | 2008-07-18 | 2008-07-22 | 1969 | 0d |  | 87/4/28 | 87/5/1 |  |  |  |
| 1971 | 4.3 | **آزمايشگاه مكانيك خاك و نقشه برداري** | 10d | 2008-07-23 | 2008-08-01 |  | 4d |  | 87/5/2 | 87/5/11 |  |  |  |
| 1972 | 4.3.1 | آزمايشگاه مكانيك خاك | 5d | 2008-07-23 | 2008-07-27 | 1970 | 820d |  | 87/5/2 | 87/5/6 |  |  |  |
| 1973 | 4.3.2 | نقشه برداري | 10d | 2008-07-23 | 2008-08-01 | 1970 | 4d |  | 87/5/2 | 87/5/11 |  |  |  |
| 1974 | 4.4 | **انشعابات** | 14d | 2008-07-23 | 2008-08-05 |  | 0d |  | 87/5/2 | 87/5/15 |  |  |  |
| 1975 | 4.4.1 | انشعاب آب و فاضلاب | 14d | 2008-07-23 | 2008-08-05 | 1970 | 0d |  | 87/5/2 | 87/5/15 |  |  |  |
| 1976 | 4.4.2 | انشعاب برق | 14d | 2008-07-23 | 2008-08-05 | 1970 | 0d |  | 87/5/2 | 87/5/15 |  |  |  |
| 1977 | 4.4.3 | انشعاب گاز | 14d | 2008-07-23 | 2008-08-05 | 1970 | 0d |  | 87/5/2 | 87/5/15 |  |  |  |
| 1978 | 4.4.4 | انشعاب تلفن | 14d | 2008-07-23 | 2008-08-05 | 1970 | 0d |  | 87/5/2 | 87/5/15 |  |  |  |
| 1979 | 4.5 | تجهيز كارگاه | 14d | 2008-07-23 | 2008-08-05 | 1970 | 0d |  | 87/5/2 | 87/5/15 | 86/11/16 | 86/12/25 | درصد |
| 1980 | 4.6 | **خاكبرداري** | 15d | 2008-08-06 | 2008-08-20 |  | 0d |  | 87/5/16 | 87/5/30 | 86/12/26 | 87/02/05 | درصد |
| 1981 | 4.6.1 | خاکبرداري با ماشين | 15d | 2008-08-06 | 2008-08-20 | 1973, 1974, 1979 | 0d |  | 87/5/16 | 87/5/30 | 86/12/26 | 87/01/16 | مترمکعب |
| 1982 | 4.6.2 | خاكبرداري دستي و رگلاژ | 15d | 2008-08-06 | 2008-08-20 | 1981FF | 0d |  | 87/5/16 | 87/5/30 | 87/01/17 | 87/02/05 |  |
| 1983 | 4.7 | **اجراي فونداسيون** | 21d | 2008-08-21 | 2008-09-10 |  | 0d |  | 87/5/31 | 87/6/20 | 87/03/05 | 87/04/08 | درصد |
| 1984 | 4.7.1 | بتن مگر | 5d | 2008-08-21 | 2008-08-25 | 1980 | 0d |  | 87/5/31 | 87/6/4 | 87/03/06 | 87/03/10 | مترمکعب |
| 1985 | 4.7.2 | آرماتور بندي فونداسيون | 10d | 2008-08-26 | 2008-09-04 | 1984 | 0d |  | 87/6/5 | 87/6/14 | 87/03/11 | 87/03/20 | تن |
| 1986 | 4.7.3 | قالب بندي فونداسيون | 10d | 2008-08-27 | 2008-09-05 | 1985SS+1d | 0d |  | 87/6/6 | 87/6/15 | 87/03/07 | 87/03/21 | مترمربع |
| 1987 | 4.7.4 | بتن ريزي فونداسيون | 5d | 2008-09-06 | 2008-09-10 | 1986 | 0d |  | 87/6/16 | 87/6/20 | 87/03/22 | 87/04/08 | مترمکعب |
| 1988 | 4.8 | **اجراي اسكلت سازه** | 412d | 2008-09-13 | 2009-11-07 |  | 0d |  | 87/6/23 | 88/8/16 |  |  | درصد |
| 1989 | 4.8.1 | **آرماتوربندي ستونها و ديوارها** | 401d | 2008-09-13 | 2009-10-27 |  | 0d |  | 87/6/23 | 88/8/5 |  |  |  |
| 1990 | 4.8.1.1 | آرماتور بندي ستونها و ديوارهاي زيرزمين دوم | 5d | 2008-09-13 | 2008-09-17 | 1983FS+2d | 0d |  | 87/6/23 | 87/6/27 |  |  | تن |
| 1991 | 4.8.1.2 | آرماتور بندي ستونها و ديوارهاي زيرزمين اول | 5d | 2008-10-16 | 2008-10-20 | 2117 | 54d | 0d | 87/7/25 | 87/7/29 | 87/04/09 | 87/04/18 | تن |
| 1992 | 4.8.1.3 | آرماتور بندي ستونها و ديوارهاي همكف | 5d | 2008-11-18 | 2008-11-22 | 2118 | 54d | 0d | 87/8/28 | 87/9/2 | 87/05/11 | 87/05/20 | تن |
| 1993 | 4.8.1.4 | آرماتور بندي ستونها و ديوارهاي طبقه اول | 5d | 2008-12-21 | 2008-12-25 | 2119 | 61d | 0d | 87/10/1 | 87/10/5 | 87/06/13 | 87/06/22 | تن |
| 1994 | 4.8.1.5 | آرماتور بندي ستونها و ديوارهاي طبقه دوم | 5d | 2009-01-23 | 2009-01-27 | 2120 | 68d | 0d | 87/11/4 | 87/11/8 | 87/07/15 | 87/07/24 | تن |
| 1995 | 4.8.1.6 | آرماتور بندي ستونها و ديوارهاي طبقه سوم | 5d | 2009-02-25 | 2009-03-01 | 2121 | 75d | 0d | 87/12/7 | 87/12/11 | 87/08/18 | 87/08/27 | تن |
| 1996 | 4.8.1.7 | آرماتور بندي ستونها وديوارهاي طبقه چهارم | 5d | 2009-04-08 | 2009-04-12 | 2122 | 82d | 0d | 88/1/19 | 88/1/23 | 87/09/21 | 87/09/30 | تن |
| 1997 | 4.8.1.8 | آرماتور بندي ستونها و ديوارهاي طبقه پنجم | 5d | 2009-05-11 | 2009-05-15 | 2123 | 88d | 0d | 88/2/21 | 88/2/25 | 87/10/24 | 87/11/03 | تن |
| 1998 | 4.8.1.9 | آرماتور بندي ستونها و ديوارهاي طبقه ششم | 5d | 2009-06-13 | 2009-06-17 | 2124 | 88d | 0d | 88/3/23 | 88/3/27 | 87/11/27 | 87/12/06 | تن |
| 1999 | 4.8.1.10 | آرماتور بندي ستونها و ديوارهاي طبقه هفتم | 5d | 2009-07-16 | 2009-07-20 | 2125 | 93d | 0d | 88/4/25 | 88/4/29 | 87/12/30 | 88/01/09 | تن |
| 2000 | 4.8.1.11 | آرماتور بندي ستونها و ديوارهاي طبقه هشتم | 5d | 2009-08-18 | 2009-08-22 | 2126 | 100d | 0d | 88/5/27 | 88/5/31 | 88/02/02 | 88/02/11 | تن |
| 2001 | 4.8.1.12 | آرماتور بندي ستونها و ديوارهاي طبقه نهم | 5d | 2009-09-20 | 2009-09-24 | 2127 | 107d | 0d | 88/6/29 | 88/7/2 | 88/02/31 | 88/03/09 | تن |
| 2002 | 4.8.1.13 | آرماتور بندي ستونها و ديوارهاي طبقه دهم و خرپشته | 5d | 2009-10-23 | 2009-10-27 | 2128 | 114d | 0d | 88/8/1 | 88/8/5 | 88/04/02 | 88/04/11 | تن |

| ID | WBS | Task | Duration | Start | Finish | Predecessors | Total slack | Free slack | Plan Start | Plan Finish | واحد | Text1 | Text2 |
| --- | --- | --- | --- | --- | --- | --- | --- | --- | --- | --- | --- | --- | --- |
| 2003 | 4.8.2 | **قالب بندي ستونها و ديوارها** | 401d | 2008-09-14 | 2009-10-28 |  | 0d |  | 87/6/24 | 88/8/6 |  |  |  |
| 2004 | 4.8.2.1 | قالب بندي ستونها و ديوارهاي زيرزمين دوم | 5d | 2008-09-14 | 2008-09-18 | 1990SS+1d | 0d |  | 87/6/24 | 87/6/28 | مترمربع |  |  |
| 2005 | 4.8.2.2 | قالب بندي ستونها و ديوارها ي زيرزمين اول | 5d | 2008-10-17 | 2008-10-21 | 1991SS+1d | 54d | 0d | 87/7/26 | 87/7/30 | مترمربع | 87/04/10 | 87/04/19 |
| 2006 | 4.8.2.3 | قالب بندي ستونها و ديوارهاي همكف | 5d | 2008-11-19 | 2008-11-23 | 1992SS+1d | 54d | 0d | 87/8/29 | 87/9/3 | مترمربع | 87/05/12 | 87/05/21 |
| 2007 | 4.8.2.4 | قالب بندي ستونها و ديوارهاي طبقه اول | 5d | 2008-12-22 | 2008-12-26 | 1993SS+1d | 61d | 0d | 87/10/2 | 87/10/6 | مترمربع | 87/06/14 | 87/06/23 |
| 2008 | 4.8.2.5 | قالب بندي ستونها و ديوارهاي طبقه دوم | 5d | 2009-01-24 | 2009-01-28 | 1994SS+1d | 68d | 0d | 87/11/5 | 87/11/9 | مترمربع | 87/07/16 | 87/07/25 |
| 2009 | 4.8.2.6 | قالب بندي ستونها و ديوارهاي طبقه سوم | 5d | 2009-02-26 | 2009-03-02 | 1995SS+1d | 75d | 0d | 87/12/8 | 87/12/12 | مترمربع | 87/08/19 | 87/08/28 |
| 2010 | 4.8.2.7 | قالب بندي ستونها و ديوارهاي طبقه چهارم | 5d | 2009-04-09 | 2009-04-13 | 1996SS+1d | 82d | 0d | 88/1/20 | 88/1/24 | مترمربع | 87/09/22 | 87/10/01 |
| 2011 | 4.8.2.8 | قالب بندي ستونها و ديوارهاي طبقه پنجم | 5d | 2009-05-12 | 2009-05-16 | 1997SS+1d | 88d | 0d | 88/2/22 | 88/2/26 | مترمربع | 87/10/25 | 87/11/04 |
| 2012 | 4.8.2.9 | قالب بندي ستونها و ديوارهاي طبقه ششم | 5d | 2009-06-14 | 2009-06-18 | 1998SS+1d | 88d | 0d | 88/3/24 | 88/3/28 | مترمربع | 87/11/28 | 87/12/07 |
| 2013 | 4.8.2.10 | قالب بندي ستونها و ديوارهاي طبقه هفتم | 5d | 2009-07-17 | 2009-07-21 | 1999SS+1d | 93d | 0d | 88/4/26 | 88/4/30 | مترمربع | 88/01/01 | 88/01/10 |
| 2014 | 4.8.2.11 | قالب بندي ستونها و ديوارهاي طبقه هشتم | 5d | 2009-08-19 | 2009-08-23 | 2000SS+1d | 100d | 0d | 88/5/28 | 88/6/1 | مترمربع | 88/02/03 | 88/02/12 |
| 2015 | 4.8.2.12 | قالب بندي ستونها و ديوارهاي طبقه نهم | 5d | 2009-09-21 | 2009-09-25 | 2001SS+1d | 107d | 0d | 88/6/30 | 88/7/3 | مترمربع | 88/03/01 | 88/03/10 |
| 2016 | 4.8.2.13 | قالب بندي ستونها و ديوارهاي طبقه دهم و خرپشته | 5d | 2009-10-24 | 2009-10-28 | 2002SS+1d | 114d | 0d | 88/8/2 | 88/8/6 | مترمربع | 88/04/03 | 88/04/12 |
| 2017 | 4.8.3 | **بتن ريزي ستونها و ديوارها** | 398d | 2008-09-19 | 2009-10-30 |  | 0d |  | 87/6/29 | 88/8/8 |  |  |  |
| 2018 | 4.8.3.1 | بتن ريزي ستونها و ديوارهاي زيرزمين دوم | 2d | 2008-09-19 | 2008-09-20 | 2004 | 0d |  | 87/6/29 | 87/6/30 | مترمکعب |  |  |
| 2019 | 4.8.3.2 | بتن ريزي ستونها و ديوارهاي زيرزمين اول | 2d | 2008-10-22 | 2008-10-23 | 2005 | 54d | 0d | 87/8/1 | 87/8/2 | مترمکعب | 87/04/19 | 87/04/28 |
| 2020 | 4.8.3.3 | بتن ريزي ستونها و ديوارهاي همكف | 2d | 2008-11-24 | 2008-11-25 | 2006 | 54d | 0d | 87/9/4 | 87/9/5 | مترمکعب | 87/05/21 | 87/05/30 |
| 2021 | 4.8.3.4 | بتن ريزي ستونها و ديوارهاي طبقه اول | 2d | 2008-12-27 | 2008-12-28 | 2007 | 61d | 0d | 87/10/7 | 87/10/8 | مترمکعب | 87/06/23 | 87/07/01 |
| 2022 | 4.8.3.5 | بتن ريزي ستونها و ديوارهاي طبقه دوم | 2d | 2009-01-29 | 2009-01-30 | 2008 | 68d | 0d | 87/11/10 | 87/11/11 | مترمکعب | 87/07/24 | 87/07/25 |
| 2023 | 4.8.3.6 | بتن ريزي ستونها و ديوارهاي طبقه سوم | 2d | 2009-03-03 | 2009-03-04 | 2009 | 75d | 0d | 87/12/13 | 87/12/14 | مترمکعب | 87/08/27 | 87/08/28 |
| 2024 | 4.8.3.7 | بتن ريزي ستونها و ديوارهاي طبقه چهارم | 2d | 2009-04-14 | 2009-04-15 | 2010 | 82d | 0d | 88/1/25 | 88/1/26 | مترمکعب | 87/09/30 | 87/10/01 |
| 2025 | 4.8.3.8 | بتن ريزي ستونها و ديوارهاي طبقه پنجم | 2d | 2009-05-17 | 2009-05-18 | 2011 | 88d | 0d | 88/2/27 | 88/2/28 | مترمکعب | 87/11/03 | 87/11/04 |
| 2026 | 4.8.3.9 | بتن ريزي ستونها و ديوارهاي طبقه ششم | 2d | 2009-06-19 | 2009-06-20 | 2012 | 88d | 0d | 88/3/29 | 88/3/30 | مترمکعب | 87/12/06 | 87/12/07 |
| 2027 | 4.8.3.10 | بتن ريزي ستونها و ديوارهاي طبقه هفتم | 2d | 2009-07-22 | 2009-07-23 | 2013 | 93d | 0d | 88/4/31 | 88/5/1 | مترمکعب | 88/01/09 | 88/01/10 |
| 2028 | 4.8.3.11 | بتن ريزي ستونها و ديوارهاي طبقه هشتم | 2d | 2009-08-24 | 2009-08-25 | 2014 | 100d | 0d | 88/6/2 | 88/6/3 | مترمکعب | 88/02/11 | 88/02/12 |
| 2029 | 4.8.3.12 | بتن ريزي ستونها و ديوارهاي طبقه نهم | 2d | 2009-09-26 | 2009-09-27 | 2015 | 107d | 0d | 88/7/4 | 88/7/5 | مترمکعب | 88/03/09 | 88/03/10 |
| 2030 | 4.8.3.13 | بتن ريزي ستونها و ديوارهاي طبقه دهم | 2d | 2009-10-29 | 2009-10-30 | 2016 | 114d | 0d | 88/8/7 | 88/8/8 | مترمکعب | 88/04/11 | 88/04/12 |

| ID | WBS | Task | Duration | Start | Finish | Predecessors | Total slack | Free slack | Plan Start | Plan Finish | واحد | Text1 | Text2 |
| --- | --- | --- | --- | --- | --- | --- | --- | --- | --- | --- | --- | --- | --- |
| 2031 | 4.8.4 | **آرماتوربندي تيرها** | 401d | 2008-09-21 | 2009-11-04 |  | 0d |  | 87/6/31 | 88/8/13 |  |  |  |
| 2032 | 4.8.4.1 | آرماتوربندي تيرهاي زيرزمين دوم | 5d | 2008-09-21 | 2008-09-25 | 2018 | 0d |  | 87/6/31 | 87/7/4 | تن |  |  |
| 2033 | 4.8.4.2 | آرماتوربندي تيرهاي زيرزمين اول | 5d | 2008-10-24 | 2008-10-28 | 2019 | 54d | 0d | 87/8/3 | 87/8/7 | تن |  |  |
| 2034 | 4.8.4.3 | آرماتوربندي تيرهاي همكف | 5d | 2008-11-26 | 2008-11-30 | 2020 | 54d | 0d | 87/9/6 | 87/9/10 | تن |  |  |
| 2035 | 4.8.4.4 | آرماتوربندي تيرهاي طبقه اول | 5d | 2008-12-29 | 2009-01-02 | 2021 | 61d | 0d | 87/10/9 | 87/10/13 | تن |  |  |
| 2036 | 4.8.4.5 | آرماتوربندي تيرهاي طبقه دوم | 5d | 2009-01-31 | 2009-02-04 | 2022 | 68d | 0d | 87/11/12 | 87/11/16 | تن | 87/07/25 | 87/08/04 |
| 2037 | 4.8.4.6 | آرماتوربندي تيرها ي طبقه سوم | 5d | 2009-03-05 | 2009-03-09 | 2023 | 75d | 0d | 87/12/15 | 87/12/19 | تن | 87/08/28 | 87/09/07 |
| 2038 | 4.8.4.7 | آرماتوربندي تيرهاي طبقه چهارم | 5d | 2009-04-16 | 2009-04-20 | 2024 | 82d | 0d | 88/1/27 | 88/1/31 | تن | 87/10/01 | 87/10/10 |
| 2039 | 4.8.4.8 | آرماتوربندي تيرهاي طبقه پنجم | 5d | 2009-05-19 | 2009-05-23 | 2025 | 88d | 0d | 88/2/29 | 88/3/2 | تن | 87/11/04 | 87/11/13 |
| 2040 | 4.8.4.9 | آرماتوربندي تيرهاي طبقه ششم | 5d | 2009-06-21 | 2009-06-25 | 2026 | 88d | 0d | 88/3/31 | 88/4/4 | تن | 87/12/07 | 87/12/16 |
| 2041 | 4.8.4.10 | آرماتوربندي تيرهاي طبقه هفتم | 5d | 2009-07-24 | 2009-07-28 | 2027 | 93d | 0d | 88/5/2 | 88/5/6 | تن | 88/01/10 | 88/01/19 |
| 2042 | 4.8.4.11 | آرماتوربندي تيرهاي طبقه هشتم | 5d | 2009-08-26 | 2009-08-30 | 2028 | 100d | 0d | 88/6/4 | 88/6/8 | تن | 88/02/12 | 88/02/21 |
| 2043 | 4.8.4.12 | آرماتوربندي تيرهاي طبقه نهم | 5d | 2009-09-28 | 2009-10-02 | 2029 | 107d | 0d | 88/7/6 | 88/7/10 | تن | 88/03/10 | 88/03/19 |
| 2044 | 4.8.4.13 | آرماتوربندي تيرهاي طبقه دهم و خرپشته | 5d | 2009-10-31 | 2009-11-04 | 2030 | 114d | 0d | 88/8/9 | 88/8/13 | تن | 88/04/12 | 88/04/21 |
| 2045 | 4.8.5 | **قالب بندي تيرها** | 401d | 2008-09-22 | 2009-11-05 |  | 0d |  | 87/7/1 | 88/8/14 |  |  |  |
| 2046 | 4.8.5.1 | قالب بندي تيرها زيرزمين دوم | 5d | 2008-09-22 | 2008-09-26 | 2032SS+1d | 0d |  | 87/7/1 | 87/7/5 | مترمربع |  |  |
| 2047 | 4.8.5.2 | قالب بندي تيرهاي زيرزمين اول | 5d | 2008-10-25 | 2008-10-29 | 2033SS+1d | 54d | 0d | 87/8/4 | 87/8/8 | مترمربع |  |  |
| 2048 | 4.8.5.3 | قالب بندي تيرهاي همكف | 5d | 2008-11-27 | 2008-12-01 | 2034SS+1d | 54d | 0d | 87/9/7 | 87/9/11 | مترمربع |  |  |
| 2049 | 4.8.5.4 | قالب بندي تيرهاي طبقه اول | 5d | 2008-12-30 | 2009-01-03 | 2035SS+1d | 61d | 0d | 87/10/10 | 87/10/14 | مترمربع |  |  |
| 2050 | 4.8.5.5 | قالب بندي تيرهاي طبقه دوم | 5d | 2009-02-01 | 2009-02-05 | 2036SS+1d | 68d | 0d | 87/11/13 | 87/11/17 | مترمربع | 87/07/26 | 87/07/30 |
| 2051 | 4.8.5.6 | قالب بندي تيرهاي طبقه سوم | 5d | 2009-03-06 | 2009-03-10 | 2037SS+1d | 75d | 0d | 87/12/16 | 87/12/20 | مترمربع |  |  |
| 2052 | 4.8.5.7 | قالب بندي تيرهاي طبقه چهارم | 5d | 2009-04-17 | 2009-04-21 | 2038SS+1d | 82d | 0d | 88/1/28 | 88/2/1 | مترمربع | 87/10/02 | 87/10/06 |
| 2053 | 4.8.5.8 | قالب بندي تيرهاي طبقه پنجم | 5d | 2009-05-20 | 2009-05-24 | 2039SS+1d | 88d | 0d | 88/2/30 | 88/3/3 | مترمربع | 87/11/05 | 87/11/09 |
| 2054 | 4.8.5.9 | قالب بندي تيرهاي طبقه ششم | 5d | 2009-06-22 | 2009-06-26 | 2040SS+1d | 88d | 0d | 88/4/1 | 88/4/5 | مترمربع | 87/12/08 | 87/12/12 |
| 2055 | 4.8.5.10 | قالب بندي تيرهاي طبقه هفتم | 5d | 2009-07-25 | 2009-07-29 | 2041SS+1d | 93d | 0d | 88/5/3 | 88/5/7 | مترمربع | 88/01/11 | 88/01/15 |
| 2056 | 4.8.5.11 | قالب بندي تيرهاي طبقه هشتم | 5d | 2009-08-27 | 2009-08-31 | 2042SS+1d | 100d | 0d | 88/6/5 | 88/6/9 | مترمربع | 88/02/13 | 88/02/17 |
| 2057 | 4.8.5.12 | قالب بندي تيرهاي طبقه نهم | 5d | 2009-09-29 | 2009-10-03 | 2043SS+1d | 107d | 0d | 88/7/7 | 88/7/11 | مترمربع | 88/03/11 | 88/03/15 |
| 2058 | 4.8.5.13 | قالب بندي تيرهاي طبقه دهم و خرپشته | 5d | 2009-11-01 | 2009-11-05 | 2044SS+1d | 114d | 0d | 88/8/10 | 88/8/14 | مترمربع | 88/04/13 | 88/04/17 |

| ID | WBS | Task | Duration | Start | Finish | Predecessors | Total slack | Free slack | Plan Start | Plan Finish | واحد | Text1 | Text2 |
| --- | --- | --- | --- | --- | --- | --- | --- | --- | --- | --- | --- | --- | --- |
| 2059 | 4.8.6 | **بتن ريزي تيرها** | 398d | 2008-09-27 | 2009-11-07 |  | 0d |  | 87/7/6 | 88/8/16 |  |  |  |
| 2060 | 4.8.6.1 | بتن ريزي تيرهاي زيرزمين دوم | 2d | 2008-09-27 | 2008-09-28 | 2046 | 0d |  | 87/7/6 | 87/7/7 | مترمکعب |  |  |
| 2061 | 4.8.6.2 | بتن ريزي تيرهاي زيرزمين اول | 2d | 2008-10-30 | 2008-10-31 | 2047 | 54d | 0d | 87/8/9 | 87/8/10 | مترمکعب |  |  |
| 2062 | 4.8.6.3 | بتن ريزي تيرهاي همكف | 2d | 2008-12-02 | 2008-12-03 | 2048 | 54d | 0d | 87/9/12 | 87/9/13 | مترمکعب |  |  |
| 2063 | 4.8.6.4 | بتن ريزي تيرها طبقه اول | 2d | 2009-01-04 | 2009-01-05 | 2049 | 61d | 0d | 87/10/15 | 87/10/16 | مترمکعب |  |  |
| 2064 | 4.8.6.5 | بتن ريزي تيرهاي طبقه دوم | 2d | 2009-02-06 | 2009-02-07 | 2050 | 68d | 0d | 87/11/18 | 87/11/19 | مترمکعب |  |  |
| 2065 | 4.8.6.6 | بتن ريزي تيرهاي طبقه سوم | 2d | 2009-03-11 | 2009-03-12 | 2051 | 75d | 0d | 87/12/21 | 87/12/22 | مترمکعب |  |  |
| 2066 | 4.8.6.7 | بتن ريزي تيرهاي طبقه چهارم | 2d | 2009-04-22 | 2009-04-23 | 2052 | 82d | 0d | 88/2/2 | 88/2/3 | مترمکعب |  |  |
| 2067 | 4.8.6.8 | بتن ريزي تيرهاي طبقه پنجم | 2d | 2009-05-25 | 2009-05-26 | 2053 | 88d | 0d | 88/3/4 | 88/3/5 | مترمکعب |  |  |
| 2068 | 4.8.6.9 | بتن ريزي تيرهاي طبقه ششم | 2d | 2009-06-27 | 2009-06-28 | 2054 | 88d | 0d | 88/4/6 | 88/4/7 | مترمکعب |  |  |
| 2069 | 4.8.6.10 | بتن ريزي تيرهاي طبقه هفتم | 2d | 2009-07-30 | 2009-07-31 | 2055 | 93d | 0d | 88/5/8 | 88/5/9 | مترمکعب |  |  |
| 2070 | 4.8.6.11 | بتن ريزي تيرهاي طبقه هشتم | 2d | 2009-09-01 | 2009-09-02 | 2056 | 100d | 0d | 88/6/10 | 88/6/11 | مترمکعب |  |  |
| 2071 | 4.8.6.12 | بتن ريزي تيرهاي طبقه نهم | 2d | 2009-10-04 | 2009-10-05 | 2057 | 107d | 0d | 88/7/12 | 88/7/13 | مترمکعب |  |  |
| 2072 | 4.8.6.13 | بتن ريزي تيرهاي طبقه دهم و خرپشته | 2d | 2009-11-06 | 2009-11-07 | 2058 | 114d | 0d | 88/8/15 | 88/8/16 | مترمکعب |  |  |
| 2073 | 4.9 | **اجراي سقف سازه** | 406d | 2008-10-06 | 2009-11-24 |  | 0d |  | 87/7/15 | 88/9/3 | درصد |  |  |
| 2074 | 4.9.1 | **ساخت تيرچه و تيرچه گذاري** | 399d | 2008-10-06 | 2009-11-17 |  | 0d |  | 87/7/15 | 88/8/26 |  |  |  |
| 2075 | 4.9.1.1 | ساخت تيرچه و تيرچه گذاري زيرزمين دوم | 3d | 2008-10-06 | 2008-10-08 | 2060FS+7d | 0d |  | 87/7/15 | 87/7/17 |  |  |  |
| 2076 | 4.9.1.2 | ساخت تيرچه و تيرچه گذاري زيرزمين اول | 3d | 2008-11-08 | 2008-11-10 | 2061FS+7d | 54d | 0d | 87/8/18 | 87/8/20 |  | 87/04/25 | 87/05/03 |
| 2077 | 4.9.1.3 | ساخت تيرچه و تيرچه گذاري همكف | 3d | 2008-12-11 | 2008-12-13 | 2062FS+7d | 54d | 0d | 87/9/21 | 87/9/23 |  | 87/05/27 | 87/06/05 |
| 2078 | 4.9.1.4 | ساخت تيرچه و تيرچه گذاري طبقه اول | 3d | 2009-01-13 | 2009-01-15 | 2063FS+7d | 61d | 0d | 87/10/24 | 87/10/26 |  | 87/06/29 | 87/07/07 |
| 2079 | 4.9.1.5 | ساخت تيرچه و تيرچه گذاري طبقه دوم | 3d | 2009-02-15 | 2009-02-17 | 2064FS+7d | 68d | 0d | 87/11/27 | 87/11/29 |  | 87/08/01 | 87/08/10 |
| 2080 | 4.9.1.6 | ساخت تيرچه و تيرچه گذاري طبقه سوم | 3d | 2009-03-29 | 2009-03-31 | 2065FS+7d | 75d | 0d | 88/1/9 | 88/1/11 |  | 87/09/04 | 87/09/13 |
| 2081 | 4.9.1.7 | ساخت تيرچه و تيرچه گذاري طبقه چهارم | 3d | 2009-05-01 | 2009-05-03 | 2066FS+7d | 82d | 0d | 88/2/11 | 88/2/13 |  | 87/10/07 | 87/10/16 |
| 2082 | 4.9.1.8 | ساخت تيرچه و تيرچه گذاري طبقه پنجم | 3d | 2009-06-03 | 2009-06-05 | 2067FS+7d | 88d | 0d | 88/3/13 | 88/3/15 |  | 87/11/10 | 87/11/19 |
| 2083 | 4.9.1.9 | ساخت تيرچه و تيرچه گذاري طبقه ششم | 3d | 2009-07-06 | 2009-07-08 | 2068FS+7d | 88d | 0d | 88/4/15 | 88/4/17 |  | 87/12/13 | 87/12/22 |
| 2084 | 4.9.1.10 | ساخت تيرچه و تيرچه گذاري طبقه هفتم | 3d | 2009-08-08 | 2009-08-10 | 2069FS+7d | 93d | 0d | 88/5/17 | 88/5/19 |  | 88/01/16 | 88/01/25 |
| 2085 | 4.9.1.11 | ساخت تيرچه و تيرچه گذاري طبقه هشتم | 3d | 2009-09-10 | 2009-09-12 | 2070FS+7d | 100d | 0d | 88/6/19 | 88/6/21 |  | 88/02/18 | 88/02/27 |
| 2086 | 4.9.1.12 | ساخت تيرچه و تيرچه گذاري طبقه نهم | 3d | 2009-10-13 | 2009-10-15 | 2071FS+7d | 107d | 0d | 88/7/21 | 88/7/23 |  | 88/03/16 | 88/03/25 |
| 2087 | 4.9.1.13 | ساخت تيرچه و تيرچه گذاري طبقه دهم و خرپشته | 3d | 2009-11-15 | 2009-11-17 | 2072FS+7d | 114d | 0d | 88/8/24 | 88/8/26 |  | 88/04/18 | 88/04/27 |

| ID | WBS | Task | Duration | Start | Finish | Predecessors | Total slack | Free slack | Plan Start | Plan Finish | واحد | Text1 | Text2 |
| --- | --- | --- | --- | --- | --- | --- | --- | --- | --- | --- | --- | --- | --- |
| 2088 | 4.9.2 | **آرماتور بندي سقف و راه پله** | 402d | 2008-10-07 | 2009-11-21 |  | 0d |  | 87/7/16 | 88/8/30 |  |  |  |
| 2089 | 4.9.2.1 | آرماتور بندي سقف و راه پله زيرزمين دوم | 6d | 2008-10-07 | 2008-10-12 | 2075SS+1d | 0d |  | 87/7/16 | 87/7/21 | تن |  |  |
| 2090 | 4.9.2.2 | آرماتور بندي سقف و راه پله زيرزمين اول | 6d | 2008-11-09 | 2008-11-14 | 2076SS+1d | 54d | 0d | 87/8/19 | 87/8/24 | تن | 87/04/27 | 87/05/05 |
| 2091 | 4.9.2.3 | آرماتور بندي سقف و راه پله همكف | 6d | 2008-12-12 | 2008-12-17 | 2077SS+1d | 54d | 0d | 87/9/22 | 87/9/27 | تن | 87/05/29 | 87/06/07 |
| 2092 | 4.9.2.4 | آرماتور بندي سقف و راه پله طبقه اول | 6d | 2009-01-14 | 2009-01-19 | 2078SS+1d | 61d | 0d | 87/10/25 | 87/10/30 | تن | 87/06/31 | 87/07/09 |
| 2093 | 4.9.2.5 | آرماتور بندي سقف و راه پله طبقه دوم | 6d | 2009-02-16 | 2009-02-21 | 2079SS+1d | 68d | 0d | 87/11/28 | 87/12/3 | تن | 87/08/03 | 87/08/12 |
| 2094 | 4.9.2.6 | آرماتور بندي سقف و راه پله طبقه سوم | 6d | 2009-03-30 | 2009-04-04 | 2080SS+1d | 75d | 0d | 88/1/10 | 88/1/15 | تن | 87/09/06 | 87/09/15 |
| 2095 | 4.9.2.7 | آرماتور بندي سقف و راه پله طبقه چهارم | 6d | 2009-05-02 | 2009-05-07 | 2081SS+1d | 82d | 0d | 88/2/12 | 88/2/17 | تن | 87/10/09 | 87/10/18 |
| 2096 | 4.9.2.8 | آرماتور بندي سقف و راه پله طبقه پنجم | 6d | 2009-06-04 | 2009-06-09 | 2082SS+1d | 88d | 0d | 88/3/14 | 88/3/19 | تن | 87/11/12 | 87/11/21 |
| 2097 | 4.9.2.9 | آرماتور بندي سقف و راه پله طبقه ششم | 6d | 2009-07-07 | 2009-07-12 | 2083SS+1d | 88d | 0d | 88/4/16 | 88/4/21 | تن | 87/12/15 | 87/12/24 |
| 2098 | 4.9.2.10 | آرماتور بندي سقف و راه پله طبقه هفتم | 6d | 2009-08-09 | 2009-08-14 | 2084SS+1d | 93d | 0d | 88/5/18 | 88/5/23 | تن | 88/01/18 | 88/01/27 |
| 2099 | 4.9.2.11 | آرماتور بندي سقف و راه پله طبقه هشتم | 6d | 2009-09-11 | 2009-09-16 | 2085SS+1d | 100d | 0d | 88/6/20 | 88/6/25 | تن | 88/02/20 | 88/02/29 |
| 2100 | 4.9.2.12 | آرماتور بندي سقف و راه پله طبقه نهم | 6d | 2009-10-14 | 2009-10-19 | 2086SS+1d | 107d | 0d | 88/7/22 | 88/7/27 | تن | 88/03/18 | 88/03/27 |
| 2101 | 4.9.2.13 | آرماتور بندي سقف و راه پله طبقه دهم | 6d | 2009-11-16 | 2009-11-21 | 2087SS+1d | 114d | 0d | 88/8/25 | 88/8/30 | تن | 88/04/20 | 88/04/29 |
| 2102 | 4.9.3 | **قالب بندي سقف و راه پله** | 401d | 2008-10-08 | 2009-11-21 |  | 0d |  | 87/7/17 | 88/8/30 |  |  |  |
| 2103 | 4.9.3.1 | قالب بندي سقف و راه پله زيرزمين دوم | 5d | 2008-10-08 | 2008-10-12 | 2089SS+1d | 0d |  | 87/7/17 | 87/7/21 | مترمربع |  |  |
| 2104 | 4.9.3.2 | قالب بندي سقف و راه پله زيرزمين اول | 5d | 2008-11-10 | 2008-11-14 | 2090SS+1d | 54d | 0d | 87/8/20 | 87/8/24 | مترمربع | 87/05/06 | 87/05/10 |
| 2105 | 4.9.3.3 | قالب بندي سقف و راه پله همكف | 5d | 2008-12-13 | 2008-12-17 | 2091SS+1d | 54d | 0d | 87/9/23 | 87/9/27 | مترمربع | 87/06/07 | 87/06/07 |
| 2106 | 4.9.3.4 | قالب بندي سقف و راه پله طبقه اول | 5d | 2009-01-15 | 2009-01-19 | 2092SS+1d | 61d | 0d | 87/10/26 | 87/10/30 | مترمربع | 87/07/09 | 87/07/09 |
| 2107 | 4.9.3.5 | قالب بندي سقف و راه پله طبقه دوم | 5d | 2009-02-17 | 2009-02-21 | 2093SS+1d | 68d | 0d | 87/11/29 | 87/12/3 | مترمربع | 87/08/12 | 87/08/12 |
| 2108 | 4.9.3.6 | قالب بندي سقف و راه پله طبقه سوم | 5d | 2009-03-31 | 2009-04-04 | 2094SS+1d | 75d | 0d | 88/1/11 | 88/1/15 | مترمربع | 87/09/15 | 87/09/15 |
| 2109 | 4.9.3.7 | قالب بندي سقف و راه پله طبقه چهارم | 5d | 2009-05-03 | 2009-05-07 | 2095SS+1d | 82d | 0d | 88/2/13 | 88/2/17 | مترمربع | 87/10/18 | 87/10/18 |
| 2110 | 4.9.3.8 | قالب بندي سقف و راه پله طبقه پنجم | 5d | 2009-06-05 | 2009-06-09 | 2096SS+1d | 88d | 0d | 88/3/15 | 88/3/19 | مترمربع | 87/11/21 | 87/11/21 |
| 2111 | 4.9.3.9 | قالب بندي سقف و راه پله طبقه ششم | 5d | 2009-07-08 | 2009-07-12 | 2097SS+1d | 88d | 0d | 88/4/17 | 88/4/21 | مترمربع | 87/12/24 | 87/12/24 |
| 2112 | 4.9.3.10 | قالب بندي سقف و راه پله طبقه هفتم | 5d | 2009-08-10 | 2009-08-14 | 2098SS+1d | 93d | 0d | 88/5/19 | 88/5/23 | مترمربع | 88/01/27 | 88/01/27 |
| 2113 | 4.9.3.11 | قالب بندي سقف و راه پله طبقه هشتم | 5d | 2009-09-12 | 2009-09-16 | 2099SS+1d | 100d | 0d | 88/6/21 | 88/6/25 | مترمربع | 88/02/30 | 88/02/30 |
| 2114 | 4.9.3.12 | قالب بندي سقف و راه پله طبقه نهم | 5d | 2009-10-15 | 2009-10-19 | 2100SS+1d | 107d | 0d | 88/7/23 | 88/7/27 | مترمربع | 88/03/27 | 88/03/27 |
| 2115 | 4.9.3.13 | قالب بندي سقف و راه پله طبقه دهم | 5d | 2009-11-17 | 2009-11-21 | 2101SS+1d | 114d | 0d | 88/8/26 | 88/8/30 | مترمربع | 88/04/29 | 88/04/29 |

| ID | WBS | Task | Duration | Start | Finish | Predecessors | Total slack | Free slack | Plan Start | Plan Finish | واحد | Text1 | Text2 |
| --- | --- | --- | --- | --- | --- | --- | --- | --- | --- | --- | --- | --- | --- |
| 2116 | 4.9.4 | **بتن ريزي سقف و راه پله** | 399d | 2008-10-13 | 2009-11-24 |  | 0d |  | 87/7/22 | 88/9/3 |  |  |  |
| 2117 | 4.9.4.1 | بتن ريزي سقف و راه پله زيرزمين دوم | 3d | 2008-10-13 | 2008-10-15 | 2103 | 0d |  | 87/7/22 | 87/7/24 | مترمکعب |  |  |
| 2118 | 4.9.4.2 | بتن ريزي سقف و راه پله زيرزمين اول | 3d | 2008-11-15 | 2008-11-17 | 2104 | 54d | 0d | 87/8/25 | 87/8/27 | مترمکعب |  |  |
| 2119 | 4.9.4.3 | بتن ريزي سقف و راه پله همكف | 3d | 2008-12-18 | 2008-12-20 | 2105 | 54d | 0d | 87/9/28 | 87/9/30 | مترمکعب | 87/06/08 | 87/06/12 |
| 2120 | 4.9.4.4 | بتن ريزي سقف و راه پله طبقه اول | 3d | 2009-01-20 | 2009-01-22 | 2106 | 61d | 0d | 87/11/1 | 87/11/3 | مترمکعب | 87/07/10 | 87/07/14 |
| 2121 | 4.9.4.5 | بتن ريزي سقف و راه پله طبقه دوم | 3d | 2009-02-22 | 2009-02-24 | 2107 | 68d | 0d | 87/12/4 | 87/12/6 | مترمکعب | 87/08/13 | 87/08/17 |
| 2122 | 4.9.4.6 | بتن ريزي سقف و راه پله طبقه سوم | 3d | 2009-04-05 | 2009-04-07 | 2108 | 75d | 0d | 88/1/16 | 88/1/18 | مترمکعب | 87/09/16 | 87/09/20 |
| 2123 | 4.9.4.7 | بتن ريزي سقف و راه پله طبقه چهارم | 3d | 2009-05-08 | 2009-05-10 | 2109 | 82d | 0d | 88/2/18 | 88/2/20 | مترمکعب | 87/10/19 | 87/10/23 |
| 2124 | 4.9.4.8 | بتن ريزي سقف و راه پله طبقه پنجم | 3d | 2009-06-10 | 2009-06-12 | 2110 | 88d | 0d | 88/3/20 | 88/3/22 | مترمکعب | 87/11/22 | 87/11/26 |
| 2125 | 4.9.4.9 | بتن ريزي سقف و راه پله طبقه ششم | 3d | 2009-07-13 | 2009-07-15 | 2111 | 88d | 0d | 88/4/22 | 88/4/24 | مترمکعب | 87/12/25 | 87/12/29 |
| 2126 | 4.9.4.10 | بتن ريزي سقف و راه پله طبقه هفتم | 3d | 2009-08-15 | 2009-08-17 | 2112 | 93d | 0d | 88/5/24 | 88/5/26 | مترمکعب | 88/01/28 | 88/02/01 |
| 2127 | 4.9.4.11 | بتن ريزي سقف و راه پله طبقه هشتم | 3d | 2009-09-17 | 2009-09-19 | 2113 | 100d | 0d | 88/6/26 | 88/6/28 | مترمکعب | 88/02/26 | 88/02/30 |
| 2128 | 4.9.4.12 | بتن ريزي سقف و راه پله طبقه نهم | 3d | 2009-10-20 | 2009-10-22 | 2114 | 107d | 0d | 88/7/28 | 88/7/30 | مترمکعب | 88/03/28 | 88/04/01 |
| 2129 | 4.9.4.13 | بتن ريزي سقف و راه پله طبقه دهم | 3d | 2009-11-22 | 2009-11-24 | 2115 | 114d | 0d | 88/9/1 | 88/9/3 | مترمکعب |  |  |
| 2130 | 4.10 | **سفت كاري** | 729d | 2008-10-23 | 2010-11-07 |  | 0d |  | 87/8/2 | 89/8/16 | درصد | 87/07/30 | 88/07/04 |
| 2131 | 4.10.1 | **نبشي كشي نما** | 333d | 2008-12-28 | 2009-12-04 |  | 240d | 18d | 87/10/8 | 88/9/13 |  |  |  |
| 2132 | 4.10.1.1 | نبشي كشي نماي همكف | 3d | 2008-12-28 | 2008-12-30 | 2119FS+7d | 570d |  | 87/10/8 | 87/10/10 |  |  |  |
| 2133 | 4.10.1.2 | نبشي كشي نماي طبقه اول | 3d | 2009-01-30 | 2009-02-01 | 2120FS+7d | 537d |  | 87/11/11 | 87/11/13 |  |  |  |
| 2134 | 4.10.1.3 | نبشي كشي نماي طبقه دوم | 3d | 2009-03-04 | 2009-03-06 | 2121FS+7d | 504d |  | 87/12/14 | 87/12/16 |  |  |  |
| 2135 | 4.10.1.4 | نبشي كشي نماي طبقه سوم | 3d | 2009-04-15 | 2009-04-17 | 2122FS+7d | 471d |  | 88/1/26 | 88/1/28 |  |  |  |
| 2136 | 4.10.1.5 | نبشي كشي نماي طبقه چهارم | 3d | 2009-05-18 | 2009-05-20 | 2123FS+7d | 438d |  | 88/2/28 | 88/2/30 |  |  |  |
| 2137 | 4.10.1.6 | نبشي كشي نماي طبقه پنجم | 3d | 2009-06-20 | 2009-06-22 | 2124FS+7d | 405d |  | 88/3/30 | 88/4/1 |  |  |  |
| 2138 | 4.10.1.7 | نبشي كشي نماي طبقه ششم | 3d | 2009-07-23 | 2009-07-25 | 2125FS+7d | 372d |  | 88/5/1 | 88/5/3 |  |  |  |
| 2139 | 4.10.1.8 | نبشي كشي نماي طبقه هفتم | 3d | 2009-08-25 | 2009-08-27 | 2126FS+7d | 339d |  | 88/6/3 | 88/6/5 |  |  |  |
| 2140 | 4.10.1.9 | نبشي كشي نماي طبقه هشتم | 3d | 2009-09-27 | 2009-09-29 | 2127FS+7d | 306d |  | 88/7/5 | 88/7/7 |  |  |  |
| 2141 | 4.10.1.10 | نبشي كشي نماي طبقه نهم | 3d | 2009-10-30 | 2009-11-01 | 2128FS+7d | 273d |  | 88/8/8 | 88/8/10 |  |  |  |
| 2142 | 4.10.1.11 | نبشي كشي نماي طبقه دهم و خرپشته | 3d | 2009-12-02 | 2009-12-04 | 2129FS+7d | 240d |  | 88/9/11 | 88/9/13 |  |  |  |

| ID | WBS | Task | Duration | Start | Finish | Predecessors | Total slack | Free slack | Text1 | Text2 | واحد | Plan Start | Plan Finish |
| --- | --- | --- | --- | --- | --- | --- | --- | --- | --- | --- | --- | --- | --- |
| 2143 | 4.10.2 | **اجراي ديوارهاي طبقات** | 410d | 2008-10-23 | 2009-12-15 |  | 0d |  | 87/11/16 | 88/07/04 | درصد | 87/8/2 | 88/9/24 |
| 2144 | 4.10.2.1 | اجراي ديوارهاي طبقه زيرزمين دوم | 14d | 2008-10-23 | 2008-11-05 | 2117FS+7d | 0d |  |  |  | مترمربع | 87/8/2 | 87/8/15 |
| 2145 | 4.10.2.2 | اجراي ديوارهاي طبقه زيرزمين اول | 14d | 2008-11-25 | 2008-12-08 | 2118FS+7d, 2144 | 57d | 0d | 87/11/16 | 87/12/05 | مترمربع | 87/9/5 | 87/9/18 |
| 2146 | 4.10.2.3 | اجراي ديوارهاي طبقه همكف | 14d | 2008-12-28 | 2009-01-10 | 2119FS+7d, 2145 | 54d | 0d | 87/12/06 | 87/12/25 | مترمربع | 87/10/8 | 87/10/21 |
| 2147 | 4.10.2.4 | اجراي ديوارهاي طبقه اول | 14d | 2009-01-30 | 2009-02-12 | 2120FS+7d, 2146 | 61d | 0d | 87/12/26 | 88/01/15 | مترمربع | 87/11/11 | 87/11/24 |
| 2148 | 4.10.2.5 | اجراي ديوارهاي طبقه دوم | 14d | 2009-03-04 | 2009-03-17 | 2121FS+7d, 2147 | 68d | 0d | 88/01/16 | 88/02/04 | مترمربع | 87/12/14 | 87/12/27 |
| 2149 | 4.10.2.6 | اجراي ديوارهاي طبقه سوم | 14d | 2009-04-15 | 2009-04-28 | 2122FS+7d, 2148 | 75d | 0d | 88/02/05 | 88/02/24 | مترمربع | 88/1/26 | 88/2/8 |
| 2150 | 4.10.2.7 | اجراي ديوارهاي طبقه چهارم | 14d | 2009-05-18 | 2009-05-31 | 2123FS+7d, 2149 | 82d | 0d | 88/02/25 | 88/03/13 | مترمربع | 88/2/28 | 88/3/10 |
| 2151 | 4.10.2.8 | اجراي ديوارهاي طبقه پنجم | 14d | 2009-06-20 | 2009-07-03 | 2124FS+7d, 2150 | 89d | 0d | 88/03/14 | 88/04/02 | مترمربع | 88/3/30 | 88/4/12 |
| 2152 | 4.10.2.9 | اجراي ديوارهاي طبقه ششم | 14d | 2009-07-23 | 2009-08-05 | 2125FS+7d, 2151 | 88d | 0d | 88/04/03 | 88/04/22 | مترمربع | 88/5/1 | 88/5/14 |
| 2153 | 4.10.2.10 | اجراي ديوارهاي طبقه هفتم | 14d | 2009-08-25 | 2009-09-07 | 2126FS+7d, 2152 | 93d | 0d | 88/04/23 | 88/05/11 | مترمربع | 88/6/3 | 88/6/16 |
| 2154 | 4.10.2.11 | اجراي ديوارهاي طبقه هشتم | 14d | 2009-09-27 | 2009-10-10 | 2127FS+7d, 2153 | 100d | 0d | 88/05/12 | 88/05/31 | مترمربع | 88/7/5 | 88/7/18 |
| 2155 | 4.10.2.12 | اجراي ديوارهاي طبقه نهم | 14d | 2009-10-30 | 2009-11-12 | 2128FS+7d, 2154 | 107d | 0d | 88/06/01 | 88/06/20 | مترمربع | 88/8/8 | 88/8/21 |
| 2156 | 4.10.2.13 | اجراي ديوارهاي طبقه دهم | 14d | 2009-12-02 | 2009-12-15 | 2129FS+7d, 2155 | 114d | 0d | 88/06/21 | 88/07/04 | مترمربع | 88/9/11 | 88/9/24 |
| 2157 | 4.10.3 | **ساخت و نصب چهارجوب درب ها و نعل درگاهها** | 400d | 2008-11-03 | 2009-12-16 |  | 322d |  |  |  |  | 87/8/13 | 88/9/25 |
| 2158 | 4.10.3.1 | ساخت و نصب چهارجوب درب ها و نعل درگاههاي طبقه زير زمين دوم | 4d | 2008-11-03 | 2008-11-06 | 2144FF+1d | 718d |  |  |  |  | 87/8/13 | 87/8/16 |
| 2159 | 4.10.3.2 | ساخت و نصب چهارجوب درب ها و نعل درگاههاي طبقه زيرزمين اول | 4d | 2008-12-06 | 2008-12-09 | 2145FF+1d | 685d |  |  |  |  | 87/9/16 | 87/9/19 |
| 2160 | 4.10.3.3 | ساخت و نصب چهارجوب درب ها و نعل درگاههاي طبقه همكف | 4d | 2009-01-08 | 2009-01-11 | 2146FF+1d | 652d |  |  |  |  | 87/10/19 | 87/10/22 |
| 2161 | 4.10.3.4 | ساخت و نصب چهارجوب درب ها و نعل درگاههاي طبقه اول | 4d | 2009-02-10 | 2009-02-13 | 2147FF+1d | 619d |  |  |  |  | 87/11/22 | 87/11/25 |
| 2162 | 4.10.3.5 | ساخت و نصب چهارجوب درب ها و نعل درگاههاي طبقه دوم | 4d | 2009-03-15 | 2009-03-18 | 2148FF+1d | 586d |  |  |  |  | 87/12/25 | 87/12/28 |
| 2163 | 4.10.3.6 | ساخت و نصب چهارجوب درب ها و نعل درگاههاي طبقه سوم | 4d | 2009-04-26 | 2009-04-29 | 2149FF+1d | 553d |  |  |  |  | 88/2/6 | 88/2/9 |
| 2164 | 4.10.3.7 | ساخت و نصب چهارجوب درب ها و نعل درگاههاي طبقه چهارم | 4d | 2009-05-29 | 2009-06-01 | 2150FF+1d | 520d |  |  |  |  | 88/3/8 | 88/3/11 |
| 2165 | 4.10.3.8 | ساخت و نصب چهارجوب درب ها و نعل درگاههاي طبقه پنجم | 4d | 2009-07-01 | 2009-07-04 | 2151FF+1d | 487d |  |  |  |  | 88/4/10 | 88/4/13 |
| 2166 | 4.10.3.9 | ساخت و نصب چهارجوب درب ها و نعل درگاههاي طبقه ششم | 4d | 2009-08-03 | 2009-08-06 | 2152FF+1d | 454d |  |  |  |  | 88/5/12 | 88/5/15 |
| 2167 | 4.10.3.10 | ساخت و نصب چهارجوب درب ها و نعل درگاههاي طبقه هفتم | 4d | 2009-09-05 | 2009-09-08 | 2153FF+1d | 421d |  |  |  |  | 88/6/14 | 88/6/17 |
| 2168 | 4.10.3.11 | ساخت و نصب چهارجوب درب ها و نعل درگاههاي طبقه هشتم | 4d | 2009-10-08 | 2009-10-11 | 2154FF+1d | 388d |  |  |  |  | 88/7/16 | 88/7/19 |
| 2169 | 4.10.3.12 | ساخت و نصب چهارجوب درب ها و نعل درگاههاي طبقه نهم | 4d | 2009-11-10 | 2009-11-13 | 2155FF+1d | 355d |  |  |  |  | 88/8/19 | 88/8/22 |
| 2170 | 4.10.3.13 | ساخت و نصب چهارجوب درب ها و نعل درگاههاي طبقه دهم و خرپشته | 4d | 2009-12-13 | 2009-12-16 | 2156FF+1d | 322d |  |  |  |  | 88/9/22 | 88/9/25 |

| ID | WBS | Task | Duration | Start | Finish | Predecessors | Total slack | Free slack | Text1 | Text2 | واحد | Plan Start | Plan Finish |
| --- | --- | --- | --- | --- | --- | --- | --- | --- | --- | --- | --- | --- | --- |
| 2171 | 4.10.4 | **اجراي گچ و خاك طبقات** | 396d | 2009-01-11 | 2010-02-19 |  | 54d |  | 87/12/06 | 88/08/09 | درصد | 87/10/22 | 88/11/30 |
| 2172 | 4.10.4.1 | اجراي گچ و خاك طبقه همكف | 30d | 2009-01-11 | 2009-02-09 | 2146, 2328 | 54d | 0d | 88/01/06 | 88/01/25 | مترمربع | 87/10/22 | 87/11/21 |
| 2173 | 4.10.4.2 | اجراي گچ و خاك طبقه اول | 30d | 2009-02-13 | 2009-03-14 | 2147, 2172 | 61d | 0d | 88/01/26 | 88/02/14 | مترمربع | 87/11/25 | 87/12/24 |
| 2174 | 4.10.4.3 | اجراي گچ و خاك طبقه دوم | 30d | 2009-03-18 | 2009-04-25 | 2148, 2173 | 68d | 0d | 88/02/15 | 88/03/03 | مترمربع | 87/12/28 | 88/2/5 |
| 2175 | 4.10.4.4 | اجراي گچ و خاك طبقه سوم | 30d | 2009-04-29 | 2009-05-28 | 2149, 2174 | 75d | 0d | 88/03/04 | 88/03/23 | مترمربع | 88/2/9 | 88/3/7 |
| 2176 | 4.10.4.5 | اجراي گچ و خاك طبقه چهارم | 30d | 2009-06-01 | 2009-06-30 | 2150, 2175 | 82d | 0d | 88/03/24 | 88/04/12 | مترمربع | 88/3/11 | 88/4/9 |
| 2177 | 4.10.4.6 | اجراي گچ و خاك طبقه پنجم | 30d | 2009-07-04 | 2009-08-02 | 2151, 2176 | 89d | 0d | 88/04/13 | 88/05/01 | مترمربع | 88/4/13 | 88/5/11 |
| 2178 | 4.10.4.7 | اجراي گچ و خاك طبقه ششم | 38d | 2009-08-06 | 2009-09-12 | 2152, 2177 | 88d | 0d | 88/05/02 | 88/05/21 | مترمربع | 88/5/15 | 88/6/21 |
| 2179 | 4.10.4.8 | اجراي گچ و خاك طبقه هفتم | 40d | 2009-09-13 | 2009-10-22 | 2153, 2178 | 88d | 0d | 88/05/22 | 88/06/10 | مترمربع | 88/6/22 | 88/7/30 |
| 2180 | 4.10.4.9 | اجراي گچ و خاك طبقه هشتم | 40d | 2009-10-23 | 2009-12-01 | 2154, 2179 | 88d | 0d | 88/06/11 | 88/06/30 | مترمربع | 88/8/1 | 88/9/10 |
| 2181 | 4.10.4.10 | اجراي گچ و خاك طبقه نهم | 40d | 2009-12-02 | 2010-01-10 | 2155, 2180 | 88d | 0d | 88/06/31 | 88/07/19 | مترمربع | 88/9/11 | 88/10/20 |
| 2182 | 4.10.4.11 | اجراي گچ و خاك طبقه دهم و خرپشته | 40d | 2010-01-11 | 2010-02-19 | 2156, 2181 | 88d | 0d | 88/07/20 | 88/08/09 | مترمربع | 88/10/21 | 88/11/30 |
| 2183 | 4.10.5 | **اجراي سقف كاذب طبقات** | 163d | 2010-05-29 | 2010-11-07 |  | 0d |  | 88/02/15 | 88/09/19 | درصد | 89/3/8 | 89/8/16 |
| 2184 | 4.10.5.1 | اجراي سقف كاذب همکف | 20d | 2010-05-29 | 2010-06-17 | 2379, 2407, 2419 | 0d |  | 88/02/15 | 88/03/03 | مترمربع | 89/3/8 | 89/3/27 |
| 2185 | 4.10.5.2 | اجراي سقف كاذب طبقه 1 | 20d | 2010-06-05 | 2010-06-24 | 2380, 2408, 2420 | 140d |  | 88/03/04 | 88/03/23 | مترمربع | 89/3/15 | 89/4/3 |
| 2186 | 4.10.5.3 | اجراي سقف كاذب طبقه 2 | 20d | 2010-06-17 | 2010-07-06 | 2381, 2409, 2421 | 128d |  | 88/03/24 | 88/04/12 | مترمربع | 89/3/27 | 89/4/15 |
| 2187 | 4.10.5.4 | اجراي سقف كاذب طبقه 3 | 20d | 2010-07-02 | 2010-07-21 | 2382, 2410, 2422 | 113d |  | 88/04/13 | 88/05/01 | مترمربع | 89/4/11 | 89/4/30 |
| 2188 | 4.10.5.5 | اجراي سقف كاذب طبقه 4 | 20d | 2010-07-17 | 2010-08-05 | 2383, 2411, 2423 | 98d |  | 88/05/02 | 88/05/21 | مترمربع | 89/4/26 | 89/5/14 |
| 2189 | 4.10.5.6 | اجراي سقف كاذب طبقه 5 | 20d | 2010-08-01 | 2010-08-20 | 2384, 2412, 2424 | 83d |  | 88/05/22 | 88/06/10 | مترمربع | 89/5/10 | 89/5/29 |
| 2190 | 4.10.5.7 | اجراي سقف كاذب طبقه 6 | 20d | 2010-08-16 | 2010-09-04 | 2385, 2413, 2425 | 68d |  | 88/06/11 | 88/06/30 | مترمربع | 89/5/25 | 89/6/13 |
| 2191 | 4.10.5.8 | اجراي سقف كاذب طبقه 7 | 20d | 2010-08-31 | 2010-09-19 | 2386, 2414, 2426 | 53d |  | 88/06/31 | 88/07/19 | مترمربع | 89/6/9 | 89/6/28 |
| 2192 | 4.10.5.9 | اجراي سقف كاذب طبقه 8 | 20d | 2010-09-15 | 2010-10-04 | 2387, 2415, 2427 | 38d |  | 88/07/20 | 88/08/09 | مترمربع | 89/6/24 | 89/7/12 |
| 2193 | 4.10.5.10 | اجراي سقف كاذب طبقه 9 | 20d | 2010-09-30 | 2010-10-19 | 2388, 2416, 2428 | 23d |  | 88/08/10 | 88/08/29 | مترمربع | 89/7/8 | 89/7/27 |
| 2194 | 4.10.5.11 | اجراي سقف كاذب طبقه10 | 22d | 2010-10-17 | 2010-11-07 | 2389, 2417, 2429 | 4d |  | 88/08/30 | 88/09/19 | مترمربع | 89/7/25 | 89/8/16 |

| ID | WBS | Task | Duration | Start | Finish | Predecessors | Total slack | Free slack | Text1 | Text2 | واحد | Plan Start | Plan Finish |
| --- | --- | --- | --- | --- | --- | --- | --- | --- | --- | --- | --- | --- | --- |
| 2195 | 4.10.6 | **اجراي كف سازي نهائی طبقات** | 222d | 2010-02-14 | 2010-10-01 |  | 0d |  | 87/10/06 | 88/10/24 | درصد | 88/11/25 | 89/7/9 |
| 2196 | 4.10.6.1 | اجراي كف سازي طبقه زيرزمين دوم | 20d | 2010-02-14 | 2010-03-05 | 2254 | 0d |  | 88/01/16 | 88/02/04 | مترمربع | 88/11/25 | 88/12/14 |
| 2197 | 4.10.6.2 | اجراي كف سازي طبقه زيرزمين اول | 20d | 2010-03-01 | 2010-03-28 | 2255, 2298 | 218d | 0d | 88/01/16 | 88/02/04 | مترمربع | 88/12/10 | 89/1/8 |
| 2198 | 4.10.6.3 | اجراي كف سازي طبقه همكف | 20d | 2010-04-04 | 2010-04-23 | 2330SS, 2256 | 0d |  | 88/03/24 | 88/04/02 | مترمربع | 89/1/15 | 89/2/3 |
| 2199 | 4.10.6.4 | اجراي كف سازي طبقه اول | 20d | 2010-04-11 | 2010-04-30 | 2331SS, 2256 | 44d | 0d | 88/04/13 | 88/04/22 | مترمربع | 89/1/22 | 89/2/10 |
| 2200 | 4.10.6.5 | اجراي كف سازي طبقه 2 | 20d | 2010-04-23 | 2010-05-12 | 2332SS, 2257 | 42d | 0d | 88/05/02 | 88/05/11 | مترمربع | 89/2/3 | 89/2/22 |
| 2201 | 4.10.6.6 | اجراي كف سازي طبقه 3 | 20d | 2010-05-08 | 2010-05-27 | 2333SS, 2258 | 37d | 0d | 88/05/22 | 88/05/31 | مترمربع | 89/2/18 | 89/3/6 |
| 2202 | 4.10.6.7 | اجراي كف سازي طبقه 4 | 20d | 2010-05-23 | 2010-06-11 | 2334SS, 2259 | 32d | 0d | 88/06/11 | 88/06/20 | مترمربع | 89/3/2 | 89/3/21 |
| 2203 | 4.10.6.8 | اجراي كف سازي طبقه 5 | 20d | 2010-06-07 | 2010-06-26 | 2335SS, 2260 | 27d | 0d | 88/06/31 | 88/07/09 | مترمربع | 89/3/17 | 89/4/5 |
| 2204 | 4.10.6.9 | اجراي كف سازي طبقه 6 | 20d | 2010-06-22 | 2010-07-11 | 2336SS, 2261 | 22d | 0d | 88/07/20 | 88/07/29 | مترمربع | 89/4/1 | 89/4/20 |
| 2205 | 4.10.6.10 | اجراي كف سازي طبقه 7 | 20d | 2010-07-07 | 2010-07-26 | 2337SS, 2262 | 17d | 0d | 88/08/10 | 88/08/19 | مترمربع | 89/4/16 | 89/5/4 |
| 2206 | 4.10.6.11 | اجراي كف سازي طبقه 8 | 20d | 2010-07-22 | 2010-08-10 | 2338SS, 2263 | 12d | 0d | 88/08/30 | 88/09/09 | مترمربع | 89/4/31 | 89/5/19 |
| 2207 | 4.10.6.12 | اجراي كف سازي طبقه 9 | 20d | 2010-08-06 | 2010-08-25 | 2339SS, 2264 | 7d | 0d | 88/09/20 | 88/09/29 | مترمربع | 89/5/15 | 89/6/3 |
| 2208 | 4.10.6.13 | اجراي كف سازي طبقه 10 و خرپشته | 20d | 2010-08-23 | 2010-09-11 | 2340SS, 2265 | 0d |  |  |  | مترمربع | 89/6/1 | 89/6/20 |
| 2209 | 4.10.6.14 | اجراي كف سازي بام | 20d | 2010-09-12 | 2010-10-01 | 2208 | 41d |  | 88/10/10 | 88/10/24 | درصد | 89/6/21 | 89/7/9 |
| 2210 | 4.11 | **فاز اول تاسيسات مكانيكي طبقات** | 558d | 2009-01-25 | 2010-08-22 |  | 0d |  | 87/12/06 | 88/08/19 | درصد | 87/11/6 | 89/5/31 |
| 2211 | 4.11.1 | **لوله كشي فاضلاب ، آب باران ، ونت** | 511d | 2009-01-25 | 2010-07-06 |  | 0d |  | 87/12/06 | 88/07/29 | درصد | 87/11/6 | 89/4/15 |
| 2212 | 4.11.1.1 | لوله كشي زيرزمين دوم | 30d | 2009-01-25 | 2009-02-23 | 2327FS+60d | 0d |  |  |  | مترطول | 87/11/6 | 87/12/5 |
| 2213 | 4.11.1.2 | لوله كشي زيرزمين اول | 30d | 2009-03-06 | 2009-04-13 | 2212FS+10d, 2328FS+10d | 0d |  | 87/12/06 | 87/12/25 | مترطول | 87/12/16 | 88/1/24 |
| 2214 | 4.11.1.3 | لوله كشي طبقه همكف | 30d | 2009-04-24 | 2009-05-23 | 2172FS+10d, 2213FS+10d | 0d |  | 87/12/26 | 88/01/15 | مترطول | 88/2/4 | 88/3/2 |
| 2215 | 4.11.1.4 | لوله كشي طبقه اول | 30d | 2009-06-03 | 2009-07-02 | 2173FS+10d, 2214FS+10d | 0d |  | 88/01/16 | 88/02/04 | مترطول | 88/3/13 | 88/4/11 |
| 2216 | 4.11.1.5 | لوله كشي طبقه دوم | 30d | 2009-07-13 | 2009-08-11 | 2174FS+10d, 2215FS+10d | 0d |  | 88/02/05 | 88/02/24 | مترطول | 88/4/22 | 88/5/20 |
| 2217 | 4.11.1.6 | لوله كشي طبقه سوم | 30d | 2009-08-22 | 2009-09-20 | 2175FS+10d, 2216FS+10d | 0d |  | 88/02/25 | 88/03/13 | مترطول | 88/5/31 | 88/6/29 |
| 2218 | 4.11.1.7 | لوله كشي طبقه چهارم | 30d | 2009-10-01 | 2009-10-30 | 2176FS+10d, 2217FS+10d | 0d |  | 88/03/14 | 88/04/02 | مترطول | 88/7/9 | 88/8/8 |
| 2219 | 4.11.1.8 | لوله كشي طبقه پنجم | 30d | 2009-11-10 | 2009-12-09 | 2177FS+10d, 2218FS+10d | 0d |  | 88/04/03 | 88/04/22 | مترطول | 88/8/19 | 88/9/18 |
| 2220 | 4.11.1.9 | لوله كشي طبقه ششم | 30d | 2009-12-20 | 2010-01-18 | 2178FS+10d, 2219FS+10d | 0d |  | 88/04/23 | 88/05/11 | مترطول | 88/9/29 | 88/10/28 |
| 2221 | 4.11.1.10 | لوله كشي طبقه هفتم | 30d | 2010-01-29 | 2010-02-27 | 2179FS+10d, 2220FS+10d | 0d |  | 88/05/12 | 88/05/31 | مترطول | 88/11/9 | 88/12/8 |
| 2222 | 4.11.1.11 | لوله كشي طبقه هشتم | 30d | 2010-03-10 | 2010-04-16 | 2180FS+10d, 2221FS+10d | 0d |  | 88/06/01 | 88/06/20 | مترطول | 88/12/19 | 89/1/27 |
| 2223 | 4.11.1.12 | لوله كشي طبقه نهم | 30d | 2010-04-27 | 2010-05-26 | 2181FS+10d, 2222FS+10d | 0d |  | 88/06/21 | 88/07/09 | مترطول | 89/2/7 | 89/3/5 |
| 2224 | 4.11.1.13 | لوله كشي طبقه دهم | 31d | 2010-06-06 | 2010-07-06 | 2182FS+10d, 2223FS+10d | 0d |  | 88/07/10 | 88/07/29 | درصد | 89/3/16 | 89/4/15 |

| ID | WBS | Task | Duration | Start | Finish | Predecessors | Total slack | Free slack | Text1 | Text2 | واحد | Plan Start | Plan Finish |
| --- | --- | --- | --- | --- | --- | --- | --- | --- | --- | --- | --- | --- | --- |
| 2225 | 4.11.2 | **لوله كشي تهويه طبقات** | 516d | 2009-01-30 | 2010-07-16 |  | 118d |  | 87/12/06 | 88/07/29 | درصد | 87/11/11 | 89/4/25 |
| 2226 | 4.11.2.1 | لوله كشي تهويه طبقه زيرزمين دوم | 30d | 2009-01-30 | 2009-02-28 | 2212SS+5d | 604d |  |  |  | مترطول | 87/11/11 | 87/12/10 |
| 2227 | 4.11.2.2 | لوله كشي تهويه طبقه زيرزمين اول | 30d | 2009-03-16 | 2009-04-23 | 2213SS+10d | 559d |  | 87/12/06 | 87/12/25 | مترطول | 87/12/26 | 88/2/3 |
| 2228 | 4.11.2.3 | لوله كشي تهويه طبقه همكف | 30d | 2009-05-04 | 2009-06-02 | 2214SS+10d | 297d |  | 87/12/26 | 88/01/15 | مترطول | 88/2/14 | 88/3/12 |
| 2229 | 4.11.2.4 | لوله كشي تهويه طبقه اول | 30d | 2009-06-13 | 2009-07-12 | 2215SS+10d | 308d | 264d | 88/01/16 | 88/02/04 | مترطول | 88/3/23 | 88/4/21 |
| 2230 | 4.11.2.5 | لوله كشي تهويه طبقه دوم | 30d | 2009-07-23 | 2009-08-21 | 2216SS+10d | 278d | 236d | 88/02/05 | 88/02/24 | مترطول | 88/5/1 | 88/5/30 |
| 2231 | 4.11.2.6 | لوله كشي تهويه طبقه سوم | 30d | 2009-09-01 | 2009-09-30 | 2217SS+10d | 248d | 211d | 88/02/25 | 88/03/13 | مترطول | 88/6/10 | 88/7/8 |
| 2232 | 4.11.2.7 | لوله كشي تهويه طبقه چهارم | 30d | 2009-10-11 | 2009-11-09 | 2218SS+10d | 218d | 186d | 88/03/14 | 88/04/02 | مترطول | 88/7/19 | 88/8/18 |
| 2233 | 4.11.2.8 | لوله كشي تهويه طبقه پنجم | 30d | 2009-11-20 | 2009-12-19 | 2219SS+10d | 188d | 161d | 88/04/03 | 88/04/22 | مترطول | 88/8/29 | 88/9/28 |
| 2234 | 4.11.2.9 | لوله كشي تهويه طبقه ششم | 30d | 2009-12-30 | 2010-01-28 | 2220SS+10d | 158d | 136d | 88/04/23 | 88/05/11 | مترطول | 88/10/9 | 88/11/8 |
| 2235 | 4.11.2.10 | لوله كشي تهويه طبقه هفتم | 30d | 2010-02-08 | 2010-03-09 | 2221SS+10d | 128d | 111d | 88/05/12 | 88/05/31 | مترطول | 88/11/19 | 88/12/18 |
| 2236 | 4.11.2.11 | لوله كشي تهويه طبقه هشتم | 30d | 2010-03-28 | 2010-04-26 | 2222SS+10d | 98d | 86d | 88/06/01 | 88/06/20 | مترطول | 89/1/8 | 89/2/6 |
| 2237 | 4.11.2.12 | لوله كشي تهويه طبقه نهم | 30d | 2010-05-07 | 2010-06-05 | 2223SS+10d | 68d | 61d | 88/06/21 | 88/07/09 | مترطول | 89/2/17 | 89/3/15 |
| 2238 | 4.11.2.13 | لوله كشي تهويه طبقه دهم | 31d | 2010-06-16 | 2010-07-16 | 2224SS+10d | 37d |  | 88/07/10 | 88/07/29 | درصد | 89/3/26 | 89/4/25 |
| 2239 | 4.11.3 | **اجراي لوله كشي آتش نشاني و نصب جعبه ها** | 91d | 2010-03-06 | 2010-06-12 |  | 0d |  | 87/12/06 | 88/07/29 | درصد | 88/12/15 | 89/3/22 |
| 2240 | 4.11.3.1 | اجراي لوله آتش نشاني و نصب جعبه هاي زيرزمين دوم | 7d | 2010-03-06 | 2010-03-12 | 2196 | 0d |  |  |  | درصد | 88/12/15 | 88/12/21 |
| 2241 | 4.11.3.2 | اجراي لوله آتش نشاني و نصب جعبه هاي زيرزمين اول | 7d | 2010-03-13 | 2010-03-27 | 2240, 2328 | 0d |  | 87/12/06 | 87/12/25 | درصد | 88/12/22 | 89/1/7 |
| 2242 | 4.11.3.3 | اجراي لوله آتش نشاني و نصب جعبه هاي طبقه همكف | 7d | 2010-03-28 | 2010-04-03 | 2172, 2241 | 0d |  | 87/12/26 | 88/01/15 | درصد | 89/1/8 | 89/1/14 |
| 2243 | 4.11.3.4 | اجراي لوله آتش نشاني و نصب جعبه هاي طبقه اول | 7d | 2010-04-04 | 2010-04-10 | 2173, 2242 | 44d | 0d | 88/01/16 | 88/02/04 | درصد | 89/1/15 | 89/1/21 |
| 2244 | 4.11.3.5 | اجراي لوله آتش نشاني و نصب جعبه هاي طبقه دوم | 7d | 2010-04-11 | 2010-04-17 | 2174, 2243 | 47d | 0d | 88/02/05 | 88/02/24 | درصد | 89/1/22 | 89/1/28 |
| 2245 | 4.11.3.6 | اجراي لوله آتش نشاني و نصب جعبه هاي طبقه سوم | 7d | 2010-04-18 | 2010-04-24 | 2175, 2244 | 50d | 0d | 88/02/25 | 88/03/13 | درصد | 89/1/29 | 89/2/4 |
| 2246 | 4.11.3.7 | اجراي لوله آتش نشاني و نصب جعبه هاي طبقه جهارم | 7d | 2010-04-25 | 2010-05-01 | 2176, 2245 | 53d | 0d | 88/03/14 | 88/04/02 | درصد | 89/2/5 | 89/2/11 |
| 2247 | 4.11.3.8 | اجراي لوله آتش نشاني و نصب جعبه هاي طبقه پنجم | 7d | 2010-05-02 | 2010-05-08 | 2177, 2246 | 56d | 0d | 88/04/03 | 88/04/22 | درصد | 89/2/12 | 89/2/18 |
| 2248 | 4.11.3.9 | اجراي لوله آتش نشاني و نصب جعبه هاي طبقه ششم | 7d | 2010-05-09 | 2010-05-15 | 2178, 2247 | 59d | 0d | 88/04/23 | 88/05/11 | درصد | 89/2/19 | 89/2/25 |
| 2249 | 4.11.3.10 | اجراي لوله آتش نشاني و نصب جعبه هاي طبقه هفتم | 7d | 2010-05-16 | 2010-05-22 | 2179, 2248 | 62d | 0d | 88/05/12 | 88/05/31 | درصد | 89/2/26 | 89/3/1 |
| 2250 | 4.11.3.11 | اجراي لوله آتش نشاني و نصب جعبه هاي طبقه هشتم | 7d | 2010-05-23 | 2010-05-29 | 2180, 2249 | 65d | 0d | 88/06/01 | 88/06/20 | درصد | 89/3/2 | 89/3/8 |
| 2251 | 4.11.3.12 | اجراي لوله آتش نشاني و نصب جعبه هاي طبقه نهم | 7d | 2010-05-30 | 2010-06-05 | 2181, 2250 | 68d | 0d | 88/06/21 | 88/07/09 | درصد | 89/3/9 | 89/3/15 |
| 2252 | 4.11.3.13 | اجراي لوله آتش نشاني و نصب جعبه هاي طبقه دهم | 7d | 2010-06-06 | 2010-06-12 | 2182, 2251 | 71d |  | 88/07/10 | 88/07/29 | درصد | 89/3/16 | 89/3/22 |

| ID | WBS | Task | Duration | Start | Finish | Predecessors | Total slack | Text1 | Text2 | واحد | Plan Start | Plan Finish |
| --- | --- | --- | --- | --- | --- | --- | --- | --- | --- | --- | --- | --- |
| 2253 | 4.11.4 | **لوله كشي سرد و گرم طبقات** | 197d | 2010-01-30 | 2010-08-22 |  | 0d | 87/12/06 | 88/07/29 | درصد | 88/11/10 | 89/5/31 |
| 2254 | 4.11.4.1 | لوله كشي سرد و گرم زيرزمين دوم | 15d | 2010-01-30 | 2010-02-14 | 2327, 2311, 2255SF | 0d |  |  | مترطول | 88/11/10 | 88/11/25 |
| 2255 | 4.11.4.2 | لوله كشي سرد و گرم زيرزمين اول | 15d | 2010-02-14 | 2010-03-01 | 2328, 2312, 2256SF | 0d | 87/12/06 | 87/12/25 | مترطول | 88/11/25 | 88/12/10 |
| 2256 | 4.11.4.3 | لوله كشي سرد و گرم طبقه همكف | 15d | 2010-03-01 | 2010-03-16 | 2172, 2313, 2257SF | 0d | 87/12/26 | 88/01/15 | مترطول | 88/12/10 | 88/12/25 |
| 2257 | 4.11.4.4 | لوله كشي سرد و گرم طبقه اول | 15d | 2010-03-16 | 2010-04-08 | 2173, 2314, 2258SF | 0d | 88/01/16 | 88/02/04 | مترطول | 88/12/25 | 89/1/19 |
| 2258 | 4.11.4.5 | لوله كشي سرد و گرم طبقه دوم | 15d | 2010-04-08 | 2010-04-23 | 2174, 2315, 2259SF | 0d | 88/02/05 | 88/02/24 | مترطول | 89/1/19 | 89/2/3 |
| 2259 | 4.11.4.6 | لوله كشي سرد و گرم طبقه سوم | 15d | 2010-04-23 | 2010-05-08 | 2175, 2316, 2260SF | 0d | 88/02/25 | 88/03/13 | مترطول | 89/2/3 | 89/2/18 |
| 2260 | 4.11.4.7 | لوله كشي سرد و گرم طبقه چهارم | 15d | 2010-05-08 | 2010-05-23 | 2176, 2317, 2261SF | 0d | 88/03/14 | 88/04/02 | مترطول | 89/2/18 | 89/3/2 |
| 2261 | 4.11.4.8 | لوله كشي سرد و گرم طبقه پنجم | 15d | 2010-05-23 | 2010-06-07 | 2177, 2318, 2262SF | 0d | 88/04/03 | 88/04/22 | مترطول | 89/3/2 | 89/3/17 |
| 2262 | 4.11.4.9 | لوله كشي سرد و گرم طبقه ششم | 15d | 2010-06-07 | 2010-06-22 | 2178, 2319, 2263SF | 0d | 88/04/23 | 88/05/11 | مترطول | 89/3/17 | 89/4/1 |
| 2263 | 4.11.4.10 | لوله كشي سرد و گرم طبقه هفتم | 15d | 2010-06-22 | 2010-07-07 | 2179, 2320, 2264SF | 0d | 88/05/12 | 88/05/31 | مترطول | 89/4/1 | 89/4/16 |
| 2264 | 4.11.4.11 | لوله كشي سرد و گرم طبقه هشتم | 15d | 2010-07-07 | 2010-07-22 | 2180, 2321, 2265SF | 0d | 88/06/01 | 88/06/20 | مترطول | 89/4/16 | 89/4/31 |
| 2265 | 4.11.4.12 | لوله كشي سرد و گرم طبقه نهم | 15d | 2010-07-22 | 2010-08-06 | 2181, 2322, 2266SF | 0d | 88/06/21 | 88/07/09 | مترطول | 89/4/31 | 89/5/15 |
| 2266 | 4.11.4.13 | لوله كشي سرد و گرم طبقه دهم | 17d | 2010-08-06 | 2010-08-22 | 2182, 2323 | 0d | 88/07/10 | 88/07/29 | مترطول | 89/5/15 | 89/5/31 |
| 2267 | 4.11.5 | **لوله كشي گرمايش طبقات** | 197d | 2010-01-30 | 2010-08-22 |  | 0d | 87/12/06 | 88/07/29 | درصد | 88/11/10 | 89/5/31 |
| 2268 | 4.11.5.1 | لوله كشي گرمايش زيرزمين دوم | 15d | 2010-01-30 | 2010-02-13 | 2254SS | 0d |  |  | مترطول | 88/11/10 | 88/11/24 |
| 2269 | 4.11.5.2 | لوله كشي گرمايش زيرزمين اول | 15d | 2010-02-14 | 2010-02-28 | 2255SS, 2268, 2328 | 0d | 87/12/06 | 87/12/25 | مترطول | 88/11/25 | 88/12/9 |
| 2270 | 4.11.5.3 | لوله كشي گرمايش طبقه همكف | 15d | 2010-03-01 | 2010-03-15 | 2172, 2256SS, 2269 | 0d | 87/12/26 | 88/01/15 | مترطول | 88/12/10 | 88/12/24 |
| 2271 | 4.11.5.4 | لوله كشي گرمايش طبقه اول | 15d | 2010-03-16 | 2010-04-07 | 2173, 2257SS, 2270 | 0d | 88/01/16 | 88/02/04 | مترطول | 88/12/25 | 89/1/18 |
| 2272 | 4.11.5.5 | لوله كشي گرمايش طبقه دوم | 15d | 2010-04-08 | 2010-04-22 | 2174, 2258SS, 2271 | 0d | 88/02/05 | 88/02/24 | مترطول | 89/1/19 | 89/2/2 |
| 2273 | 4.11.5.6 | لوله كشي گرمايش طبقه سوم | 15d | 2010-04-23 | 2010-05-07 | 2175, 2259SS, 2272 | 0d | 88/02/25 | 88/03/13 | مترطول | 89/2/3 | 89/2/17 |
| 2274 | 4.11.5.7 | لوله كشي گرمايش طبقه چهارم | 15d | 2010-05-08 | 2010-05-22 | 2176, 2260SS, 2273 | 0d | 88/03/14 | 88/04/02 | مترطول | 89/2/18 | 89/3/1 |
| 2275 | 4.11.5.8 | لوله كشي گرمايش طبقه پنجم | 15d | 2010-05-23 | 2010-06-06 | 2177, 2261SS, 2274 | 0d | 88/04/03 | 88/04/22 | مترطول | 89/3/2 | 89/3/16 |
| 2276 | 4.11.5.9 | لوله كشي گرمايش طبقه ششم | 15d | 2010-06-07 | 2010-06-21 | 2178, 2262SS, 2275 | 0d | 88/04/23 | 88/05/11 | مترطول | 89/3/17 | 89/3/31 |
| 2277 | 4.11.5.10 | لوله كشي گرمايش طبقه هفتم | 15d | 2010-06-22 | 2010-07-06 | 2179, 2263SS, 2276 | 0d | 88/05/12 | 88/05/31 | مترطول | 89/4/1 | 89/4/15 |
| 2278 | 4.11.5.11 | لوله كشي گرمايش طبقه هشتم | 15d | 2010-07-07 | 2010-07-21 | 2180, 2264SS, 2277 | 0d | 88/06/01 | 88/06/20 | مترطول | 89/4/16 | 89/4/30 |
| 2279 | 4.11.5.12 | لوله كشي گرمايش طبقه نهم | 15d | 2010-07-22 | 2010-08-05 | 2181, 2265SS, 2278 | 0d | 88/06/21 | 88/07/09 | مترطول | 89/4/31 | 89/5/14 |
| 2280 | 4.11.5.13 | لوله كشي گرمايش طبقه دهم | 17d | 2010-08-06 | 2010-08-22 | 2182, 2266SS, 2279 | 0d | 88/07/10 | 88/07/29 | مترطول | 89/5/15 | 89/5/31 |

| ID | WBS | Task | Duration | Start | Finish | Predecessors | Total slack | Free slack | Text1 | Text2 | واحد | Plan Start | Plan Finish |
| --- | --- | --- | --- | --- | --- | --- | --- | --- | --- | --- | --- | --- | --- |
| 2281 | 4.11.6 | **لوله كشي سرمايش(سيستم اسپليت) طبقات** | 197d | 2010-01-30 | 2010-08-22 |  | 0d |  | 87/12/06 | 88/07/29 | درصد | 88/11/10 | 89/5/31 |
| 2282 | 4.11.6.1 | لوله كشي سرمايش(سيستم اسپليت) زيرزمين دوم | 15d | 2010-01-30 | 2010-02-13 | 2268SS, 2327 | 0d |  |  |  | مترطول | 88/11/10 | 88/11/24 |
| 2283 | 4.11.6.2 | لوله كشي سرمايش(سيستم اسپليت )زيرزمين اول | 15d | 2010-02-14 | 2010-02-28 | 2282, 2328 | 0d |  | 87/12/06 | 87/12/25 | مترطول | 88/11/25 | 88/12/9 |
| 2284 | 4.11.6.3 | لوله كشي سرمايش(سيستم اسپليت ) طبقه همكف | 15d | 2010-03-01 | 2010-03-15 | 2172, 2283 | 0d |  | 87/12/26 | 88/01/15 | مترطول | 88/12/10 | 88/12/24 |
| 2285 | 4.11.6.4 | لوله كشي سرمايش(سيستم اسپليت )طبقه اول | 15d | 2010-03-16 | 2010-04-07 | 2173, 2284 | 0d |  | 88/01/16 | 88/02/04 | مترطول | 88/12/25 | 89/1/18 |
| 2286 | 4.11.6.5 | لوله كشي سرمايش(سيستم اسپليت ) طبقه دوم | 15d | 2010-04-08 | 2010-04-22 | 2174, 2285 | 0d |  | 88/02/05 | 88/02/24 | مترطول | 89/1/19 | 89/2/2 |
| 2287 | 4.11.6.6 | لوله كشي سرمايش(سيستم اسپليت ) طبقه سوم | 15d | 2010-04-23 | 2010-05-07 | 2175, 2286 | 0d |  | 88/02/25 | 88/03/13 | مترطول | 89/2/3 | 89/2/17 |
| 2288 | 4.11.6.7 | لوله كشي سرمايش(سيستم اسپليت ) طبقه چهارم | 15d | 2010-05-08 | 2010-05-22 | 2176, 2287 | 0d |  | 88/03/14 | 88/04/02 | مترطول | 89/2/18 | 89/3/1 |
| 2289 | 4.11.6.8 | لوله كشي سرمايش(سيستم اسپليت )طبقه پنجم | 15d | 2010-05-23 | 2010-06-06 | 2177, 2288 | 0d |  | 88/04/03 | 88/04/22 | مترطول | 89/3/2 | 89/3/16 |
| 2290 | 4.11.6.9 | لوله كشي سرمايش(سيستم اسپليت ) طبقه ششم | 15d | 2010-06-07 | 2010-06-21 | 2178, 2289 | 0d |  | 88/04/23 | 88/05/11 | مترطول | 89/3/17 | 89/3/31 |
| 2291 | 4.11.6.10 | لوله كشي سرمايش(سيستم اسپليت ) طبقه هفتم | 15d | 2010-06-22 | 2010-07-06 | 2179, 2290 | 0d |  | 88/05/12 | 88/05/31 | مترطول | 89/4/1 | 89/4/15 |
| 2292 | 4.11.6.11 | لوله كشي سرمايش(سيستم اسپليت )طبقه هشتم | 15d | 2010-07-07 | 2010-07-21 | 2180, 2291 | 0d |  | 88/06/01 | 88/06/20 | مترطول | 89/4/16 | 89/4/30 |
| 2293 | 4.11.6.12 | لوله كشي سرمايش(سيستم اسپليت )طبقه نهم | 15d | 2010-07-22 | 2010-08-05 | 2181, 2292 | 0d |  | 88/06/21 | 88/07/09 | مترطول | 89/4/31 | 89/5/14 |
| 2294 | 4.11.6.13 | لوله كشي سرمايش(سيستم اسپليت )طبقه دهم | 17d | 2010-08-06 | 2010-08-22 | 2182, 2293 | 0d |  | 88/07/10 | 88/07/29 | مترطول | 89/5/15 | 89/5/31 |
| 2295 | 4.12 | **فاز اول تاسيسات برقي طبقات** | 601d | 2008-11-26 | 2010-08-05 |  | 17d |  | 87/12/06 | 88/07/29 | درصد | 87/9/6 | 89/5/14 |
| 2296 | 4.12.1 | **اجراي سيستم ارت بندي طبقات** | 457d | 2008-11-26 | 2010-03-06 |  | 161d |  |  |  |  | 87/9/6 | 88/12/15 |
| 2297 | 4.12.1.1 | اجراي سيستم ارت بندي( زيرزمين دوم ) | 15d | 2008-11-26 | 2008-12-10 | 2327 | 423d | 18d |  |  | درصد | 87/9/6 | 87/9/20 |
| 2298 | 4.12.1.2 | اجراي سيستم ارت بندي( زيرزمين اول ) | 15d | 2008-12-29 | 2009-01-12 | 2297, 2328 | 405d | 28d | 87/12/06 | 87/12/25 | درصد | 87/10/9 | 87/10/23 |
| 2299 | 4.12.1.3 | اجراي سيستم ارت بندي( همكف ) | 15d | 2009-02-10 | 2009-02-24 | 2172, 2298 | 377d | 18d | 87/12/26 | 88/01/15 | درصد | 87/11/22 | 87/12/6 |
| 2300 | 4.12.1.4 | اجراي سيستم ارت بندي طبقه اول | 15d | 2009-03-15 | 2009-04-07 | 2173, 2299 | 359d | 18d | 88/01/16 | 88/02/04 | درصد | 87/12/25 | 88/1/18 |
| 2301 | 4.12.1.5 | اجراي سيستم ارت بندي طبقه دوم | 15d | 2009-04-26 | 2009-05-10 | 2174, 2300 | 341d | 18d | 88/02/05 | 88/02/24 | درصد | 88/2/6 | 88/2/20 |
| 2302 | 4.12.1.6 | اجراي سيستم ارت بندي طبقه سوم | 15d | 2009-05-29 | 2009-06-12 | 2175, 2301 | 323d | 18d | 88/02/25 | 88/03/13 | درصد | 88/3/8 | 88/3/22 |
| 2303 | 4.12.1.7 | اجراي سيستم ارت بندي طبقه چهارم | 15d | 2009-07-01 | 2009-07-15 | 2176, 2302 | 305d | 18d | 88/03/14 | 88/04/02 | درصد | 88/4/10 | 88/4/24 |
| 2304 | 4.12.1.8 | اجراي سيستم ارت بندي طبقه پنجم | 15d | 2009-08-03 | 2009-08-17 | 2177, 2303 | 287d | 26d | 88/04/03 | 88/04/22 | درصد | 88/5/12 | 88/5/26 |
| 2305 | 4.12.1.9 | اجراي سيستم ارت بندي طبقه ششم | 15d | 2009-09-13 | 2009-09-27 | 2178, 2304 | 261d | 25d | 88/04/23 | 88/05/11 | درصد | 88/6/22 | 88/7/5 |
| 2306 | 4.12.1.10 | اجراي سيستم ارت بندي طبقه هفتم | 15d | 2009-10-23 | 2009-11-06 | 2179, 2305 | 236d | 25d | 88/05/12 | 88/05/31 | درصد | 88/8/1 | 88/8/15 |
| 2307 | 4.12.1.11 | اجراي سيستم ارت بندي طبقه هشتم | 15d | 2009-12-02 | 2009-12-16 | 2180, 2306 | 211d | 25d | 88/06/01 | 88/06/20 | درصد | 88/9/11 | 88/9/25 |
| 2308 | 4.12.1.12 | اجراي سيستم ارت بندي طبقه نهم | 15d | 2010-01-11 | 2010-01-25 | 2181, 2307 | 186d | 25d | 88/06/21 | 88/07/09 | درصد | 88/10/21 | 88/11/5 |
| 2309 | 4.12.1.13 | اجراي سيستم ارت بندي طبقه دهم | 15d | 2010-02-20 | 2010-03-06 | 2182, 2308 | 161d |  | 88/07/10 | 88/07/29 | درصد | 88/12/1 | 88/12/15 |

| ID | WBS | Task | Duration | Start | Finish | Predecessors | Total slack | Free slack | Plan Start | Plan Finish | واحد | Text1 | Text2 |
| --- | --- | --- | --- | --- | --- | --- | --- | --- | --- | --- | --- | --- | --- |
| 2310 | 4.12.2 | **لوله گذاري و نصب قوطي كليد و پريز طبقات** | 481d | 2009-04-04 | 2010-08-05 |  | 0d |  | 88/1/15 | 89/5/14 |  |  |  |
| 2311 | 4.12.2.1 | لوله گذاري و نصب قوطي كليد و پريز( زيرزمين دوم ) | 30d | 2009-04-04 | 2009-05-03 | 2212, 2327FS+120d | 91d | 0d | 88/1/15 | 88/2/13 | درصد |  |  |
| 2312 | 4.12.2.2 | لوله گذاري و نصب قوطي كليد و پريز( زيرزمين اول ) | 30d | 2009-05-04 | 2009-06-02 | 2213, 2311, 2328FS+10d | 91d | 0d | 88/2/14 | 88/3/12 | درصد | 87/12/06 | 87/12/25 |
| 2313 | 4.12.2.3 | لوله گذاري و نصب قوطي كليد و پريز( همكف ) | 30d | 2009-06-03 | 2009-07-02 | 2172FS+10d, 2214, 2312 | 91d | 0d | 88/3/13 | 88/4/11 | درصد | 87/12/26 | 88/01/15 |
| 2314 | 4.12.2.4 | لوله گذاري و نصب قوطي كليد و پريز 1 | 30d | 2009-07-03 | 2009-08-01 | 2173FS+10d, 2215, 2313 | 91d | 10d | 88/4/12 | 88/5/10 | درصد | 88/01/16 | 88/02/04 |
| 2315 | 4.12.2.5 | لوله گذاري و نصب قوطي كليد و پريز 2 | 30d | 2009-08-12 | 2009-09-10 | 2174FS+10d, 2216, 2314 | 81d | 10d | 88/5/21 | 88/6/19 | درصد | 88/02/05 | 88/02/24 |
| 2316 | 4.12.2.6 | لوله گذاري و نصب قوطي كليد و پريز 3 | 30d | 2009-09-21 | 2009-10-20 | 2175FS+10d, 2217, 2315 | 71d | 10d | 88/6/30 | 88/7/28 | درصد | 88/02/25 | 88/03/13 |
| 2317 | 4.12.2.7 | لوله گذاري و نصب قوطي كليد و پريز 4 | 30d | 2009-10-31 | 2009-11-29 | 2176FS+10d, 2218, 2316 | 61d | 10d | 88/8/9 | 88/9/8 | درصد | 88/03/14 | 88/04/02 |
| 2318 | 4.12.2.8 | لوله گذاري و نصب قوطي كليد و پريز 5 | 30d | 2009-12-10 | 2010-01-08 | 2177FS+10d, 2219, 2317 | 51d | 10d | 88/9/19 | 88/10/18 | درصد | 88/04/03 | 88/04/22 |
| 2319 | 4.12.2.9 | لوله گذاري و نصب قوطي كليد و پريز 6 | 30d | 2010-01-19 | 2010-02-17 | 2178FS+10d, 2220, 2318 | 41d | 10d | 88/10/29 | 88/11/28 | درصد | 88/04/23 | 88/05/11 |
| 2320 | 4.12.2.10 | لوله گذاري و نصب قوطي كليد و پريز 7 | 30d | 2010-02-28 | 2010-04-06 | 2179FS+10d, 2221, 2319 | 31d | 10d | 88/12/9 | 89/1/17 | درصد | 88/05/12 | 88/05/31 |
| 2321 | 4.12.2.11 | لوله گذاري و نصب قوطي كليد و پريز 8 | 30d | 2010-04-17 | 2010-05-16 | 2180FS+10d, 2222, 2320 | 21d | 10d | 89/1/28 | 89/2/26 | درصد | 88/06/01 | 88/06/20 |
| 2322 | 4.12.2.12 | لوله گذاري و نصب قوطي كليد و پريز 9 | 30d | 2010-05-27 | 2010-06-25 | 2181FS+10d, 2223, 2321 | 11d |  | 89/3/6 | 89/4/4 | درصد | 88/06/21 | 88/07/09 |
| 2323 | 4.12.2.13 | لوله گذاري و نصب قوطي كليد و پريز 10 | 30d | 2010-07-07 | 2010-08-05 | 2182FS+10d, 2224, 2322 | 0d |  | 89/4/16 | 89/5/14 | درصد | 88/07/10 | 88/07/29 |
| 2324 | 4.13 | **نازك كاري** | 711d | 2008-11-06 | 2010-11-03 |  | 0d |  | 87/8/16 | 89/8/12 | درصد | 87/10/06 | 88/12/04 |
| 2325 | 4.13.1 | اجراي بتن كف پاركينگ و كفسازي | 10d | 2010-02-14 | 2010-02-23 | 2254, 2297 | 233d | 0d | 88/11/25 | 88/12/4 | درصد | 87/10/06 | 88/02/04 |
| 2326 | 4.13.2 | **سيمانكاري آستر و رويه زيرزمين پاركينگ** | 53d | 2008-11-06 | 2008-12-28 |  | 0d |  | 87/8/16 | 87/10/8 |  |  |  |
| 2327 | 4.13.2.1 | سيمانكاري آستر و رويه زيرزمين دوم | 20d | 2008-11-06 | 2008-11-25 | 2144 | 0d |  | 87/8/16 | 87/9/5 | مترمربع |  |  |
| 2328 | 4.13.2.2 | سيمانكاري آستر و رويه زيرزمين اول | 20d | 2008-12-09 | 2008-12-28 | 2145, 2327 | 57d | 0d | 87/9/19 | 87/10/8 | مترمربع | 87/12/06 | 87/12/25 |
| 2329 | 4.13.3 | **پلاستر سيمان سرويسها،آشپزخانه ها،،بالكن هاو…** | 151d | 2010-04-04 | 2010-09-01 |  | 0d |  | 89/1/15 | 89/6/10 |  |  |  |
| 2330 | 4.13.3.1 | پلاستر سيمان سرويسها،آشپزخانه هاو،بالكن هاي طبقه همكف | 10d | 2010-04-04 | 2010-04-13 | 2214, 2228, 2242, 2256, 2270, 2284, 2299, 2313 | 0d |  | 89/1/15 | 89/1/24 | متر مربع |  |  |
| 2331 | 4.13.3.2 | پلاستر سيمان سرويسها،آشپزخانه هاو،بالكن هاي طبقه اول | 10d | 2010-04-11 | 2010-04-20 | 2215, 2229, 2243, 2257, 2271, 2285, 2300, 2314 | 44d | 0d | 89/1/22 | 89/1/31 | متر مربع |  |  |
| 2332 | 4.13.3.3 | پلاستر سيمان سرويسها،آشپزخانه هاو،بالكن هاي طبقه دوم | 10d | 2010-04-23 | 2010-05-02 | 2216, 2230, 2244, 2258, 2272, 2286, 2301, 2315 | 42d | 0d | 89/2/3 | 89/2/12 | متر مربع |  |  |
| 2333 | 4.13.3.4 | پلاستر سيمان سرويسها،آشپزخانه هاو،بالكن هاي طبقه سوم | 10d | 2010-05-08 | 2010-05-17 | 2217, 2231, 2245, 2259, 2273, 2287, 2302, 2316 | 37d | 0d | 89/2/18 | 89/2/27 | متر مربع |  |  |
| 2334 | 4.13.3.5 | پلاستر سيمان سرويسها،آشپزخانه هاو،بالكن هاي طبقه چهارم | 10d | 2010-05-23 | 2010-06-01 | 2218, 2232, 2246, 2260, 2274, 2288, 2303, 2317 | 32d | 0d | 89/3/2 | 89/3/11 | متر مربع |  |  |
| 2335 | 4.13.3.6 | پلاستر سيمان سرويسها،آشپزخانه هاو،بالكن هاي طبقه پنجم | 10d | 2010-06-07 | 2010-06-16 | 2219, 2233, 2247, 2261, 2275, 2289, 2304, 2318 | 27d | 0d | 89/3/17 | 89/3/26 | متر مربع |  |  |
| 2336 | 4.13.3.7 | پلاستر سيمان سرويسها،آشپزخانه هاو،بالكن هاي طبقه ششم | 10d | 2010-06-22 | 2010-07-01 | 2220, 2234, 2248, 2262, 2276, 2290, 2305, 2319 | 22d | 0d | 89/4/1 | 89/4/10 | متر مربع |  |  |
| 2337 | 4.13.3.8 | پلاستر سيمان سرويسها،آشپزخانه هاو،بالكن هاي طبقه هفتم | 10d | 2010-07-07 | 2010-07-16 | 2221, 2235, 2249, 2263, 2277, 2291, 2306, 2320 | 17d | 0d | 89/4/16 | 89/4/25 | متر مربع |  |  |
| 2338 | 4.13.3.9 | پلاستر سيمان سرويسها،آشپزخانه هاو،بالكن هاي طبقه هشتم | 10d | 2010-07-22 | 2010-07-31 | 2222, 2236, 2250, 2264, 2278, 2292, 2307, 2321 | 12d | 0d | 89/4/31 | 89/5/9 | متر مربع |  |  |
| 2339 | 4.13.3.10 | پلاستر سيمان سرويسها،آشپزخانه هاو،بالكن هاي طبقه نهم | 10d | 2010-08-06 | 2010-08-15 | 2223, 2237, 2251, 2265, 2279, 2293, 2308, 2322 | 7d | 0d | 89/5/15 | 89/5/24 | متر مربع |  |  |
| 2340 | 4.13.3.11 | پلاستر سيمان سرويسها،آشپزخانه هاو،بالكن هاي طبقه دهم | 10d | 2010-08-23 | 2010-09-01 | 2224, 2238, 2252, 2266, 2280, 2294, 2309, 2323 | 0d |  | 89/6/1 | 89/6/10 | متر مربع |  |  |

| ID | WBS | Task | Duration | Start | Finish | Predecessors | Total slack | Free slack | Plan Start | Plan Finish | Text1 | Text2 | واحد |
| --- | --- | --- | --- | --- | --- | --- | --- | --- | --- | --- | --- | --- | --- |
| 2341 | 4.13.4 | **نصب پنجره ها و شيشه هاي طبقات** | 146d | 2010-04-04 | 2010-08-27 |  | 76d | 0d | 89/1/15 | 89/6/5 |  |  |  |
| 2342 | 4.13.4.1 | نصب پنجره ها و شيشه هاي طبقه همكف | 5d | 2010-04-04 | 2010-04-08 | 2330SS | 217d |  | 89/1/15 | 89/1/19 |  |  |  |
| 2343 | 4.13.4.2 | نصب پنجره ها و شيشه هاي طبقه اول | 5d | 2010-04-11 | 2010-04-15 | 2331SS | 210d |  | 89/1/22 | 89/1/26 |  |  |  |
| 2344 | 4.13.4.3 | نصب پنجره ها و شيشه هاي طبقه دوم | 5d | 2010-04-23 | 2010-04-27 | 2332SS | 198d |  | 89/2/3 | 89/2/7 |  |  |  |
| 2345 | 4.13.4.4 | نصب پنجره ها و شيشه هاي طبقه سوم | 5d | 2010-05-08 | 2010-05-12 | 2333SS | 183d |  | 89/2/18 | 89/2/22 |  |  |  |
| 2346 | 4.13.4.5 | نصب پنجره ها و شيشه هاي طبقه چهارم | 5d | 2010-05-23 | 2010-05-27 | 2334SS | 168d |  | 89/3/2 | 89/3/6 |  |  |  |
| 2347 | 4.13.4.6 | نصب پنجره ها و شيشه هاي طبقه پنجم | 5d | 2010-06-07 | 2010-06-11 | 2335SS | 153d |  | 89/3/17 | 89/3/21 |  |  |  |
| 2348 | 4.13.4.7 | نصب پنجره ها و شيشه هاي طبقه ششم | 5d | 2010-06-22 | 2010-06-26 | 2336SS | 138d |  | 89/4/1 | 89/4/5 |  |  |  |
| 2349 | 4.13.4.8 | نصب پنجره ها و شيشه هاي طبقه هفتم | 5d | 2010-07-07 | 2010-07-11 | 2337SS | 123d |  | 89/4/16 | 89/4/20 |  |  |  |
| 2350 | 4.13.4.9 | نصب پنجره ها و شيشه هاي طبقه هشتم | 5d | 2010-07-22 | 2010-07-26 | 2338SS | 108d |  | 89/4/31 | 89/5/4 |  |  |  |
| 2351 | 4.13.4.10 | نصب پنجره ها و شيشه هاي طبقه نهم | 5d | 2010-08-06 | 2010-08-10 | 2339SS | 93d |  | 89/5/15 | 89/5/19 |  |  |  |
| 2352 | 4.13.4.11 | نصب پنجره ها و شيشه هاي طبقه دهم | 5d | 2010-08-23 | 2010-08-27 | 2340SS | 76d |  | 89/6/1 | 89/6/5 |  |  |  |
| 2353 | 4.13.5 | نماسازي | 94d | 2009-12-23 | 2010-04-04 | 2131, 2341SF | 222d |  | 88/10/2 | 89/1/15 | 88/05/14 | 88/12/01 | مترمربع |
| 2354 | 4.13.6 | **عايق كاري سرويسها،آشپزخانه ها،بالكن ها و پشت بام** | 146d | 2010-04-24 | 2010-09-16 |  | 0d |  | 89/2/4 | 89/6/25 |  |  |  |
| 2355 | 4.13.6.1 | عايق كاري سرويسها،آشپزخانه هاو،بالكن هاي طبقه همكف | 5d | 2010-04-24 | 2010-04-28 | 2198, 2330 | 0d |  | 89/2/4 | 89/2/8 |  |  | مترمربع |
| 2356 | 4.13.6.2 | عايق كاري سرويسها،آشپزخانه هاو،بالكن هاي طبقه اول | 5d | 2010-05-01 | 2010-05-05 | 2199, 2331 | 44d | 0d | 89/2/11 | 89/2/15 |  |  | مترمربع |
| 2357 | 4.13.6.3 | عايق كاري سرويسها،آشپزخانه هاو،بالكن هاي طبقه دوم | 5d | 2010-05-13 | 2010-05-17 | 2200, 2332 | 42d | 0d | 89/2/23 | 89/2/27 |  |  | مترمربع |
| 2358 | 4.13.6.4 | عايق كاري سرويسها،آشپزخانه هاو،بالكن هاي طبقه سوم | 5d | 2010-05-28 | 2010-06-01 | 2201, 2333 | 37d | 0d | 89/3/7 | 89/3/11 |  |  | مترمربع |
| 2359 | 4.13.6.5 | عايق كاري سرويسها،آشپزخانه هاو،بالكن هاي طبقه چهارم | 5d | 2010-06-12 | 2010-06-16 | 2202, 2334 | 32d | 0d | 89/3/22 | 89/3/26 |  |  | مترمربع |
| 2360 | 4.13.6.6 | عايق كاري سرويسها،آشپزخانه هاو،بالكن هاي طبقه پنجم | 5d | 2010-06-27 | 2010-07-01 | 2203, 2335 | 27d | 0d | 89/4/6 | 89/4/10 |  |  | مترمربع |
| 2361 | 4.13.6.7 | عايق كاري سرويسها،آشپزخانه هاو،بالكن هاي طبقه ششم | 5d | 2010-07-12 | 2010-07-16 | 2204, 2336 | 22d | 0d | 89/4/21 | 89/4/25 |  |  | مترمربع |
| 2362 | 4.13.6.8 | عايق كاري سرويسها،آشپزخانه هاو،بالكن هاي طبقه هفتم | 5d | 2010-07-27 | 2010-07-31 | 2205, 2337 | 17d | 0d | 89/5/5 | 89/5/9 |  |  | مترمربع |
| 2363 | 4.13.6.9 | عايق كاري سرويسها،آشپزخانه هاو،بالكن هاي طبقه هشتم | 5d | 2010-08-11 | 2010-08-15 | 2206, 2338 | 12d | 0d | 89/5/20 | 89/5/24 |  |  | مترمربع |
| 2364 | 4.13.6.10 | عايق كاري سرويسها،آشپزخانه هاو،بالكن هاي طبقه نهم | 5d | 2010-08-26 | 2010-08-30 | 2207, 2339 | 7d | 0d | 89/6/4 | 89/6/8 |  |  | مترمربع |
| 2365 | 4.13.6.11 | عايق كاري سرويسها،آشپزخانه هاو،بالكن هاي طبقه دهم | 5d | 2010-09-12 | 2010-09-16 | 2208, 2340 | 0d |  | 89/6/21 | 89/6/25 |  |  | مترمربع |

| ID | WBS | Task | Duration | Start | Finish | Predecessors | Total slack | Free slack | Plan Start | Plan Finish | واحد | Text1 | Text2 |
| --- | --- | --- | --- | --- | --- | --- | --- | --- | --- | --- | --- | --- | --- |
| 2366 | 4.13.7 | **سراميك كاري سرويسها و آشپزخانه هاوپذيرايي و اتاق خوابها** | 161d | 2010-04-29 | 2010-10-06 |  | 0d |  | 89/2/9 | 89/7/14 |  |  |  |
| 2367 | 4.13.7.1 | سراميك كاري سرويسها و آشپزخانه هاوپذيرايي و اتاق خوابهاي همكف | 20d | 2010-04-29 | 2010-05-18 | 2355 | 0d |  | 89/2/9 | 89/2/28 | مترمربع |  |  |
| 2368 | 4.13.7.2 | سراميك كاري سرويسها و آشپزخانه هاوپذيرايي و اتاق خوابهاي طبقه اول | 20d | 2010-05-06 | 2010-05-25 | 2356 | 44d | 0d | 89/2/16 | 89/3/4 | مترمربع |  |  |
| 2369 | 4.13.7.3 | سراميك كاري سرويسها و آشپزخانه هاوپذيرايي و اتاق خوابهاي طبقه دوم | 20d | 2010-05-18 | 2010-06-06 | 2357 | 42d | 0d | 89/2/28 | 89/3/16 | مترمربع |  |  |
| 2370 | 4.13.7.4 | سراميك كاري سرويسها و آشپزخانه هاوپذيرايي و اتاق خوابهاي طبقه سوم | 20d | 2010-06-02 | 2010-06-21 | 2358 | 37d | 0d | 89/3/12 | 89/3/31 | مترمربع |  |  |
| 2371 | 4.13.7.5 | سراميك كاري سرويسها و آشپزخانه هاوپذيرايي و اتاق خوابهاي طبقه چهارم | 20d | 2010-06-17 | 2010-07-06 | 2359 | 32d | 0d | 89/3/27 | 89/4/15 | مترمربع |  |  |
| 2372 | 4.13.7.6 | سراميك كاري سرويسها و آشپزخانه هاوپذيرايي و اتاق خوابهاي طبقه پنجم | 20d | 2010-07-02 | 2010-07-21 | 2360 | 27d | 0d | 89/4/11 | 89/4/30 | مترمربع |  |  |
| 2373 | 4.13.7.7 | سراميك كاري سرويسها و آشپزخانه هاوپذيرايي و اتاق خوابهاي طبقه ششم | 20d | 2010-07-17 | 2010-08-05 | 2361 | 22d | 0d | 89/4/26 | 89/5/14 | مترمربع |  |  |
| 2374 | 4.13.7.8 | سراميك كاري سرويسها و آشپزخانه هاوپذيرايي و اتاق خوابهاي طبقه هفتم | 20d | 2010-08-01 | 2010-08-20 | 2362 | 17d | 0d | 89/5/10 | 89/5/29 | مترمربع |  |  |
| 2375 | 4.13.7.9 | سراميك كاري سرويسها و آشپزخانه هاوپذيرايي و اتاق خوابهاي طبقه هشتم | 20d | 2010-08-16 | 2010-09-04 | 2363 | 12d | 0d | 89/5/25 | 89/6/13 | مترمربع |  |  |
| 2376 | 4.13.7.10 | سراميك كاري سرويسها و آشپزخانه هاوپذيرايي و اتاق خوابهاي طبقه نهم | 20d | 2010-08-31 | 2010-09-19 | 2364 | 7d | 0d | 89/6/9 | 89/6/28 | مترمربع |  |  |
| 2377 | 4.13.7.11 | سراميك كاري سرويسها و آشپزخانه هاوپذيرايي و اتاق خوابهاي طبقه دهم | 20d | 2010-09-17 | 2010-10-06 | 2365 | 0d |  | 89/6/26 | 89/7/14 | مترمربع |  |  |
| 2378 | 4.13.8 | **كاشيكاري سرويسها و آشپزخانه ها** | 161d | 2010-05-09 | 2010-10-16 |  | 0d |  | 89/2/19 | 89/7/24 |  | 87/12/06 | 88/08/10 |
| 2379 | 4.13.8.1 | كاشيكاري سرويسها و آشپزخانه هاي طبقه همكف | 20d | 2010-05-09 | 2010-05-28 | 2367SS+10d | 0d |  | 89/2/19 | 89/3/7 | مترمربع |  |  |
| 2380 | 4.13.8.2 | كاشيكاري سرويسها و آشپزخانه هاي طبقه اول | 20d | 2010-05-16 | 2010-06-04 | 2368SS+10d | 140d | 0d | 89/2/26 | 89/3/14 | مترمربع | 87/12/06 | 87/12/25 |
| 2381 | 4.13.8.3 | كاشيكاري سرويسها و آشپزخانه هاي طبقه دوم | 20d | 2010-05-28 | 2010-06-16 | 2369SS+10d | 128d | 0d | 89/3/7 | 89/3/26 | مترمربع | 88/01/26 | 88/02/14 |
| 2382 | 4.13.8.4 | كاشيكاري سرويسها و آشپزخانه هاي طبقه سوم | 20d | 2010-06-12 | 2010-07-01 | 2370SS+10d | 113d | 0d | 89/3/22 | 89/4/10 | مترمربع | 88/02/15 | 88/03/03 |
| 2383 | 4.13.8.5 | كاشيكاري سرويسها و آشپزخانه هاي طبقه چهارم | 20d | 2010-06-27 | 2010-07-16 | 2371SS+10d | 98d | 0d | 89/4/6 | 89/4/25 | مترمربع | 88/03/04 | 88/03/23 |
| 2384 | 4.13.8.6 | كاشيكاري سرويسها و آشپزخانه هاي طبقه پنجم | 20d | 2010-07-12 | 2010-07-31 | 2372SS+10d | 83d | 0d | 89/4/21 | 89/5/9 | مترمربع | 88/03/24 | 88/04/12 |
| 2385 | 4.13.8.7 | كاشيكاري سرويسها و آشپزخانه هاي طبقه ششم | 20d | 2010-07-27 | 2010-08-15 | 2373SS+10d | 68d | 0d | 89/5/5 | 89/5/24 | مترمربع | 88/04/13 | 88/05/01 |
| 2386 | 4.13.8.8 | كاشيكاري سرويسها و آشپزخانه هاي طبقه هفتم | 20d | 2010-08-11 | 2010-08-30 | 2374SS+10d | 53d | 0d | 89/5/20 | 89/6/8 | مترمربع | 88/05/02 | 88/05/21 |
| 2387 | 4.13.8.9 | كاشيكاري سرويسها و آشپزخانه هاي طبقه هشتم | 20d | 2010-08-26 | 2010-09-14 | 2375SS+10d | 38d | 0d | 89/6/4 | 89/6/23 | مترمربع | 88/05/22 | 88/06/10 |
| 2388 | 4.13.8.10 | كاشيكاري سرويسها و آشپزخانه هاي طبقه نهم | 20d | 2010-09-10 | 2010-09-29 | 2376SS+10d | 23d | 0d | 89/6/19 | 89/7/7 | مترمربع | 88/06/11 | 88/06/30 |
| 2389 | 4.13.8.11 | كاشيكاري سرويسها و آشپزخانه هاي طبقه دهم | 20d | 2010-09-27 | 2010-10-16 | 2377SS+10d | 4d | 0d | 89/7/5 | 89/7/24 | مترمربع | 88/06/31 | 88/07/19 |

| ID | WBS | Task | Duration | Start | Finish | Predecessors | Total slack | Free slack | Plan Start | Plan Finish | واحد |
| --- | --- | --- | --- | --- | --- | --- | --- | --- | --- | --- | --- |
| 2390 | 4.13.9 | **اجراي سنگ كف و اجراي پله ها** | 187d | 2010-02-14 | 2010-08-27 |  | 66d |  | 88/11/25 | 89/6/5 |  |
| 2391 | 4.13.9.1 | اجراي سنگ كف و اجراي پله هاي طبقه زيرزمين دوم | 5d | 2010-02-14 | 2010-02-18 | 2254, 2297 | 238d | 5d | 88/11/25 | 88/11/29 | مترمربع |
| 2392 | 4.13.9.2 | اجراي سنگ كف و اجراي پله هاي طبقه زيرزمين اول | 5d | 2010-03-01 | 2010-03-05 | 2255, 2298 | 233d | 15d | 88/12/10 | 88/12/14 | مترمربع |
| 2393 | 4.13.9.3 | اجراي سنگ كف و اجراي پله هاي طبقه همكف | 5d | 2010-04-04 | 2010-04-08 | 2330SS | 40d | 15d | 89/1/15 | 89/1/19 | مترمربع |
| 2394 | 4.13.9.4 | اجراي سنگ كف و اجراي پله هاي طبقه اول | 5d | 2010-04-11 | 2010-04-15 | 2331SS | 180d | 15d | 89/1/22 | 89/1/26 | مترمربع |
| 2395 | 4.13.9.5 | اجراي سنگ كف و اجراي پله هاي طبقه دوم | 5d | 2010-04-23 | 2010-04-27 | 2332SS | 168d | 15d | 89/2/3 | 89/2/7 | مترمربع |
| 2396 | 4.13.9.6 | اجراي سنگ كف و اجراي پله هاي طبقه سوم | 5d | 2010-05-08 | 2010-05-12 | 2333SS | 153d | 15d | 89/2/18 | 89/2/22 | مترمربع |
| 2397 | 4.13.9.7 | اجراي سنگ كف و اجراي پله هاي طبقه چهارم | 5d | 2010-05-23 | 2010-05-27 | 2334SS | 138d | 15d | 89/3/2 | 89/3/6 | مترمربع |
| 2398 | 4.13.9.8 | اجراي سنگ كف و اجراي پله هاي طبقه پنجم | 5d | 2010-06-07 | 2010-06-11 | 2335SS | 123d | 15d | 89/3/17 | 89/3/21 | مترمربع |
| 2399 | 4.13.9.9 | اجراي سنگ كف و اجراي پله هاي طبقه ششم | 5d | 2010-06-22 | 2010-06-26 | 2336SS | 108d | 15d | 89/4/1 | 89/4/5 | مترمربع |
| 2400 | 4.13.9.10 | اجراي سنگ كف و اجراي پله هاي طبقه هفتم | 5d | 2010-07-07 | 2010-07-11 | 2337SS | 93d | 15d | 89/4/16 | 89/4/20 | مترمربع |
| 2401 | 4.13.9.11 | اجراي سنگ كف و اجراي پله هاي طبقه هشتم | 5d | 2010-07-22 | 2010-07-26 | 2338SS | 78d | 15d | 89/4/31 | 89/5/4 | مترمربع |
| 2402 | 4.13.9.12 | اجراي سنگ كف و اجراي پله هاي طبقه نهم | 5d | 2010-08-06 | 2010-08-10 | 2339SS | 63d | 15d | 89/5/15 | 89/5/19 | مترمربع |
| 2403 | 4.13.9.13 | اجراي سنگ كف و اجراي پله هاي طبقه دهم | 5d | 2010-08-23 | 2010-08-27 | 2340SS | 44d | 15d | 89/6/1 | 89/6/5 | مترمربع |
| 2404 | 4.13.10 | **اجراي سنگ بدنه در راهروها و راه پله ها** | 202d | 2010-02-24 | 2010-09-21 |  | 51d |  | 88/12/5 | 89/6/30 |  |
| 2405 | 4.13.10.1 | اجراي سنگ بدنه در راهروها و راه پله هاي طبقه زيرزمين دوم | 10d | 2010-02-24 | 2010-03-05 | 2325, 2391 | 233d | 0d | 88/12/5 | 88/12/14 | مترمربع |
| 2406 | 4.13.10.2 | اجراي سنگ بدنه در راهروها و راه پله هاي طبقه زيرزمين اول | 10d | 2010-03-29 | 2010-04-07 | 2197, 2392 | 218d |  | 89/1/9 | 89/1/18 | مترمربع |
| 2407 | 4.13.10.3 | اجراي سنگ بدنه در راهروها و راه پله هاي طبقه همكف | 10d | 2010-04-24 | 2010-05-03 | 2198, 2393 | 25d |  | 89/2/4 | 89/2/13 | مترمربع |
| 2408 | 4.13.10.4 | اجراي سنگ بدنه در راهروها و راه پله هاي طبقه اول | 10d | 2010-05-01 | 2010-05-10 | 2199, 2394 | 165d | 25d | 89/2/11 | 89/2/20 | مترمربع |
| 2409 | 4.13.10.5 | اجراي سنگ بدنه در راهروها و راه پله هاي طبقه دوم | 10d | 2010-05-13 | 2010-05-22 | 2200, 2395 | 153d | 25d | 89/2/23 | 89/3/1 | مترمربع |
| 2410 | 4.13.10.6 | اجراي سنگ بدنه در راهروها و راه پله هاي طبقه سوم | 10d | 2010-05-28 | 2010-06-06 | 2201, 2396 | 138d | 25d | 89/3/7 | 89/3/16 | مترمربع |
| 2411 | 4.13.10.7 | اجراي سنگ بدنه در راهروها و راه پله هاي طبقه چهارم | 10d | 2010-06-12 | 2010-06-21 | 2202, 2397 | 123d | 25d | 89/3/22 | 89/3/31 | مترمربع |
| 2412 | 4.13.10.8 | اجراي سنگ بدنه در راهروها و راه پله هاي طبقه پنجم | 10d | 2010-06-27 | 2010-07-06 | 2203, 2398 | 108d | 25d | 89/4/6 | 89/4/15 | مترمربع |
| 2413 | 4.13.10.9 | اجراي سنگ بدنه در راهروها و راه پله هاي طبقه ششم | 10d | 2010-07-12 | 2010-07-21 | 2204, 2399 | 93d | 25d | 89/4/21 | 89/4/30 | مترمربع |
| 2414 | 4.13.10.10 | اجراي سنگ بدنه در راهروها و راه پله هاي طبقه هفتم | 10d | 2010-07-27 | 2010-08-05 | 2205, 2400 | 78d | 25d | 89/5/5 | 89/5/14 | مترمربع |
| 2415 | 4.13.10.11 | اجراي سنگ بدنه در راهروها و راه پله هاي طبقه هشتم | 10d | 2010-08-11 | 2010-08-20 | 2206, 2401 | 63d | 25d | 89/5/20 | 89/5/29 | مترمربع |
| 2416 | 4.13.10.12 | اجراي سنگ بدنه در راهروها و راه پله هاي طبقه نهم | 10d | 2010-08-26 | 2010-09-04 | 2207, 2402 | 48d | 25d | 89/6/4 | 89/6/13 | مترمربع |
| 2417 | 4.13.10.13 | اجراي سنگ بدنه در راهروها و راه پله هاي طبقه دهم | 10d | 2010-09-12 | 2010-09-21 | 2208, 2403 | 29d | 25d | 89/6/21 | 89/6/30 | مترمربع |

| ID | WBS | Task | Duration | Start | Finish | Predecessors | Total slack | Free slack | Plan Start | Plan Finish | واحد |
| --- | --- | --- | --- | --- | --- | --- | --- | --- | --- | --- | --- |
| 2418 | 4.13.11 | **اجراي موزاييك و قرنيز ديوارها** | 151d | 2010-04-24 | 2010-09-21 |  | 25d |  | 89/2/4 | 89/6/30 |  |
| 2419 | 4.13.11.1 | اجراي موزاييك و قرنيز ديوارها طبقه همكف | 10d | 2010-04-24 | 2010-05-03 | 2198, 2393 | 25d |  | 89/2/4 | 89/2/13 | مترمربع |
| 2420 | 4.13.11.2 | اجراي موزاييك و قرنيز ديوارهاي طبقه اول | 10d | 2010-05-01 | 2010-05-10 | 2199, 2394 | 165d | 25d | 89/2/11 | 89/2/20 | مترمربع |
| 2421 | 4.13.11.3 | اجراي موزاييك و قرنيز ديوارهاي طبقه دوم | 10d | 2010-05-13 | 2010-05-22 | 2200, 2395 | 153d | 25d | 89/2/23 | 89/3/1 | مترمربع |
| 2422 | 4.13.11.4 | اجراي موزاييك و قرنيز ديوارهاي طبقه سوم | 10d | 2010-05-28 | 2010-06-06 | 2201, 2396 | 138d | 25d | 89/3/7 | 89/3/16 | مترمربع |
| 2423 | 4.13.11.5 | اجراي موزاييك و قرنيز ديوارهاي طبقه چهارم | 10d | 2010-06-12 | 2010-06-21 | 2202, 2397 | 123d | 25d | 89/3/22 | 89/3/31 | مترمربع |
| 2424 | 4.13.11.6 | اجراي موزاييك و قرنيز ديوارهاي طبقه پنجم | 10d | 2010-06-27 | 2010-07-06 | 2203, 2398 | 108d | 25d | 89/4/6 | 89/4/15 | مترمربع |
| 2425 | 4.13.11.7 | اجراي موزاييك و قرنيز ديوارهاي طبقه ششم | 10d | 2010-07-12 | 2010-07-21 | 2204, 2399 | 93d | 25d | 89/4/21 | 89/4/30 | مترمربع |
| 2426 | 4.13.11.8 | اجراي موزاييك و قرنيز ديوارهاي طبقه هفتم | 10d | 2010-07-27 | 2010-08-05 | 2205, 2400 | 78d | 25d | 89/5/5 | 89/5/14 | مترمربع |
| 2427 | 4.13.11.9 | اجراي موزاييك و قرنيز ديوارهاي طبقه هشتم | 10d | 2010-08-11 | 2010-08-20 | 2206, 2401 | 63d | 25d | 89/5/20 | 89/5/29 | مترمربع |
| 2428 | 4.13.11.10 | اجراي موزاييك و قرنيز ديوارهاي طبقه نهم | 10d | 2010-08-26 | 2010-09-04 | 2207, 2402 | 48d | 25d | 89/6/4 | 89/6/13 | مترمربع |
| 2429 | 4.13.11.11 | اجراي موزاييك و قرنيز ديوارهاي طبقه دهم | 10d | 2010-09-12 | 2010-09-21 | 2208, 2403 | 29d | 25d | 89/6/21 | 89/6/30 | مترمربع |
| 2430 | 4.13.12 | **اجراي كارهاي چوبي درهاي ورودي وادها،اتاق خوابها و …** | 110d | 2010-06-28 | 2010-10-15 |  | 1d |  | 89/4/7 | 89/7/23 |  |
| 2431 | 4.13.12.1 | اجراي كارهاي چوبي درهاي ورودي وادها،اتاق خوابهاي طبقه همكف | 10d | 2010-06-28 | 2010-07-07 | 2455 | 99d | 0d | 89/4/7 | 89/4/16 |  |
| 2432 | 4.13.12.2 | اجراي كارهاي چوبي درهاي ورودي وادها،اتاق خوابهاي طبقه اول | 10d | 2010-07-08 | 2010-07-17 | 2456 | 89d | 0d | 89/4/17 | 89/4/26 |  |
| 2433 | 4.13.12.3 | اجراي كارهاي چوبي درهاي ورودي وادها،اتاق خوابهاي طبقه دوم | 10d | 2010-07-18 | 2010-07-27 | 2457 | 79d | 0d | 89/4/27 | 89/5/5 |  |
| 2434 | 4.13.12.4 | اجراي كارهاي چوبي درهاي ورودي وادها،اتاق خوابهاي طبقه سوم | 10d | 2010-07-28 | 2010-08-06 | 2458 | 69d | 0d | 89/5/6 | 89/5/15 |  |
| 2435 | 4.13.12.5 | اجراي كارهاي چوبي درهاي ورودي وادها،اتاق خوابهاي طبقه چهارم | 10d | 2010-08-07 | 2010-08-16 | 2459 | 59d | 0d | 89/5/16 | 89/5/25 |  |
| 2436 | 4.13.12.6 | اجراي كارهاي چوبي درهاي ورودي وادها،اتاق خوابهاي طبقه پنجم | 10d | 2010-08-17 | 2010-08-26 | 2460 | 49d | 0d | 89/5/26 | 89/6/4 |  |
| 2437 | 4.13.12.7 | اجراي كارهاي چوبي درهاي ورودي وادها،اتاق خوابهاي طبقه ششم | 10d | 2010-08-27 | 2010-09-05 | 2461 | 39d | 0d | 89/6/5 | 89/6/14 |  |
| 2438 | 4.13.12.8 | اجراي كارهاي چوبي درهاي ورودي وادها،اتاق خوابهاي طبقه هفتم | 10d | 2010-09-06 | 2010-09-15 | 2462 | 29d | 0d | 89/6/15 | 89/6/24 |  |
| 2439 | 4.13.12.9 | اجراي كارهاي چوبي درهاي ورودي وادها،اتاق خوابهاي طبقه هشتم | 10d | 2010-09-16 | 2010-09-25 | 2463 | 19d | 0d | 89/6/25 | 89/7/3 |  |
| 2440 | 4.13.12.10 | اجراي كارهاي چوبي درهاي ورودي وادها،اتاق خوابهاي طبقه نهم | 10d | 2010-09-26 | 2010-10-05 | 2464 | 9d | 0d | 89/7/4 | 89/7/13 |  |
| 2441 | 4.13.12.11 | اجراي كارهاي چوبي درهاي ورودي وادها،اتاق خوابهاي طبقه دهم | 10d | 2010-10-06 | 2010-10-15 | 2465 | 1d |  | 89/7/14 | 89/7/23 |  |

| ID | WBS | Task | Duration | Start | Finish | Predecessors | Total slack | Text1 | Text2 | واحد | Plan Start | Plan Finish |
| --- | --- | --- | --- | --- | --- | --- | --- | --- | --- | --- | --- | --- |
| 2442 | 4.13.13 | **اجراي سقف كاذب سرويسهاي طبقات** | 156d | 2010-05-29 | 2010-10-31 |  | 11d | 88/02/15 | 88/09/19 | درصد | 89/3/8 | 89/8/9 |
| 2443 | 4.13.13.1 | اجراي سقف كاذب سرويسهاي طبقه همكف | 15d | 2010-05-29 | 2010-06-12 | 2379 | 152d | 88/02/15 | 88/03/03 | مترمربع | 89/3/8 | 89/3/22 |
| 2444 | 4.13.13.2 | اجراي سقف كاذب سرويسهاي طبقه اول | 15d | 2010-06-05 | 2010-06-19 | 2380 | 145d | 88/03/04 | 88/03/23 | مترمربع | 89/3/15 | 89/3/29 |
| 2445 | 4.13.13.3 | اجراي سقف كاذب سرويسهاي طبقه دوم | 15d | 2010-06-17 | 2010-07-01 | 2381 | 133d | 88/03/24 | 88/04/12 | مترمربع | 89/3/27 | 89/4/10 |
| 2446 | 4.13.13.4 | اجراي سقف كاذب سرويسهاي طبقه سوم | 15d | 2010-07-02 | 2010-07-16 | 2382 | 118d | 88/04/13 | 88/05/01 | مترمربع | 89/4/11 | 89/4/25 |
| 2447 | 4.13.13.5 | اجراي سقف كاذب سرويسهاي طبقه چهارم | 15d | 2010-07-17 | 2010-07-31 | 2383 | 103d | 88/05/02 | 88/05/21 | مترمربع | 89/4/26 | 89/5/9 |
| 2448 | 4.13.13.6 | اجراي سقف كاذب سرويسهاي طبقه پنجم | 15d | 2010-08-01 | 2010-08-15 | 2384 | 88d | 88/05/22 | 88/06/10 | مترمربع | 89/5/10 | 89/5/24 |
| 2449 | 4.13.13.7 | اجراي سقف كاذب سرويسهاي طبقه ششم | 15d | 2010-08-16 | 2010-08-30 | 2385 | 73d | 88/06/11 | 88/06/30 | مترمربع | 89/5/25 | 89/6/8 |
| 2450 | 4.13.13.8 | اجراي سقف كاذب سرويسهاي طبقه هفتم | 15d | 2010-08-31 | 2010-09-14 | 2386 | 58d | 88/06/31 | 88/07/19 | مترمربع | 89/6/9 | 89/6/23 |
| 2451 | 4.13.13.9 | اجراي سقف كاذب سرويسهاي طبقه هشتم | 15d | 2010-09-15 | 2010-09-29 | 2387 | 43d | 88/07/20 | 88/08/09 | مترمربع | 89/6/24 | 89/7/7 |
| 2452 | 4.13.13.10 | اجراي سقف كاذب سرويسهاي طبقه نهم | 15d | 2010-09-30 | 2010-10-14 | 2388 | 28d | 88/08/10 | 88/08/29 | مترمربع | 89/7/8 | 89/7/22 |
| 2453 | 4.13.13.11 | اجراي سقف كاذب سرويسهاي طبقه دهم | 15d | 2010-10-17 | 2010-10-31 | 2389 | 11d | 88/08/30 | 88/09/19 | مترمربع | 89/7/25 | 89/8/9 |
| 2454 | 4.13.14 | **اجراي سفيدكاري** | 110d | 2010-06-18 | 2010-10-05 |  | 0d | 87/12/26 | 88/10/09 | درصد | 89/3/28 | 89/7/13 |
| 2455 | 4.13.14.1 | اجراي سفيدکاري همکف | 10d | 2010-06-18 | 2010-06-27 | 2172, 2184 | 0d | 88/03/04 | 88/03/23 | مترمربع | 89/3/28 | 89/4/6 |
| 2456 | 4.13.14.2 | اجراي سفيدكاري طبقه 1 | 10d | 2010-06-28 | 2010-07-07 | 2455 | 0d | 88/03/24 | 88/04/12 | مترمربع | 89/4/7 | 89/4/16 |
| 2457 | 4.13.14.3 | اجراي سفيدكاري طبقه 2 | 10d | 2010-07-08 | 2010-07-17 | 2456 | 0d | 88/04/13 | 88/05/01 | مترمربع | 89/4/17 | 89/4/26 |
| 2458 | 4.13.14.4 | اجراي سفيدكاري طبقه 3 | 10d | 2010-07-18 | 2010-07-27 | 2457 | 0d | 88/05/02 | 88/05/21 | مترمربع | 89/4/27 | 89/5/5 |
| 2459 | 4.13.14.5 | اجراي سفيدكاري طبقه 4 | 10d | 2010-07-28 | 2010-08-06 | 2458 | 0d | 88/05/22 | 88/06/10 | مترمربع | 89/5/6 | 89/5/15 |
| 2460 | 4.13.14.6 | اجراي سفيدكاري طبقه 5 | 10d | 2010-08-07 | 2010-08-16 | 2459 | 0d | 88/06/11 | 88/06/30 | مترمربع | 89/5/16 | 89/5/25 |
| 2461 | 4.13.14.7 | اجراي سفيدكاري طبقه 6 | 10d | 2010-08-17 | 2010-08-26 | 2460 | 0d | 88/06/31 | 88/07/19 | مترمربع | 89/5/26 | 89/6/4 |
| 2462 | 4.13.14.8 | اجراي سفيدكاري طبقه 7 | 10d | 2010-08-27 | 2010-09-05 | 2461 | 0d | 88/07/20 | 88/08/09 | مترمربع | 89/6/5 | 89/6/14 |
| 2463 | 4.13.14.9 | اجراي سفيدكاري طبقه 8 | 10d | 2010-09-06 | 2010-09-15 | 2462 | 0d | 88/08/10 | 88/08/29 | مترمربع | 89/6/15 | 89/6/24 |
| 2464 | 4.13.14.10 | اجراي سفيدكاري طبقه 9 | 10d | 2010-09-16 | 2010-09-25 | 2463 | 0d | 88/08/30 | 88/09/19 | مترمربع | 89/6/25 | 89/7/3 |
| 2465 | 4.13.14.11 | اجراي سفيدكاري طبقه 10 وخرپشته | 10d | 2010-09-26 | 2010-10-05 | 2464 | 0d | 88/09/20 | 88/10/09 | مترمربع | 89/7/4 | 89/7/13 |

| ID | WBS | Task | Duration | Start | Finish | Predecessors | Total slack | Free slack | Plan Start | Plan Finish |
| --- | --- | --- | --- | --- | --- | --- | --- | --- | --- | --- |
| 2466 | 4.13.15 | **نصب دربهاي اصلي ساختمان** | 105d | 2010-06-28 | 2010-10-10 |  | 4d |  | 89/4/7 | 89/7/18 |
| 2467 | 4.13.15.1 | نصب دربهاي اصلي ساختمان طبقه همكف | 5d | 2010-06-28 | 2010-07-02 | 2455 | 104d | 5d | 89/4/7 | 89/4/11 |
| 2468 | 4.13.15.2 | نصب دربهاي اصلي طبقه اول | 5d | 2010-07-08 | 2010-07-12 | 2456 | 94d | 5d | 89/4/17 | 89/4/21 |
| 2469 | 4.13.15.3 | نصب دربهاي اصلي طبقه دوم | 5d | 2010-07-18 | 2010-07-22 | 2457 | 84d | 5d | 89/4/27 | 89/4/31 |
| 2470 | 4.13.15.4 | نصب دربهاي اصلي طبقه سوم | 5d | 2010-07-28 | 2010-08-01 | 2458 | 74d | 5d | 89/5/6 | 89/5/10 |
| 2471 | 4.13.15.5 | نصب دربهاي اصلي طبقه چهارم | 5d | 2010-08-07 | 2010-08-11 | 2459 | 64d | 5d | 89/5/16 | 89/5/20 |
| 2472 | 4.13.15.6 | نصب دربهاي اصلي طبقه پنجم | 5d | 2010-08-17 | 2010-08-21 | 2460 | 54d | 5d | 89/5/26 | 89/5/30 |
| 2473 | 4.13.15.7 | نصب دربهاي اصلي طبقه ششم | 5d | 2010-08-27 | 2010-08-31 | 2461 | 44d | 5d | 89/6/5 | 89/6/9 |
| 2474 | 4.13.15.8 | نصب دربهاي اصلي طبقه هفتم | 5d | 2010-09-06 | 2010-09-10 | 2462 | 34d | 5d | 89/6/15 | 89/6/19 |
| 2475 | 4.13.15.9 | نصب دربهاي اصلي طبقه هشتم | 5d | 2010-09-16 | 2010-09-20 | 2463 | 24d | 5d | 89/6/25 | 89/6/29 |
| 2476 | 4.13.15.10 | نصب دربهاي اصلي طبقه نهم | 5d | 2010-09-26 | 2010-09-30 | 2464 | 14d | 5d | 89/7/4 | 89/7/8 |
| 2477 | 4.13.15.11 | نصب دربهاي اصلي طبقه دهم | 5d | 2010-10-06 | 2010-10-10 | 2465 | 0d |  | 89/7/14 | 89/7/18 |
| 2478 | 4.13.16 | **نصب كابينت طبقات** | 110d | 2010-06-28 | 2010-10-15 |  | 1d |  | 89/4/7 | 89/7/23 |
| 2479 | 4.13.16.1 | نصب كابينت طبقه همكف | 10d | 2010-06-28 | 2010-07-07 | 2455 | 99d | 0d | 89/4/7 | 89/4/16 |
| 2480 | 4.13.16.2 | نصب كابينت طبقه اول | 10d | 2010-07-08 | 2010-07-17 | 2456 | 89d | 0d | 89/4/17 | 89/4/26 |
| 2481 | 4.13.16.3 | نصب كابينت طبقه دوم | 10d | 2010-07-18 | 2010-07-27 | 2457 | 79d | 0d | 89/4/27 | 89/5/5 |
| 2482 | 4.13.16.4 | نصب كابينت طبقه سوم | 10d | 2010-07-28 | 2010-08-06 | 2458 | 69d | 0d | 89/5/6 | 89/5/15 |
| 2483 | 4.13.16.5 | نصب كابينت طبقه چهارم | 10d | 2010-08-07 | 2010-08-16 | 2459 | 59d | 0d | 89/5/16 | 89/5/25 |
| 2484 | 4.13.16.6 | نصب كابينت طبقه پنجم | 10d | 2010-08-17 | 2010-08-26 | 2460 | 49d | 0d | 89/5/26 | 89/6/4 |
| 2485 | 4.13.16.7 | نصب كابينت طبقه ششم | 10d | 2010-08-27 | 2010-09-05 | 2461 | 39d | 0d | 89/6/5 | 89/6/14 |
| 2486 | 4.13.16.8 | نصب كابينت طبقه هفتم | 10d | 2010-09-06 | 2010-09-15 | 2462 | 29d | 0d | 89/6/15 | 89/6/24 |
| 2487 | 4.13.16.9 | نصب كابينت طبقه هشتم | 10d | 2010-09-16 | 2010-09-25 | 2463 | 19d | 0d | 89/6/25 | 89/7/3 |
| 2488 | 4.13.16.10 | نصب كابينت طبقه نهم | 10d | 2010-09-26 | 2010-10-05 | 2464 | 9d | 0d | 89/7/4 | 89/7/13 |
| 2489 | 4.13.16.11 | نصب كابينت طبقه دهم | 10d | 2010-10-06 | 2010-10-15 | 2465 | 1d |  | 89/7/14 | 89/7/23 |

| ID | WBS | Task | Duration | Start | Finish | Predecessors | Total slack | Free slack | Plan Start | Plan Finish | Text1 | Text2 | واحد |
| --- | --- | --- | --- | --- | --- | --- | --- | --- | --- | --- | --- | --- | --- |
| 2490 | 4.13.17 | **نصب نرده طبقات** | 105d | 2010-06-28 | 2010-10-10 |  | 6d |  | 89/4/7 | 89/7/18 |  |  |  |
| 2491 | 4.13.17.1 | نصب نرده طبقه همكف | 5d | 2010-06-28 | 2010-07-02 | 2455 | 104d | 5d | 89/4/7 | 89/4/11 |  |  |  |
| 2492 | 4.13.17.2 | نصب نرده طبقه اول | 5d | 2010-07-08 | 2010-07-12 | 2456 | 94d | 5d | 89/4/17 | 89/4/21 |  |  |  |
| 2493 | 4.13.17.3 | نصب نرده طبقه دوم | 5d | 2010-07-18 | 2010-07-22 | 2457 | 84d | 5d | 89/4/27 | 89/4/31 |  |  |  |
| 2494 | 4.13.17.4 | نصب نرده طبقه سوم | 5d | 2010-07-28 | 2010-08-01 | 2458 | 74d | 5d | 89/5/6 | 89/5/10 |  |  |  |
| 2495 | 4.13.17.5 | نصب نرده طبقه چهارم | 5d | 2010-08-07 | 2010-08-11 | 2459 | 64d | 5d | 89/5/16 | 89/5/20 |  |  |  |
| 2496 | 4.13.17.6 | نصب نرده طبقه پنجم | 5d | 2010-08-17 | 2010-08-21 | 2460 | 54d | 5d | 89/5/26 | 89/5/30 |  |  |  |
| 2497 | 4.13.17.7 | نصب نرده طبقه ششم | 5d | 2010-08-27 | 2010-08-31 | 2461 | 44d | 5d | 89/6/5 | 89/6/9 |  |  |  |
| 2498 | 4.13.17.8 | نصب نرده طبقه هفتم | 5d | 2010-09-06 | 2010-09-10 | 2462 | 34d | 5d | 89/6/15 | 89/6/19 |  |  |  |
| 2499 | 4.13.17.9 | نصب نرده طبقه هشتم | 5d | 2010-09-16 | 2010-09-20 | 2463 | 24d | 5d | 89/6/25 | 89/6/29 |  |  |  |
| 2500 | 4.13.17.10 | نصب نرده طبقه نهم | 5d | 2010-09-26 | 2010-09-30 | 2464 | 14d | 5d | 89/7/4 | 89/7/8 |  |  |  |
| 2501 | 4.13.17.11 | نصب نرده طبقه دهم | 5d | 2010-10-06 | 2010-10-10 | 2465 | 6d |  | 89/7/14 | 89/7/18 |  |  |  |
| 2502 | 4.13.18 | **نقاشي** | 119d | 2010-07-08 | 2010-11-03 |  | 0d |  | 89/4/17 | 89/8/12 | 88/02/05 | 88/11/14 | درصد |
| 2503 | 4.13.18.1 | نقاشي طبفه همكف | 18d | 2010-07-08 | 2010-07-25 | 2431, 2467, 2479, 2491, 2517, 2556 | 99d | 0d | 89/4/17 | 89/5/3 | 88/04/03 | 88/04/22 | مترمربع |
| 2504 | 4.13.18.2 | نقاشي طبقه 1 | 18d | 2010-07-18 | 2010-08-04 | 2432, 2468, 2480, 2492, 2518, 2557 | 89d | 0d | 89/4/27 | 89/5/13 | 88/04/23 | 88/05/11 | مترمربع |
| 2505 | 4.13.18.3 | نقاشي طبقه 2 | 18d | 2010-07-28 | 2010-08-14 | 2433, 2469, 2481, 2493, 2558, 2518 | 79d | 0d | 89/5/6 | 89/5/23 | 88/05/12 | 88/05/31 | مترمربع |
| 2506 | 4.13.18.4 | نقاشي طبقه 3 | 18d | 2010-08-07 | 2010-08-24 | 2434, 2470, 2482, 2494, 2559, 2519 | 69d | 0d | 89/5/16 | 89/6/2 | 88/06/01 | 88/06/20 | مترمربع |
| 2507 | 4.13.18.5 | نقاشي طبقه 4 | 18d | 2010-08-17 | 2010-09-03 | 2435, 2471, 2483, 2495, 2560, 2520 | 59d | 0d | 89/5/26 | 89/6/12 | 88/06/21 | 88/07/09 | مترمربع |
| 2508 | 4.13.18.6 | نقاشي طبقه 5 | 18d | 2010-08-27 | 2010-09-13 | 2436, 2472, 2484, 2496, 2561, 2521 | 49d | 0d | 89/6/5 | 89/6/22 | 88/07/10 | 88/07/29 | مترمربع |
| 2509 | 4.13.18.7 | نقاشي طبقه 6 | 18d | 2010-09-06 | 2010-09-23 | 2437, 2473, 2485, 2497, 2522, 2562 | 39d | 0d | 89/6/15 | 89/7/1 | 88/07/30 | 88/08/19 | مترمربع |
| 2510 | 4.13.18.8 | نقاشي طبقه 7 | 18d | 2010-09-16 | 2010-10-03 | 2438, 2474, 2486, 2498, 2523, 2563 | 29d | 0d | 89/6/25 | 89/7/11 | 88/08/20 | 88/09/09 | مترمربع |
| 2511 | 4.13.18.9 | نقاشي طبقه 8 | 18d | 2010-09-26 | 2010-10-13 | 2439, 2475, 2487, 2499, 2524, 2564 | 19d | 0d | 89/7/4 | 89/7/21 | 88/09/10 | 88/09/29 | مترمربع |
| 2512 | 4.13.18.10 | نقاشي طبقه 9 | 18d | 2010-10-06 | 2010-10-23 | 2440, 2476, 2488, 2500, 2525, 2565 | 9d | 0d | 89/7/14 | 89/8/1 | 88/09/30 | 88/10/19 | مترمربع |
| 2513 | 4.13.18.11 | نقاشي طبقه 10 | 18d | 2010-10-17 | 2010-11-03 | 2441, 2477, 2489, 2501, 2526, 2566 | 0d |  | 89/7/25 | 89/8/12 | 88/10/25 | 88/11/14 | مترمربع |

| ID | WBS | Task | Duration | Start | Finish | Predecessors | Total slack | Free slack | Plan Start | Plan Finish | Text1 | Text2 | واحد |
| --- | --- | --- | --- | --- | --- | --- | --- | --- | --- | --- | --- | --- | --- |
| 2514 | 4.14 | **فاز دوم تاسيسات مكانيكي** | 243d | 2010-03-06 | 2010-11-11 |  | 0d |  | 88/12/15 | 89/8/20 |  |  |  |
| 2515 | 4.14.1 | نصب سيستم آتشنشاني در موتورخانه | 10d | 2010-03-06 | 2010-03-15 | 2405 | 233d |  | 88/12/15 | 88/12/24 |  |  |  |
| 2516 | 4.14.2 | **اجراي لوله گاز** | 110d | 2010-06-20 | 2010-10-07 |  | 19d |  | 89/3/30 | 89/7/15 | 87/12/26 | 88/08/19 | درصد |
| 2517 | 4.14.2.1 | لوله كشي گاز طبقه همکف | 10d | 2010-06-20 | 2010-06-29 | 2455SS+2d | 19d | 0d | 89/3/30 | 89/4/8 | 88/01/16 | 88/02/04 | درصد |
| 2518 | 4.14.2.2 | لوله كشي گاز طبقه اول | 10d | 2010-06-30 | 2010-07-09 | 2456SS+2d, 2517 | 19d | 0d | 89/4/9 | 89/4/18 | 88/02/05 | 88/02/24 | درصد |
| 2519 | 4.14.2.3 | لوله كشي گاز طبقه دوم | 10d | 2010-07-10 | 2010-07-19 | 2457SS+2d, 2518 | 19d | 0d | 89/4/19 | 89/4/28 | 88/02/25 | 88/03/13 | درصد |
| 2520 | 4.14.2.4 | لوله كشي گاز طبقه سوم | 10d | 2010-07-20 | 2010-07-29 | 2458SS+2d, 2519 | 19d | 0d | 89/4/29 | 89/5/7 | 88/03/14 | 88/04/02 | درصد |
| 2521 | 4.14.2.5 | لوله كشي گاز طبقه چهارم | 10d | 2010-07-30 | 2010-08-08 | 2459SS+2d, 2520 | 19d | 0d | 89/5/8 | 89/5/17 | 88/04/03 | 88/04/22 | درصد |
| 2522 | 4.14.2.6 | لوله كشي گاز طبقه پنجم | 10d | 2010-08-09 | 2010-08-18 | 2460SS+2d, 2521 | 19d | 0d | 89/5/18 | 89/5/27 | 88/04/23 | 88/05/11 | درصد |
| 2523 | 4.14.2.7 | لوله كشي گاز طبقه ششم | 10d | 2010-08-19 | 2010-08-28 | 2461SS+2d, 2522 | 19d | 0d | 89/5/28 | 89/6/6 | 88/05/12 | 88/05/31 | درصد |
| 2524 | 4.14.2.8 | لوله كشي گاز طبقه هفتم | 10d | 2010-08-29 | 2010-09-07 | 2462SS+2d, 2523 | 19d | 0d | 89/6/7 | 89/6/16 | 88/06/01 | 88/06/20 | درصد |
| 2525 | 4.14.2.9 | لوله كشي گاز طبقه هشتم | 10d | 2010-09-08 | 2010-09-17 | 2463SS+2d, 2524 | 19d | 0d | 89/6/17 | 89/6/26 | 88/06/21 | 88/07/09 | درصد |
| 2526 | 4.14.2.10 | لوله كشي گاز طبقه نهم | 10d | 2010-09-18 | 2010-09-27 | 2464SS+2d, 2525 | 19d | 0d | 89/6/27 | 89/7/5 | 88/07/10 | 88/07/29 | درصد |
| 2527 | 4.14.2.11 | لوله كشي گاز طبقه 10 و بام | 10d | 2010-09-28 | 2010-10-07 | 2465SS+2d, 2526 | 35d |  | 89/7/6 | 89/7/15 | 88/07/30 | 88/08/19 | درصد |
| 2528 | 4.14.3 | **نصب شيرآلات و رادياتورهاي طبقات** | 109d | 2010-07-26 | 2010-11-11 |  | 0d |  | 89/5/4 | 89/8/20 |  |  |  |
| 2529 | 4.14.3.1 | نصب شيرآلات و رادياتورهاي طبقه همكف | 8d | 2010-07-26 | 2010-08-02 | 2503 | 101d |  | 89/5/4 | 89/5/11 |  |  |  |
| 2530 | 4.14.3.2 | نصب شيرآلات و رادياتورهاي طبقه اول | 8d | 2010-08-05 | 2010-08-12 | 2504 | 91d |  | 89/5/14 | 89/5/21 |  |  |  |
| 2531 | 4.14.3.3 | نصب شيرآلات و رادياتورهاي طبقه دوم | 8d | 2010-08-15 | 2010-08-22 | 2505 | 81d |  | 89/5/24 | 89/5/31 |  |  |  |
| 2532 | 4.14.3.4 | نصب شيرآلات و رادياتورهاي طبقه سوم | 8d | 2010-08-25 | 2010-09-01 | 2506 | 71d |  | 89/6/3 | 89/6/10 |  |  |  |
| 2533 | 4.14.3.5 | نصب شيرآلات و رادياتورهاي طبقه چهارم | 8d | 2010-09-04 | 2010-09-11 | 2507 | 61d |  | 89/6/13 | 89/6/20 |  |  |  |
| 2534 | 4.14.3.6 | نصب شيرآلات و رادياتورهاي طبقه پنجم | 8d | 2010-09-14 | 2010-09-21 | 2508 | 51d |  | 89/6/23 | 89/6/30 |  |  |  |
| 2535 | 4.14.3.7 | نصب شيرآلات و رادياتورهاي طبقه ششم | 8d | 2010-09-24 | 2010-10-01 | 2509 | 41d |  | 89/7/2 | 89/7/9 |  |  |  |
| 2536 | 4.14.3.8 | نصب شيرآلات و رادياتورهاي طبقه هفتم | 8d | 2010-10-04 | 2010-10-11 | 2510 | 31d |  | 89/7/12 | 89/7/19 |  |  |  |
| 2537 | 4.14.3.9 | نصب شيرآلات و رادياتورهاي طبقه هشتم | 8d | 2010-10-14 | 2010-10-21 | 2511 | 21d |  | 89/7/22 | 89/7/29 |  |  |  |
| 2538 | 4.14.3.10 | نصب شيرآلات و رادياتورهاي طبقه نهم | 8d | 2010-10-24 | 2010-10-31 | 2512 | 11d |  | 89/8/2 | 89/8/9 |  |  |  |
| 2539 | 4.14.3.11 | نصب شيرآلات و رادياتورهاي طبقه دهم | 8d | 2010-11-04 | 2010-11-11 | 2513 | 0d |  | 89/8/13 | 89/8/20 |  |  |  |

| ID | WBS | Task | Duration | Start | Finish | Predecessors | Total slack | Free slack | Plan Start | Plan Finish |
| --- | --- | --- | --- | --- | --- | --- | --- | --- | --- | --- |
| 2540 | 4.14.4 | **نصب پكيج هاي طبقات** | 109d | 2010-07-26 | 2010-11-11 |  | 0d |  | 89/5/4 | 89/8/20 |
| 2541 | 4.14.4.1 | نصب پكيج هاي طبقه همكف | 10d | 2010-07-26 | 2010-08-04 | 2503 | 99d |  | 89/5/4 | 89/5/13 |
| 2542 | 4.14.4.2 | نصب پكيج هاي طبقه اول | 10d | 2010-08-05 | 2010-08-14 | 2504 | 89d |  | 89/5/14 | 89/5/23 |
| 2543 | 4.14.4.3 | نصب پكيج هاي طبقه دوم | 10d | 2010-08-15 | 2010-08-24 | 2505 | 79d |  | 89/5/24 | 89/6/2 |
| 2544 | 4.14.4.4 | نصب پكيج هاي طبقه سوم | 10d | 2010-08-25 | 2010-09-03 | 2506 | 69d |  | 89/6/3 | 89/6/12 |
| 2545 | 4.14.4.5 | نصب پكيج هاي طبقه چهارم | 10d | 2010-09-04 | 2010-09-13 | 2507 | 59d |  | 89/6/13 | 89/6/22 |
| 2546 | 4.14.4.6 | نصب پكيج هاي طبقه پنجم | 10d | 2010-09-14 | 2010-09-23 | 2508 | 49d |  | 89/6/23 | 89/7/1 |
| 2547 | 4.14.4.7 | نصب پكيج هاي طبقه ششم | 10d | 2010-09-24 | 2010-10-03 | 2509 | 39d |  | 89/7/2 | 89/7/11 |
| 2548 | 4.14.4.8 | نصب پكيج هاي طبقه هفتم | 10d | 2010-10-04 | 2010-10-13 | 2510 | 29d |  | 89/7/12 | 89/7/21 |
| 2549 | 4.14.4.9 | نصب پكيج هاي طبقه هشتم | 10d | 2010-10-14 | 2010-10-23 | 2511 | 19d |  | 89/7/22 | 89/8/1 |
| 2550 | 4.14.4.10 | نصب پكيج هاي طبقه نهم | 10d | 2010-10-24 | 2010-11-02 | 2512 | 9d |  | 89/8/2 | 89/8/11 |
| 2551 | 4.14.4.11 | نصب پكيج هاي طبقه دهم | 8d | 2010-11-04 | 2010-11-11 | 2513 | 0d |  | 89/8/13 | 89/8/20 |
| 2552 | 4.15 | **فاز دوم تاسيسات برقي** | 177d | 2010-05-19 | 2010-11-11 |  | 0d |  | 89/2/29 | 89/8/20 |
| 2553 | 4.15.1 | **سيم كشي طبقات** | 171d | 2010-05-19 | 2010-11-05 |  | 0d |  | 89/2/29 | 89/8/14 |
| 2554 | 4.15.1.1 | سيم كشي زيرزمين دوم | 10d | 2010-10-27 | 2010-11-05 | 2555 | 0d |  | 89/8/5 | 89/8/14 |
| 2555 | 4.15.1.2 | سيم كشي زيرزمين اول | 10d | 2010-10-17 | 2010-10-26 | 2566 | 0d |  | 89/7/25 | 89/8/4 |
| 2556 | 4.15.1.3 | سيم كشي طبقه همكف | 10d | 2010-05-19 | 2010-05-28 | 2367 | 41d | 0d | 89/2/29 | 89/3/7 |
| 2557 | 4.15.1.4 | سيم كشي طبقه اول | 10d | 2010-05-29 | 2010-06-07 | 2368, 2556 | 41d | 0d | 89/3/8 | 89/3/17 |
| 2558 | 4.15.1.5 | سيم كشي طبقه دوم | 10d | 2010-06-08 | 2010-06-17 | 2369, 2557 | 41d | 4d | 89/3/18 | 89/3/27 |
| 2559 | 4.15.1.6 | سيم كشي طبقه سوم | 10d | 2010-06-22 | 2010-07-01 | 2370, 2558 | 37d | 5d | 89/4/1 | 89/4/10 |
| 2560 | 4.15.1.7 | سيم كشي طبقه چهارم | 10d | 2010-07-07 | 2010-07-16 | 2371, 2559 | 32d | 5d | 89/4/16 | 89/4/25 |
| 2561 | 4.15.1.8 | سيم كشي طبقه پنجم | 10d | 2010-07-22 | 2010-07-31 | 2372, 2560 | 27d | 5d | 89/4/31 | 89/5/9 |
| 2562 | 4.15.1.9 | سيم كشي طبقه ششم | 10d | 2010-08-06 | 2010-08-15 | 2373, 2561 | 22d | 5d | 89/5/15 | 89/5/24 |
| 2563 | 4.15.1.10 | سيم كشي طبقه هفتم | 10d | 2010-08-21 | 2010-08-30 | 2374, 2562 | 17d | 5d | 89/5/30 | 89/6/8 |
| 2564 | 4.15.1.11 | سيم كشي طبقه هشتم | 10d | 2010-09-05 | 2010-09-14 | 2375, 2563 | 12d | 5d | 89/6/14 | 89/6/23 |
| 2565 | 4.15.1.12 | سيم كشي طبقه نهم | 10d | 2010-09-20 | 2010-09-29 | 2376, 2564 | 7d | 6d | 89/6/29 | 89/7/7 |
| 2566 | 4.15.1.13 | سيم كشي طبقه دهم و خرپشته | 10d | 2010-10-07 | 2010-10-16 | 2377, 2565 | 0d |  | 89/7/15 | 89/7/24 |

| ID | WBS | Task | Duration | Start | Finish | Predecessors | Total slack | Plan Start | Plan Finish |
| --- | --- | --- | --- | --- | --- | --- | --- | --- | --- |
| 2567 | 4.15.2 | **نصب كليد و پريز لوازم برقي و هواكش** | 109d | 2010-07-26 | 2010-11-11 |  | 0d | 89/5/4 | 89/8/20 |
| 2568 | 4.15.2.1 | نصب كليد و پريز لوازم برقي و هواكش زيرزمين دوم | 6d | 2010-11-06 | 2010-11-11 | 2554 | 0d | 89/8/15 | 89/8/20 |
| 2569 | 4.15.2.2 | نصب كليد و پريز لوازم برقي و هواكش زيرزمين اول | 10d | 2010-10-27 | 2010-11-05 | 2555 | 6d | 89/8/5 | 89/8/14 |
| 2570 | 4.15.2.3 | نصب كليد و پريز لوازم برقي و هواكش طبقه همكف | 10d | 2010-07-26 | 2010-08-04 | 2503 | 99d | 89/5/4 | 89/5/13 |
| 2571 | 4.15.2.4 | نصب كليد و پريز لوازم برقي و هواكش طبقه اول | 10d | 2010-08-05 | 2010-08-14 | 2504 | 89d | 89/5/14 | 89/5/23 |
| 2572 | 4.15.2.5 | نصب كليد و پريز لوازم برقي و هواكش طبقه دوم | 10d | 2010-08-15 | 2010-08-24 | 2505 | 79d | 89/5/24 | 89/6/2 |
| 2573 | 4.15.2.6 | نصب كليد و پريز لوازم برقي و هواكش طبقه سوم | 10d | 2010-08-25 | 2010-09-03 | 2506 | 69d | 89/6/3 | 89/6/12 |
| 2574 | 4.15.2.7 | نصب كليد و پريز لوازم برقي و هواكش طبقه چهارم | 10d | 2010-09-04 | 2010-09-13 | 2507 | 59d | 89/6/13 | 89/6/22 |
| 2575 | 4.15.2.8 | نصب كليد و پريز لوازم برقي و هواكش طبقه پنجم | 10d | 2010-09-14 | 2010-09-23 | 2508 | 49d | 89/6/23 | 89/7/1 |
| 2576 | 4.15.2.9 | نصب كليد و پريز لوازم برقي و هواكش طبقه ششم | 10d | 2010-09-24 | 2010-10-03 | 2509 | 39d | 89/7/2 | 89/7/11 |
| 2577 | 4.15.2.10 | نصب كليد و پريز لوازم برقي و هواكش طبقه هفتم | 10d | 2010-10-04 | 2010-10-13 | 2510 | 29d | 89/7/12 | 89/7/21 |
| 2578 | 4.15.2.11 | نصب كليد و پريز لوازم برقي و هواكش طبقه هشتم | 10d | 2010-10-14 | 2010-10-23 | 2511 | 19d | 89/7/22 | 89/8/1 |
| 2579 | 4.15.2.12 | نصب كليد و پريز لوازم برقي و هواكش طبقه نهم | 10d | 2010-10-24 | 2010-11-02 | 2512 | 9d | 89/8/2 | 89/8/11 |
| 2580 | 4.15.2.13 | نصب كليد و پريز لوازم برقي و هواكش طبقه دهم | 6d | 2010-11-04 | 2010-11-09 | 2513 | 2d | 89/8/13 | 89/8/18 |
| 2581 | 4.15.3 | **ساخت و نصب تابلوهاي برقي** | 109d | 2010-07-26 | 2010-11-11 |  | 0d | 89/5/4 | 89/8/20 |
| 2582 | 4.15.3.1 | ساخت و نصب تابلوهاي برقي زيرزمين دوم | 6d | 2010-11-06 | 2010-11-11 | 2554 | 0d | 89/8/15 | 89/8/20 |
| 2583 | 4.15.3.2 | ساخت و نصب تابلوهاي برقي زيرزمين اول | 10d | 2010-10-27 | 2010-11-05 | 2555 | 6d | 89/8/5 | 89/8/14 |
| 2584 | 4.15.3.3 | ساخت و نصب تابلوهاي برقي طبقه همكف | 10d | 2010-07-26 | 2010-08-04 | 2503 | 99d | 89/5/4 | 89/5/13 |
| 2585 | 4.15.3.4 | ساخت و نصب تابلوهاي برقي طبقه اول | 10d | 2010-08-05 | 2010-08-14 | 2504 | 89d | 89/5/14 | 89/5/23 |
| 2586 | 4.15.3.5 | ساخت و نصب تابلوهاي برقي طبقه دوم | 10d | 2010-08-15 | 2010-08-24 | 2505 | 79d | 89/5/24 | 89/6/2 |
| 2587 | 4.15.3.6 | ساخت و نصب تابلوهاي برقي طبقه سوم | 10d | 2010-08-25 | 2010-09-03 | 2506 | 69d | 89/6/3 | 89/6/12 |
| 2588 | 4.15.3.7 | ساخت و نصب تابلوهاي برقي طبقه چهارم | 10d | 2010-09-04 | 2010-09-13 | 2507 | 59d | 89/6/13 | 89/6/22 |
| 2589 | 4.15.3.8 | ساخت و نصب تابلوهاي برقي طبقه پنجم | 10d | 2010-09-14 | 2010-09-23 | 2508 | 49d | 89/6/23 | 89/7/1 |
| 2590 | 4.15.3.9 | ساخت و نصب تابلوهاي برقي طبقه ششم | 10d | 2010-09-24 | 2010-10-03 | 2509 | 39d | 89/7/2 | 89/7/11 |
| 2591 | 4.15.3.10 | ساخت و نصب تابلوهاي برقي طبقه هفتم | 10d | 2010-10-04 | 2010-10-13 | 2510 | 29d | 89/7/12 | 89/7/21 |
| 2592 | 4.15.3.11 | ساخت و نصب تابلوهاي برقي طبقه هشتم | 10d | 2010-10-14 | 2010-10-23 | 2511 | 19d | 89/7/22 | 89/8/1 |
| 2593 | 4.15.3.12 | ساخت و نصب تابلوهاي برقي طبقه نهم | 10d | 2010-10-24 | 2010-11-02 | 2512 | 9d | 89/8/2 | 89/8/11 |
| 2594 | 4.15.3.13 | ساخت و نصب تابلوهاي برقي طبقه دهم | 8d | 2010-11-04 | 2010-11-11 | 2513 | 0d | 89/8/13 | 89/8/20 |

| ID | WBS | Task | Type | Duration | Start | Finish | Predecessors | Total slack | Free slack | Plan Start | Plan Finish |
| --- | --- | --- | --- | --- | --- | --- | --- | --- | --- | --- | --- |
| 2595 | 4.15.4 | **نصب و راه اندازي سيستم اعلام حريق و درب بازكن** |  | 109d | 2010-07-26 | 2010-11-11 |  | 0d |  | 89/5/4 | 89/8/20 |
| 2596 | 4.15.4.1 | نصب و راه اندازي سيستم اعلام حريق و درب بازكن زيرزمين دوم |  | 6d | 2010-11-06 | 2010-11-11 | 2554 | 0d |  | 89/8/15 | 89/8/20 |
| 2597 | 4.15.4.2 | نصب و راه اندازي سيستم اعلام حريق و درب بازكن زيرزمين اول |  | 10d | 2010-10-27 | 2010-11-05 | 2555 | 6d |  | 89/8/5 | 89/8/14 |
| 2598 | 4.15.4.3 | نصب و راه اندازي سيستم اعلام حريق و درب بازكن طبقه همكف |  | 10d | 2010-07-26 | 2010-08-04 | 2503 | 99d |  | 89/5/4 | 89/5/13 |
| 2599 | 4.15.4.4 | نصب و راه اندازي سيستم اعلام حريق و درب بازكن طبقه اول |  | 10d | 2010-08-05 | 2010-08-14 | 2504 | 89d |  | 89/5/14 | 89/5/23 |
| 2600 | 4.15.4.5 | نصب و راه اندازي سيستم اعلام حريق و درب بازكن طبقه دوم |  | 10d | 2010-08-15 | 2010-08-24 | 2505 | 79d |  | 89/5/24 | 89/6/2 |
| 2601 | 4.15.4.6 | نصب و راه اندازي سيستم اعلام حريق و درب بازكن طبقه سوم |  | 10d | 2010-08-25 | 2010-09-03 | 2506 | 69d |  | 89/6/3 | 89/6/12 |
| 2602 | 4.15.4.7 | نصب و راه اندازي سيستم اعلام حريق و درب بازكن طبقه چهارم |  | 10d | 2010-09-04 | 2010-09-13 | 2507 | 59d |  | 89/6/13 | 89/6/22 |
| 2603 | 4.15.4.8 | نصب و راه اندازي سيستم اعلام حريق و درب بازكن طبقه پنجم |  | 10d | 2010-09-14 | 2010-09-23 | 2508 | 49d |  | 89/6/23 | 89/7/1 |
| 2604 | 4.15.4.9 | نصب و راه اندازي سيستم اعلام حريق و درب بازكن طبقه ششم |  | 10d | 2010-09-24 | 2010-10-03 | 2509 | 39d |  | 89/7/2 | 89/7/11 |
| 2605 | 4.15.4.10 | نصب و راه اندازي سيستم اعلام حريق و درب بازكن طبقه هفتم |  | 10d | 2010-10-04 | 2010-10-13 | 2510 | 29d |  | 89/7/12 | 89/7/21 |
| 2606 | 4.15.4.11 | نصب و راه اندازي سيستم اعلام حريق و درب بازكن طبقه هشتم |  | 10d | 2010-10-14 | 2010-10-23 | 2511 | 19d |  | 89/7/22 | 89/8/1 |
| 2607 | 4.15.4.12 | نصب و راه اندازي سيستم اعلام حريق و درب بازكن طبقه نهم |  | 10d | 2010-10-24 | 2010-11-02 | 2512 | 9d |  | 89/8/2 | 89/8/11 |
| 2608 | 4.15.4.13 | نصب و راه اندازي سيستم اعلام حريق و درب بازكن طبقه دهم |  | 8d | 2010-11-04 | 2010-11-11 | 2513 | 0d |  | 89/8/13 | 89/8/20 |
| 2609 | 4.16 | **نصب و راه اندازي آسانسور و ژنراتور** |  | 70d | 2010-09-01 | 2010-11-09 |  | 0d |  | 89/6/10 | 89/8/18 |
| 2610 | 4.16.1 | آهن كشي آسانسور |  | 20d | 2010-09-01 | 2010-09-20 | 2611FF-20d | 50d |  | 89/6/10 | 89/6/29 |
| 2611 | 4.16.2 | نصب درب و ريل |  | 20d | 2010-09-21 | 2010-10-10 | 2477FF | 0d |  | 89/6/30 | 89/7/18 |
| 2612 | 4.16.3 | نصب و راه اندازي كامل آسانسور |  | 20d | 2010-10-11 | 2010-10-30 | 2611 | 0d |  | 89/7/19 | 89/8/8 |
| 2613 | 4.16.4 | نصب و راه اندازي ژنراتور |  | 10d | 2010-10-31 | 2010-11-09 | 2612 | 0d |  | 89/8/9 | 89/8/18 |
| 2614 | 4.17 | **محوطه سازي** |  | 215d | 2010-03-04 | 2010-10-12 |  | 30d |  | 88/12/13 | 89/7/20 |
| 2615 | 4.17.1 | ديواركشي پيرامون |  | 40d | 2010-05-11 | 2010-06-19 | 2616FF-70d | 145d | 0d | 89/2/21 | 89/3/29 |
| 2616 | 4.17.2 | محوطه سازي مجتمع |  | 60d | 2010-06-30 | 2010-08-28 | 2617FF-45d | 75d | 0d | 89/4/9 | 89/6/6 |
| 2617 | 4.17.3 | اجراي تاسيسات محوطه |  | 35d | 2010-09-08 | 2010-10-12 | 2619FF-30d | 30d | 0d | 89/6/17 | 89/7/20 |
| 2618 | 4.17.4 | اجرا ساختمان نگهباني و سردرب |  | 50d | 2010-03-04 | 2010-04-30 | 2615FF-50d | 195d |  | 88/12/13 | 89/2/10 |
| 2619 | 4.18 | برچيدن كارگاه بلوك 1 |  | 10d | 2010-11-02 | 2010-11-11 | 2609FS-8d | 0d |  | 89/8/11 | 89/8/20 |
| 2620 | 4.19 | اتمام بلوك 1 | milestone | 0d | 2010-11-11 | 2010-11-11 | 2619 | 0d |  | 89/8/20 | 89/8/20 |
| 2621 | 5 | اتمام 4 بلوك 320 واحدي شهريار | milestone | 0d | 2010-11-11 | 2010-11-11 | 655 | 0d |  | 89/8/20 | 89/8/20 |
